# IMPACT Master Schedule

Schedule from MS Project, 2003-02-26 to 2005-11-21, status date 2004-02-29, A marks actual dates.
IMPACT Instrument Suites
NASA GSFC - STEREO
This is the IMPACT Consolidated Schedule. Creation began in October 2003 and was then put on hold and subsequently completed in January 2004. Completed tasks, redundant milestones, contingency blocks and obsolete tasks were deleted from this schedule. / Schedule was baselined on 2/18/04 with status through January 31, 2004. / Maintenance of this Schedule was transferred from Jim Rodgers to Tabitha Merchant on 03/22/04

## Calendars

- Standard: Mon-Fri 08:00-12:00, 13:00-17:00; Sat-Sun off. Exceptions (off unless hours are given): 2003-05-26, 2003-07-04, 2003-09-01, 2003-10-13, 2003-11-11, 2003-11-27, 2003-12-25, 2004-01-01, 2004-01-19, 2004-02-16, 2004-05-31, 2004-09-06, 2004-10-11, 2004-11-11, 2004-11-25.
- Boom Test Calendar: Mon-Fri 08:00-12:00, 13:00-17:00; Sat-Sun off. Exceptions (off unless hours are given): 2003-05-26, 2003-07-04, 2003-09-01, 2003-10-13, 2003-11-11, 2003-11-27, 2003-12-25, 2004-01-01, 2004-01-19, 2004-02-16, 2004-02-28 to 2004-02-29 08:00-12:00, 13:00-17:00, 2004-03-06 to 2004-03-07 08:00-12:00, 13:00-17:00, 2004-05-31, 2004-09-06, 2004-10-11, 2004-11-11, 2004-11-25.

## Schedule

| ID | WBS | Task | Type | Duration | Start | Finish | Predecessors | Complete | Remaining | Baseline start | Baseline finish | Baseline duration | Total slack | Free slack | Constraint | Text1 |
| --- | --- | --- | --- | --- | --- | --- | --- | --- | --- | --- | --- | --- | --- | --- | --- | --- |
| 1 | 1 | **IMPACT - Dave Curtis (UCB) & Lil Reichenthal (GSFC)** |  | 699d | 2003-02-26 A | 2005-11-21 |  | 60% | 277.89d | 2003-02-26 | 2005-11-18 | 698d | 0d |  |  |  |
| 2 | 1.1 | **Suite Deliveries to APL** |  | 25d | 2004-09-21 | 2004-10-28 |  |  |  | 2004-08-13 | 2004-10-28 | 51d | 0d |  |  |  |
| 3 | 1.1.1 | FM 1 Target Delivery Date | milestone | 0d | 2004-10-07 | 2004-10-07 | 5, 7 |  |  | 2004-10-07 | 2004-10-07 | 0d | -6d | 0d | must start on 2004-10-07 | MS-BOOM |
| 4 | 1.1.2 | FM 1 Target Delivery Date | milestone | 0d | 2004-10-28 | 2004-10-28 | 8, 6 |  |  | 2004-10-28 | 2004-10-28 | 0d | 0d |  | must start on 2004-10-28 | MS-BOOM |
| 5 | 1.1.3 | Boom Suite FM 1 Ready for Delivery to APL | milestone | 0d | 2004-09-21 | 2004-09-21 | 351 |  |  | 2004-08-13 | 2004-08-13 | 0d | 11d |  |  | MS-BOOM |
| 6 | 1.1.4 | Boom Suite FM 2 Ready for Delivery to APL | milestone | 0d | 2004-10-06 | 2004-10-06 | 357 |  |  | 2004-09-28 | 2004-09-28 | 0d | 14d |  |  | MS-BOOM |
| 7 | 1.1.5 | SEP Suite FM 1 Ready for Delivery to APL | milestone | 0d | 2004-10-15 | 2004-10-15 | 775, 590, 526 |  |  | 2004-09-14 | 2004-09-14 | 0d | -6d | 0d |  | MS-SEP |
| 8 | 1.1.6 | SEP Suite FM 2 Ready for Delivery to APL | milestone | 0d | 2004-10-22 | 2004-10-22 | 782, 593 |  |  | 2004-10-12 | 2004-10-12 | 0d | 3d |  |  | MS-SEP |
| 9 | 1.2 | **Environmental Testing - PER, Impact Suite EMC, Snapshots of Boom & SEP Suite Test Flows** |  | 194d | 2004-01-14 A | 2004-10-18 |  | 3% | 188.21d | 2004-01-14 | 2004-10-05 | 186d | 283d |  |  |  |
| 10 | 1.2.1 | **Reviews (PER and TRR's) - TRR Dates are Tentative** |  | 151d | 2004-01-14 A | 2004-08-16 |  | 25% | 113.25d | 2004-01-14 | 2004-07-08 | 124d | 326d |  |  |  |
| 11 | 1.2.1.1 | Instrument PER at UCB |  | 1d | 2004-01-14 A | 2004-01-14 A |  | 100% |  | 2004-01-14 | 2004-01-14 | 1d |  |  | start no earlier than 2004-01-14 |  |
| 12 | 1.2.1.2 | TRR 1 - Prior to FM 1 SEPT Thermal Vac |  | 1d | 2004-02-13 A | 2004-02-13 A | 39SS-6d | 100% |  | 2004-02-13 | 2004-02-13 | 1d |  |  |  |  |
| 13 | 1.2.1.3 | TRR 2 - Prior to FM 1 STE-U Thermal Vac/Thermal Balance |  | 1d | 2004-04-19 | 2004-04-19 | 21SS |  |  | 2004-03-25 | 2004-03-25 | 1d | 410d |  | start no earlier than 2004-04-19 |  |
| 14 | 1.2.1.4 | TRR 3 - Prior to FM 1 Boom Structure Vibration |  | 1d | 2004-04-19 | 2004-04-19 | 22SS-9d |  |  | 2004-04-20 | 2004-04-20 | 1d | 410d |  |  |  |
| 15 | 1.2.1.5 | TRR 4 - Prior to FM 1 IDPU Vibration |  | 1d | 2004-05-18 | 2004-05-18 | 23SS-5d |  |  | 2004-04-26 | 2004-04-26 | 1d | 389d |  |  |  |
| 16 | 1.2.1.6 | TRR 5 - Prior to FM 1 SWEA Vibration |  | 1d | 2004-06-08 | 2004-06-08 | 26SS-5d |  |  | 2004-05-28 | 2004-05-28 | 1d | 375d |  |  |  |
| 17 | 1.2.1.7 | TRR 6 - Prior to FM 1 Impact Suite EMC (for Boom and SEP) |  | 1d | 2004-07-28 | 2004-07-28 | 19SS-5d |  |  | 2004-06-22 | 2004-06-22 | 1d | 339d |  |  |  |
| 18 | 1.2.1.8 | TRR 7 - Prior to FM 1 SIT Vibration |  | 1d | 2004-08-16 | 2004-08-16 | 43SS-5d |  |  | 2004-07-08 | 2004-07-08 | 1d | 326d |  |  |  |
| 19 | 1.2.2 | IMPACT Suite FM 1 EMC Testing at UCB |  | 10d | 2004-08-04 | 2004-08-17 | 350, 753, 422 |  |  | 2004-06-29 | 2004-07-12 | 10d | -13d | 0d |  | MS-BOOM |
| 20 | 1.2.3 | **Boom Suite FM 1 Environmental Test Flow Snapshot - UCB** |  | 110d | 2004-04-05 | 2004-09-07 |  |  |  | 2004-04-01 | 2004-07-30 | 86d | 311d |  |  |  |
| 21 | 1.2.3.1 | STE-U Thermal Vac/Thermal Balance/Bake Out |  | 14d | 2004-04-05 | 2004-04-22 | 270SS |  |  | 2004-04-01 | 2004-04-20 | 14d | 407d | 10d |  |  |
| 22 | 1.2.3.2 | Boom Structure Vibration |  | 4d | 2004-04-30 | 2004-05-05 | 210SS |  |  | 2004-04-27 | 2004-04-30 | 4d | 398d | 0d |  |  |
| 23 | 1.2.3.3 | IDPU Vibration |  | 5d | 2004-05-25 | 2004-06-01 | 173SS |  |  | 2004-05-03 | 2004-05-07 | 5d | 380d | 0d |  |  |
| 24 | 1.2.3.4 | Boom Structure Thermal Vac & Bake Out |  | 15d | 2004-05-06 | 2004-05-26 | 211SS |  |  | 2004-05-03 | 2004-05-21 | 15d | 383d |  |  |  |
| 25 | 1.2.3.5 | IDPU Thermal Vac & Bake Out |  | 10d | 2004-06-02 | 2004-06-15 | 174SS |  |  | 2004-05-10 | 2004-05-21 | 10d | 370d |  |  |  |
| 26 | 1.2.3.6 | SWEA/STE Vibration |  | 5d | 2004-06-15 | 2004-06-21 | 336SS |  |  | 2004-06-07 | 2004-06-11 | 5d | 366d | 0d |  |  |
| 27 | 1.2.3.7 | SWEA/STE Thermal Vac/Thermal Balance/Bake Out |  | 14d | 2004-08-18 | 2004-09-07 | 337SS |  |  | 2004-07-13 | 2004-07-30 | 14d | 311d |  |  |  |

Notes:
- 1: This is the new IMPACT Consolidated Schedule. Creation began in October 2003 and was then put on hold and subsequently completed in January 2004. Completed tasks, redundant milestones, contingency blocks and obsolete tasks were deleted from this schedule. / Schedule was baselined on 2/18/04 with status through January 31, 2004.
- 7: The SEPT (FM 1) and SIT (FM 1 & 2) instruments are being delivered directly to APL after their environmental testing at GSFC and seperate from the other SEP Suite instruments (SEP Central, LET and HET).
- 8: The SEPT (FM 1) and SIT (FM 1 & 2) instruments are being delivered directly to APL after their environmental testing at GSFC and seperate from the other SEP Suite instruments (SEP Central, LET and HET).
- 11: This is the initial IMPACT PER. Additional TRR's (Test Readiness Reviews) will be scheduled and held as the suite instruments become ready for their environmental testing.
- 20: This section is a "snapshot" of the environmental test flow for the FM 1 Boom Suite. It reflects the details of the testing activities found within the body of the schedule. It was placed in the schedule to allow someone to get a quick look at the test flow and the associated dates. The tasks contained within this section are not tied to any other activities (and do not drive any other activities) and so therefore you will see large float values associated with them. It is simply a quick look at the test flow so that one does not have to filter through the schedule to locate the environmental test activities.

| ID | WBS | Task | Duration | Start | Finish | Predecessors | Complete | Remaining | Baseline start | Baseline finish | Baseline duration | Total slack | Free slack |
| --- | --- | --- | --- | --- | --- | --- | --- | --- | --- | --- | --- | --- | --- |
| 28 | 1.2.4 | **Boom Suite FM 2 Environmental Test Flow Snapshot - UCB** | 83d | 2004-05-27 | 2004-09-22 |  |  |  | 2004-04-27 | 2004-09-14 | 99d | 300d |  |
| 29 | 1.2.4.1 | STE-U Thermal Vac/Bake Out | 10d | 2004-05-27 | 2004-06-10 | 278SS |  |  | 2004-04-27 | 2004-05-10 | 10d | 373d |  |
| 30 | 1.2.4.2 | IDPU Vibration | 5d | 2004-07-07 | 2004-07-13 | 177SS |  |  | 2004-05-10 | 2004-05-14 | 5d | 350d |  |
| 31 | 1.2.4.3 | Boom Structure Vibration | 4d | 2004-06-17 | 2004-06-22 | 232SS |  |  | 2004-05-17 | 2004-05-20 | 4d | 365d |  |
| 32 | 1.2.4.4 | IDPU Thermal Vac & Bake Out | 10d | 2004-07-14 | 2004-07-27 | 178SS |  |  | 2004-05-17 | 2004-05-28 | 10d | 340d |  |
| 33 | 1.2.4.5 | Boom Structure Thermal Vac & Bake Out | 15d | 2004-06-23 | 2004-07-13 | 233SS |  |  | 2004-05-24 | 2004-06-14 | 15d | 350d |  |
| 34 | 1.2.4.6 | SWEA/STE Vibration | 5d | 2004-08-17 | 2004-08-23 | 344SS |  |  | 2004-08-09 | 2004-08-13 | 5d | 321d |  |
| 35 | 1.2.4.7 | SWEA/STE Thermal Vac & Bake Out | 10d | 2004-08-24 | 2004-09-07 | 345SS |  |  | 2004-08-16 | 2004-08-27 | 10d | 311d |  |
| 36 | 1.2.4.8 | Boom Suite FM 2 EMC | 5d | 2004-09-16 | 2004-09-22 | 356SS |  |  | 2004-09-08 | 2004-09-14 | 5d | 300d |  |
| 37 | 1.2.5 | **SEP Suite FM 1 Environmental Test Flow Snapshot** | 169d | 2004-02-19 A | 2004-10-15 |  | 4% | 162.1d | 2004-02-17 | 2004-09-14 | 149d | 284d |  |
| 38 | 1.2.5.1 | SEPT (NS & E) Vibration (in Europe) | 4d | 2004-02-19 A | 2004-02-24 A | 562SS | 100% |  | 2004-02-17 | 2004-02-24 | 8d |  |  |
| 39 | 1.2.5.2 | SEPT (NS & E) Thermal Vac (in Europe) | 10d | 2004-02-27 | 2004-03-11 | 563SS, 570SS |  |  | 2004-02-25 | 2004-03-08 | 9d | 437d | 0d |
| 40 | 1.2.5.3 | SEPT (NS & E) Bake Out (in Europe) | 2d | 2004-03-05 | 2004-03-08 | 564SS, 571SS |  |  | 2004-03-09 | 2004-03-10 | 2d | 440d |  |
| 41 | 1.2.5.4 | SEPT (NS & E) Thermal Balance (at GSFC) | 10d | 2004-08-18 | 2004-08-31 | 565SS, 572SS |  |  | 2004-07-13 | 2004-07-26 | 10d | 315d |  |
| 42 | 1.2.5.5 | LET/HET/SEP Cen Accelerator Test (at MSU) | 11d | 2004-08-18 | 2004-09-01 | 784SS |  |  | 2004-07-13 | 2004-07-27 | 11d | 314d |  |
| 43 | 1.2.5.6 | SIT Vibe and Acoustics (at GSFC) | 10d | 2004-08-23 | 2004-09-03 | 708SS |  |  | 2004-07-15 | 2004-07-28 | 10d | 312d | 0d |
| 44 | 1.2.5.7 | LET/HET/SEP Cen Vibe and Acoustics (at JPL) | 10d | 2004-08-30 | 2004-09-13 | 770SS |  |  | 2004-07-23 | 2004-08-05 | 10d | 307d |  |
| 45 | 1.2.5.8 | SIT Thermal Balance (at GSFC) | 5d | 2004-09-08 | 2004-09-14 | 710SS |  |  | 2004-07-30 | 2004-08-05 | 5d | 306d |  |
| 46 | 1.2.5.9 | LET/HET/SEP Cen Thermal Balance (at JPL) | 5d | 2004-09-14 | 2004-09-20 | 771SS |  |  | 2004-08-06 | 2004-08-12 | 5d | 302d |  |
| 47 | 1.2.5.10 | SIT Thermal Vac (at GSFC) | 10d | 2004-09-15 | 2004-09-28 | 711SS |  |  | 2004-08-06 | 2004-08-19 | 10d | 296d |  |
| 48 | 1.2.5.11 | LET/HET/SEP Cen Thermal Vac (at JPL) | 15d | 2004-09-21 | 2004-10-12 | 772SS |  |  | 2004-08-19 | 2004-09-09 | 15d | 287d |  |
| 49 | 1.2.5.12 | SIT Bake Out (at GSFC) | 3d | 2004-10-01 | 2004-10-05 | 713SS |  |  | 2004-08-24 | 2004-08-26 | 3d | 291d |  |
| 50 | 1.2.5.13 | LET/HET/SEP Cen Bake Out (at JPL) | 3d | 2004-10-13 | 2004-10-15 | 775SS |  |  | 2004-09-10 | 2004-09-14 | 3d | 284d |  |
| 51 | 1.2.6 | **SEP Suite FM 2 Environmental Test Flow Snapshot** | 170d | 2004-02-19 A | 2004-10-18 |  | 5% | 162.27d | 2004-02-17 | 2004-10-05 | 164d | 283d |  |
| 52 | 1.2.6.1 | SEPT (NS & E) Vibe and Acoustics (in Europe) | 4d | 2004-02-19 A | 2004-02-24 A | 577SS | 100% |  | 2004-02-17 | 2004-02-24 | 8d |  |  |
| 53 | 1.2.6.2 | SEPT (NS & E) Thermal Vac (in Europe) | 10d | 2004-03-05 | 2004-03-18 | 578SS, 584SS |  |  | 2004-03-09 | 2004-03-17 | 9d | 432d |  |
| 54 | 1.2.6.3 | SEPT (NS & E) Bake Out (in Europe) | 2d | 2004-03-12 | 2004-03-15 | 579SS, 585SS |  |  | 2004-03-18 | 2004-03-19 | 2d | 435d |  |
| 55 | 1.2.6.4 | LET/HET/SEP Cen Accelerator Test (at MSU) | 11d | 2004-08-18 | 2004-09-01 | 785SS |  |  | 2004-07-13 | 2004-07-27 | 11d | 314d |  |
| 56 | 1.2.6.5 | LET/HET/SEP Cen Vibe and Acoustics (at JPL) | 10d | 2004-08-31 | 2004-09-14 | 778SS |  |  | 2004-07-23 | 2004-08-05 | 10d | 306d |  |
| 57 | 1.2.6.6 | SEP Suite FM 2 EMC (at Caltech) | 5d | 2004-08-24 | 2004-08-30 | 777SS |  |  | 2004-08-12 | 2004-08-18 | 5d | 316d |  |
| 58 | 1.2.6.7 | LET/HET/SEP Cen Thermal Vac (at JPL) | 15d | 2004-09-15 | 2004-10-05 | 779SS |  |  | 2004-08-19 | 2004-09-09 | 15d | 291d |  |
| 59 | 1.2.6.8 | SIT Vibe and Acoustics (at GSFC) | 10d | 2004-09-02 | 2004-09-16 | 717SS |  |  | 2004-08-23 | 2004-09-03 | 10d | 304d |  |
| 60 | 1.2.6.9 | SIT Thermal Balance (at GSFC) | 5d | 2004-09-20 | 2004-09-24 | 719SS |  |  | 2004-09-08 | 2004-09-14 | 5d | 298d |  |
| 61 | 1.2.6.10 | LET/HET/SEP Cen Bake Out (at JPL) | 3d | 2004-10-06 | 2004-10-08 | 782SS |  |  | 2004-09-10 | 2004-09-14 | 3d | 288d |  |
| 62 | 1.2.6.11 | SIT Thermal Vac (at GSFC) | 10d | 2004-09-27 | 2004-10-08 | 720SS |  |  | 2004-09-15 | 2004-09-28 | 10d | 288d |  |
| 63 | 1.2.6.12 | SIT Bake Out (at GSFC) | 3d | 2004-10-14 | 2004-10-18 | 722SS |  |  | 2004-10-01 | 2004-10-05 | 3d | 283d |  |

Notes:
- 28: This section is a "snapshot" of the environmental test flow for the FM 2 Boom Suite. It reflects the details of the testing activities found within the body of the schedule. It was placed in the schedule to allow someone to get a quick look at the test flow and the associated dates. The tasks contained within this section are not tied to any other activities (and do not drive any other activities) and so therefore you will see large float values associated with them. It is simply a quick look at the test flow so that one does not have to filter through the schedule to locate the environmental test activities.
- 37: This section is a "snapshot" of the environmental test flow for the FM 1 SEP Suite. It reflects the details of the testing activities found within the body of the schedule. It was placed in the schedule to allow someone to get a quick look at the test flow and the associated dates. The tasks contained within this section are not tied to any other activities (and do not drive any other activities) and so therefore you will see large float values associated with them. It is simply a quick look at the test flow so that one does not have to filter through the schedule to locate the environmental test activities.
- 38: There was a failure on the SEPT door during Vibration Test. Vibration Test will be repeated once the fix to the door is implemented. Time and place is TBD.
- 51: This section is a "snapshot" of the environmental test flow for the FM 2 SEP Suite. It reflects the details of the testing activities found within the body of the schedule. It was placed in the schedule to allow someone to get a quick look at the test flow and the associated dates. The tasks contained within this section are not tied to any other activities (and do not drive any other activities) and so therefore you will see large float values associated with them. It is simply a quick look at the test flow so that one does not have to filter through the schedule to locate the environmental test activities.
- 52: There was a failure on the SEPT door during Vibration Test. Vibration Test will be repeated once the fix to the door is implemented. Time and place is TBD.

| ID | WBS | Task | Type | Duration | Start | Finish | Predecessors | Complete | Remaining | Baseline start | Baseline finish | Baseline duration | Total slack | Free slack | Constraint | Text1 |
| --- | --- | --- | --- | --- | --- | --- | --- | --- | --- | --- | --- | --- | --- | --- | --- | --- |
| 64 | 1.3 | **Power Converters - UCB** |  | 339d | 2003-02-26 A | 2004-06-29 |  | 63% | 125.7d | 2003-02-26 | 2004-06-23 | 335d | 19d |  |  |  |
| 65 | 1.3.1 | **Deliveries** |  | 141d | 2003-12-09 A | 2004-06-29 |  | 20% | 112.8d | 2003-12-09 | 2004-04-30 | 100d | 19d |  |  |  |
| 66 | 1.3.1.1 | **FM 1** |  | 111d | 2003-12-09 A | 2004-05-17 |  | 40% | 66.6d | 2003-12-09 | 2004-04-23 | 95d | 13d |  |  |  |
| 67 | 1.3.1.1.1 | Deliver IDPU FM 1 LVPS (stays at UCB) | milestone | 0d | 2004-05-17 | 2004-05-17 | 121 |  |  | 2004-04-23 | 2004-04-23 | 0d | 13d | 0d |  | MS-BOOM |
| 68 | 1.3.1.1.2 | Deliver SEP FM 1 LVPS (to Caltech) |  | 1d | 2004-05-13 | 2004-05-13 | 125 |  |  | 2004-04-06 | 2004-04-06 | 1d | 13d |  |  | MS-SEP |
| 69 | 1.3.1.1.3 | Deliver SWEA/STE FM 1 LVPS (stays at UCB) | milestone | 0d | 2004-04-23 | 2004-04-23 | 129 |  |  | 2004-04-15 | 2004-04-15 | 0d | 7d | 0d |  | MS-BOOM |
| 70 | 1.3.1.1.4 | Deliver PLASTIC FM 1 LVPS (to UNH) |  | 2d | 2004-04-12 | 2004-04-13 | 133 |  |  | 2004-03-24 | 2004-03-25 | 2d | 15d |  | finish no later than 2004-05-04 |  |
| 71 | 1.3.1.1.5 | Deliver SIT FM 1 HVPS (to UMD) |  | 2d | 2003-12-09 A | 2003-12-10 A | 135 | 100% |  | 2003-12-09 | 2003-12-10 | 2d |  |  |  |  |
| 72 | 1.3.1.2 | **FM 2** |  | 32d | 2004-05-14 | 2004-06-29 |  |  |  | 2004-04-12 | 2004-04-30 | 15d | 7d |  |  |  |
| 73 | 1.3.1.2.1 | Deliver IDPU FM 2 LVPS (stays at UCB) | milestone | 0d | 2004-06-29 | 2004-06-29 | 140 |  |  | 2004-04-30 | 2004-04-30 | 0d | 19d | 0d |  | MS-BOOM |
| 74 | 1.3.1.2.2 | Deliver SEP FM 2 LVPS (to Caltech) |  | 1d | 2004-05-18 | 2004-05-18 | 144 |  |  | 2004-04-19 | 2004-04-19 | 1d | 10d |  |  | MS-SEP |
| 75 | 1.3.1.2.3 | Deliver SWEA/STE FM 2 LVPS (stays at UCB) | milestone | 0d | 2004-06-07 | 2004-06-07 | 148 |  |  | 2004-04-26 | 2004-04-26 | 0d | 24d | 10d |  | MS-BOOM |
| 76 | 1.3.1.2.4 | Deliver PLASTIC FM 2 LVPS (to UNH) |  | 2d | 2004-05-21 | 2004-05-24 | 152 |  |  | 2004-04-12 | 2004-04-13 | 2d | 12d |  | finish no later than 2004-06-10 |  |
| 77 | 1.3.1.2.5 | Deliver SIT FM 2 HVPS (to UMD) |  | 2d | 2004-05-14 | 2004-05-17 | 156 |  |  | 2004-04-12 | 2004-04-13 | 2d | 7d | 5d |  | MS-SEP |
| 78 | 1.3.2 | **Remaining Flight Procurements** |  | 95d | 2003-10-24 A | 2004-03-12 |  | 75% | 23.75d | 2003-10-24 | 2004-02-19 | 79d | 13d |  |  |  |
| 79 | 1.3.2.1 | Procure IDPU Flight Printed Wiring Board |  | 10d | 2004-03-01 | 2004-03-12 | 85 |  |  | 2004-02-05 | 2004-02-19 | 10d | 13d | 0d | start no earlier than 2004-03-01 |  |
| 80 | 1.3.2.2 | Procure SEP Flight Printed Wiring Board |  | 10d | 2003-11-24 A | 2003-12-08 A | 86 | 100% |  | 2003-11-24 | 2003-12-08 | 10d |  |  | start no earlier than 2003-11-24 |  |
| 81 | 1.3.2.3 | Procure SWEA Flight Printed Wiring Board |  | 10d | 2003-12-04 A | 2003-12-17 A | 87 | 100% |  | 2003-12-04 | 2003-12-17 | 10d |  |  |  |  |
| 82 | 1.3.2.4 | Procure PLASTIC Flight Printed Wiring Board |  | 10d | 2003-10-24 A | 2003-11-06 A |  | 100% |  | 2003-10-24 | 2003-11-06 | 10d |  |  | start no earlier than 2003-10-24 |  |
| 83 | 1.3.3 | **Fabrication** |  | 239d | 2003-02-26 A | 2004-02-06 A |  | 100% |  | 2003-02-26 | 2004-02-06 | 239d |  |  |  |  |
| 84 | 1.3.3.1 | **FM 1 & FM 2** |  | 195d | 2003-02-26 A | 2003-12-03 A |  | 100% |  | 2003-02-26 | 2003-12-03 | 195d |  |  |  |  |
| 85 | 1.3.3.1.1 | Re-layout IDPU LVPS Flight Printed Wiring Board |  | 186d | 2003-02-26 A | 2003-11-19 A |  | 100% |  | 2003-02-26 | 2003-11-19 | 186d |  |  | start no earlier than 2003-02-26 |  |
| 86 | 1.3.3.1.2 | Re-layout SEP LVPS Flight Printed Wiring Board |  | 32d | 2003-09-24 A | 2003-11-07 A |  | 100% |  | 2003-09-24 | 2003-11-07 | 32d |  |  | start no earlier than 2003-09-24 |  |
| 87 | 1.3.3.1.3 | Re-layout SWEA LVPS Flight Printed Wiring Board |  | 5d | 2003-11-26 A | 2003-12-03 A |  | 100% |  | 2003-11-26 | 2003-12-03 | 5d |  |  | start no earlier than 2003-11-26 |  |

| ID | WBS | Task | Duration | Start | Finish | Predecessors | Complete | Remaining | Baseline start | Baseline finish | Baseline duration | Total slack | Free slack | Constraint |
| --- | --- | --- | --- | --- | --- | --- | --- | --- | --- | --- | --- | --- | --- | --- |
| 88 | 1.3.3.2 | **FM 1** | 45d | 2003-09-29 A | 2003-12-03 A |  | 100% |  | 2003-09-29 | 2003-12-03 | 45d |  |  |  |
| 89 | 1.3.3.2.1 | Wind IDPU LVPS FM 1 Magnets | 10d | 2003-10-17 A | 2003-10-30 A |  | 100% |  | 2003-10-17 | 2003-10-30 | 10d |  |  | start no earlier than 2003-10-17 |
| 90 | 1.3.3.2.2 | Wind SEP LVPS FM 1 Magnets | 15d | 2003-09-29 A | 2003-10-20 A |  | 100% |  | 2003-09-29 | 2003-10-20 | 15d |  |  | start no earlier than 2003-09-29 |
| 91 | 1.3.3.2.3 | Wind SWEA LVPS FM 1 Magnets | 5d | 2003-11-26 A | 2003-12-03 A |  | 100% |  | 2003-11-26 | 2003-12-03 | 5d |  |  | start no earlier than 2003-11-26 |
| 92 | 1.3.3.2.4 | Wind PLASTIC LVPS FM 1 Magnets | 45d | 2003-09-29 A | 2003-12-03 A |  | 100% |  | 2003-09-29 | 2003-12-03 | 45d |  |  | start no earlier than 2003-09-29 |
| 93 | 1.3.3.3 | **FM 2** | 28d | 2003-12-29 A | 2004-02-06 A |  | 100% |  | 2003-12-29 | 2004-02-06 | 28d |  |  |  |
| 94 | 1.3.3.3.1 | Wind HVPS FM 2 Magnets | 28d | 2003-12-29 A | 2004-02-06 A |  | 100% |  | 2003-12-29 | 2004-02-06 | 28d |  |  | start no earlier than 2003-12-29 |
| 95 | 1.3.3.3.2 | Wind IDPU LVPS FM 2 Magnets | 28d | 2003-12-29 A | 2004-02-06 A | 94SS | 100% |  | 2003-12-29 | 2004-02-06 | 28d |  |  |  |
| 96 | 1.3.3.3.3 | Wind SEP LVPS FM 2 Magnets | 28d | 2003-12-29 A | 2004-02-06 A | 94SS | 100% |  | 2003-12-29 | 2004-02-06 | 28d |  |  |  |
| 97 | 1.3.3.3.4 | Wind SWEA LVPS FM 2 Magnets | 28d | 2003-12-29 A | 2004-02-06 A | 94SS | 100% |  | 2003-12-29 | 2004-02-06 | 28d |  |  |  |
| 98 | 1.3.3.3.5 | Wind PLASTIC LVPS FM 2 Magnets | 28d | 2003-12-29 A | 2004-02-06 A | 94SS | 100% |  | 2003-12-29 | 2004-02-06 | 28d |  |  |  |
| 99 | 1.3.4 | **Assembly** | 98d | 2003-12-29 A | 2004-05-17 |  | 45% | 53.51d | 2003-12-29 | 2004-03-19 | 57d | 19d |  |  |
| 100 | 1.3.4.1 | **FM 1** | 68d | 2003-12-29 A | 2004-04-05 |  | 78% | 14.81d | 2003-12-29 | 2004-03-12 | 52d | 13d |  |  |
| 101 | 1.3.4.1.1 | Assemble IDPU FM 1 LVPS | 12d | 2004-03-19 | 2004-04-05 | 89, 113 |  |  | 2004-02-26 | 2004-03-12 | 12d | 13d | 0d |  |
| 102 | 1.3.4.1.2 | Assemble SEP FM 1 LVPS | 40d | 2004-01-12 A | 2004-03-09 A | 114, 90 | 100% |  | 2004-01-12 | 2004-02-23 | 29d |  |  | start no earlier than 2004-01-12 |
| 103 | 1.3.4.1.3 | Assemble SWEA FM 1 LVPS | 20d | 2004-02-13 A | 2004-03-12 | 91, 115 | 50% | 10d | 2004-02-13 | 2004-03-04 | 14d | 7d | 0d | start no earlier than 2004-02-13 |
| 104 | 1.3.4.1.4 | Assemble PLASTIC FM 1 LVPS | 29d | 2003-12-29 A | 2004-02-09 A | 116, 92 | 100% |  | 2003-12-29 | 2004-02-09 | 29d |  |  | start no earlier than 2003-12-29 |
| 105 | 1.3.4.2 | **FM 2** | 46d | 2004-03-15 | 2004-05-17 |  |  |  | 2004-02-09 | 2004-03-19 | 29d | 7d |  |  |
| 106 | 1.3.4.2.1 | Assemble IDPU FM 2 LVPS | 15d | 2004-04-27 | 2004-05-17 | 95, 119 |  |  | 2004-03-01 | 2004-03-19 | 15d | 19d | 0d | start no earlier than 2004-03-01 |
| 107 | 1.3.4.2.2 | Assemble SEP FM 2 LVPS | 15d | 2004-03-16 | 2004-04-05 | 96, 123 |  |  | 2004-02-13 | 2004-03-05 | 15d | 10d | 0d | start no earlier than 2004-02-13 |
| 108 | 1.3.4.2.3 | Assemble SWEA FM 2 LVPS | 15d | 2004-04-05 | 2004-04-23 | 97, 127 |  |  | 2004-02-24 | 2004-03-15 | 15d | 24d | 0d | start no earlier than 2004-02-24 |
| 109 | 1.3.4.2.4 | Assemble PLASTIC FM 2 LVPS | 14d | 2004-03-22 | 2004-04-08 | 98, 131 |  |  | 2004-02-09 | 2004-02-27 | 14d | 12d | 0d | start no earlier than 2004-02-09 |
| 110 | 1.3.4.2.5 | Assemble SIT FM 2 HVPS | 14d | 2004-03-15 | 2004-04-01 | 94, 103 |  |  | 2004-02-09 | 2004-02-27 | 14d | 7d | 0d |  |
| 111 | 1.3.5 | **Testing** | 166d | 2003-10-31 A | 2004-06-29 |  | 21% | 130.91d | 2003-10-31 | 2004-06-23 | 162d | 19d |  |  |
| 112 | 1.3.5.1 | **FM 1 & FM 2** | 79d | 2003-11-24 A | 2004-03-18 |  | 80% | 15.8d | 2003-11-24 | 2004-02-25 | 63d | 13d |  |  |
| 113 | 1.3.5.1.1 | Coupon Test IDPU Flight Printed Wiring Board | 4d | 2004-03-15 | 2004-03-18 | 79 |  |  | 2004-02-20 | 2004-02-25 | 4d | 13d | 0d |  |
| 114 | 1.3.5.1.2 | Coupon Test SEP Flight Printed Wiring Board | 5d | 2003-12-09 A | 2003-12-15 A | 80 | 100% |  | 2003-12-09 | 2003-12-15 | 5d |  |  |  |
| 115 | 1.3.5.1.3 | Coupon Test SWEA Flight Printed Wiring Board | 6d | 2004-01-09 A | 2004-01-16 A | 81 | 100% |  | 2004-01-09 | 2004-01-16 | 6d |  |  | start no earlier than 2004-01-09 |
| 116 | 1.3.5.1.4 | Coupon Test PLASTIC Flight Printed Wiring Board | 5d | 2003-11-24 A | 2003-12-01 A | 82 | 100% |  | 2003-11-24 | 2003-12-01 | 5d |  |  | start no earlier than 2003-11-24 |

| ID | WBS | Task | Duration | Start | Finish | Predecessors | Complete | Remaining | Baseline start | Baseline finish | Baseline duration | Total slack | Free slack | Constraint |
| --- | --- | --- | --- | --- | --- | --- | --- | --- | --- | --- | --- | --- | --- | --- |
| 117 | 1.3.5.2 | **FM 1** | 136d | 2003-10-31 A | 2004-05-17 |  | 35% | 88.82d | 2003-10-31 | 2004-06-23 | 162d | 13d |  |  |
| 118 | 1.3.5.2.1 | **IDPU** | 30d | 2004-04-06 | 2004-05-17 |  |  |  | 2004-03-15 | 2004-04-23 | 30d | 13d |  |  |
| 119 | 1.3.5.2.1.1 | Test IDPU FM 1 LVPS | 15d | 2004-04-06 | 2004-04-26 | 101 |  |  | 2004-03-15 | 2004-04-02 | 15d | 13d | 0d |  |
| 120 | 1.3.5.2.1.2 | Coat & Stake IDPU LVPS FM 1 Boards | 5d | 2004-04-27 | 2004-05-03 | 119 |  |  | 2004-04-05 | 2004-04-09 | 5d | 13d | 0d |  |
| 121 | 1.3.5.2.1.3 | Retest IDPU LVPS FM 1 Boards | 10d | 2004-05-04 | 2004-05-17 | 120 |  |  | 2004-04-12 | 2004-04-23 | 10d | 13d | 0d |  |
| 122 | 1.3.5.2.2 | **SEP** | 46d | 2004-03-10 | 2004-05-12 |  |  |  | 2004-02-24 | 2004-04-05 | 30d | 10d |  |  |
| 123 | 1.3.5.2.2.1 | Test SEP FM 1 LVPS | 4d | 2004-03-10 | 2004-03-15 | 102 |  |  | 2004-02-24 | 2004-03-15 | 15d | 10d | 0d |  |
| 124 | 1.3.5.2.2.2 | Coat & Stake SEP LVPS FM 1 Boards | 5d | 2004-03-16 | 2004-03-22 | 123 |  |  | 2004-03-16 | 2004-03-22 | 5d | 40d | 27d |  |
| 125 | 1.3.5.2.2.3 | Retest SEP LVPS FM 1 Boards | 10d | 2004-04-29 | 2004-05-12 | 124, 369 |  |  | 2004-03-23 | 2004-04-05 | 10d | 13d | 0d |  |
| 126 | 1.3.5.2.3 | **SWEA** | 30d | 2004-03-15 A | 2004-04-23 |  | 43% | 17d | 2004-03-05 | 2004-04-15 | 30d | 7d |  |  |
| 127 | 1.3.5.2.3.1 | Test SWEA FM 1 LVPS | 15d | 2004-03-15 A | 2004-04-02 | 103 | 87% | 2d | 2004-03-05 | 2004-03-25 | 15d | 7d | 0d |  |
| 128 | 1.3.5.2.3.2 | Coat & Stake SWEA LVPS FM 1 Boards | 5d | 2004-04-05 | 2004-04-09 | 127 |  |  | 2004-03-26 | 2004-04-01 | 5d | 7d | 0d |  |
| 129 | 1.3.5.2.3.3 | Retest SWEA LVPS FM 1 Boards | 10d | 2004-04-12 | 2004-04-23 | 128 |  |  | 2004-04-02 | 2004-04-15 | 10d | 7d | 0d |  |
| 130 | 1.3.5.2.4 | **PLASTIC** | 43d | 2004-02-10 A | 2004-04-09 |  | 30% | 30d | 2004-02-10 | 2004-03-23 | 30d | 15d |  |  |
| 131 | 1.3.5.2.4.1 | Test PLASTIC FM 1 LVPS | 28d | 2004-02-10 A | 2004-03-19 | 104 | 46% | 15d | 2004-02-10 | 2004-03-02 | 15d | 12d | 0d |  |
| 132 | 1.3.5.2.4.2 | Coat & Stake PLASTIC LVPS FM 1 Boards | 5d | 2004-03-22 | 2004-03-26 | 131 |  |  | 2004-03-03 | 2004-03-09 | 5d | 15d | 0d |  |
| 133 | 1.3.5.2.4.3 | Retest PLASTIC LVPS FM 1 Boards | 10d | 2004-03-29 | 2004-04-09 | 132 |  |  | 2004-03-10 | 2004-03-23 | 10d | 15d | 0d |  |
| 134 | 1.3.5.2.5 | **SIT** | 25d | 2003-10-31 A | 2003-12-08 A |  | 100% |  | 2003-10-31 | 2004-06-23 | 162d |  |  |  |
| 135 | 1.3.5.2.5.1 | Test SIT FM 1 HVPS | 25d | 2003-10-31 A | 2003-12-08 A |  | 100% |  | 2003-10-31 | 2003-12-08 | 25d |  |  | start no earlier than 2003-10-31 |
| 136 | 1.3.5.3 | **FM 2** | 62d | 2004-04-02 | 2004-06-29 |  |  |  | 2004-03-01 | 2004-04-30 | 45d | 7d |  |  |
| 137 | 1.3.5.3.1 | **IDPU** | 30d | 2004-05-18 | 2004-06-29 |  |  |  | 2004-03-22 | 2004-04-30 | 30d | 19d |  |  |
| 138 | 1.3.5.3.1.1 | Test IDPU FM 2 LVPS | 15d | 2004-05-18 | 2004-06-08 | 106 |  |  | 2004-03-22 | 2004-04-09 | 15d | 19d | 0d |  |
| 139 | 1.3.5.3.1.2 | Coat & Stake IDPU LVPS FM 2 Boards | 5d | 2004-06-09 | 2004-06-15 | 138 |  |  | 2004-04-12 | 2004-04-16 | 5d | 19d | 0d |  |
| 140 | 1.3.5.3.1.3 | Retest IDPU LVPS FM 2 Boards | 10d | 2004-06-16 | 2004-06-29 | 139 |  |  | 2004-04-19 | 2004-04-30 | 10d | 19d | 0d |  |

| ID | WBS | Task | Type | Duration | Start | Finish | Predecessors | Complete | Remaining | Baseline start | Baseline finish | Baseline duration | Total slack | Free slack | Constraint | Text1 |
| --- | --- | --- | --- | --- | --- | --- | --- | --- | --- | --- | --- | --- | --- | --- | --- | --- |
| 141 | 1.3.5.3.2 | **SEP** |  | 30d | 2004-04-06 | 2004-05-17 |  |  |  | 2004-03-08 | 2004-04-16 | 30d | 10d |  |  |  |
| 142 | 1.3.5.3.2.1 | Test SEP FM 2 LVPS |  | 15d | 2004-04-06 | 2004-04-26 | 107 |  |  | 2004-03-08 | 2004-03-26 | 15d | 10d | 0d |  |  |
| 143 | 1.3.5.3.2.2 | Coat & Stake SEP LVPS FM 2 Boards |  | 5d | 2004-04-27 | 2004-05-03 | 142 |  |  | 2004-03-29 | 2004-04-02 | 5d | 10d | 0d |  |  |
| 144 | 1.3.5.3.2.3 | Retest SEP LVPS FM 2 Boards |  | 10d | 2004-05-04 | 2004-05-17 | 143, 369 |  |  | 2004-04-05 | 2004-04-16 | 10d | 10d | 0d |  |  |
| 145 | 1.3.5.3.3 | **SWEA** |  | 30d | 2004-04-26 | 2004-06-07 |  |  |  | 2004-03-16 | 2004-04-26 | 30d | 24d |  |  |  |
| 146 | 1.3.5.3.3.1 | Test SWEA FM 2 LVPS |  | 15d | 2004-04-26 | 2004-05-14 | 108 |  |  | 2004-03-16 | 2004-04-05 | 15d | 24d | 0d |  |  |
| 147 | 1.3.5.3.3.2 | Coat & Stake SWEA LVPS FM 2 Boards |  | 5d | 2004-05-17 | 2004-05-21 | 146 |  |  | 2004-04-06 | 2004-04-12 | 5d | 24d | 0d |  |  |
| 148 | 1.3.5.3.3.3 | Retest SWEA LVPS FM 2 Boards |  | 10d | 2004-05-24 | 2004-06-07 | 147 |  |  | 2004-04-13 | 2004-04-26 | 10d | 24d | 0d |  |  |
| 149 | 1.3.5.3.4 | **PLASTIC** |  | 30d | 2004-04-09 | 2004-05-20 |  |  |  | 2004-03-01 | 2004-04-09 | 30d | 12d |  |  |  |
| 150 | 1.3.5.3.4.1 | Test PLASTIC FM 2 LVPS |  | 15d | 2004-04-09 | 2004-04-29 | 109 |  |  | 2004-03-01 | 2004-03-19 | 15d | 12d | 0d |  |  |
| 151 | 1.3.5.3.4.2 | Coat & Stake PLASTIC LVPS FM 2 Boards |  | 5d | 2004-04-30 | 2004-05-06 | 150 |  |  | 2004-03-22 | 2004-03-26 | 5d | 12d | 0d |  |  |
| 152 | 1.3.5.3.4.3 | Retest PLASTIC LVPS FM 2 Boards |  | 10d | 2004-05-07 | 2004-05-20 | 151 |  |  | 2004-03-29 | 2004-04-09 | 10d | 12d | 0d |  |  |
| 153 | 1.3.5.3.5 | **SIT** |  | 30d | 2004-04-02 | 2004-05-13 |  |  |  | 2004-03-01 | 2004-04-09 | 30d | 7d |  |  |  |
| 154 | 1.3.5.3.5.1 | Test SIT FM 2 HVPS |  | 15d | 2004-04-02 | 2004-04-22 | 110 |  |  | 2004-03-01 | 2004-03-19 | 15d | 7d | 0d |  |  |
| 155 | 1.3.5.3.5.2 | Coat & Stake SIT FM 2 HVPS Boards |  | 5d | 2004-04-23 | 2004-04-29 | 154 |  |  | 2004-03-22 | 2004-03-26 | 5d | 7d | 0d |  |  |
| 156 | 1.3.5.3.5.3 | Retest SIT FM 2 HVPS Boards |  | 10d | 2004-04-30 | 2004-05-13 | 155 |  |  | 2004-03-29 | 2004-04-09 | 10d | 7d | 0d |  |  |
| 157 | 1.4 | **IDPU - UCB** |  | 340d | 2003-05-05 A | 2004-09-07 |  | 76% | 83.19d | 2003-05-05 | 2004-09-07 | 340d | 0d |  |  |  |
| 158 | 1.4.1 | **Deliveries** |  | 30d | 2004-06-15 | 2004-07-27 |  |  |  | 2004-04-13 | 2004-05-28 | 33d | 13d |  |  |  |
| 159 | 1.4.1.1 | IDPU FM 1 Complete (to UCB for Boom I&T, then to CIT for SEP I&T, Suite EMC, BO & Final Boom I&T) | milestone | 0d | 2004-06-15 | 2004-06-15 | 174 |  |  | 2004-05-21 | 2004-05-21 | 0d | 13d | 6d |  | MS-BOOM |
| 160 | 1.4.1.2 | IDPU FM 2 Complete (to CIT for SEP I&T, then to UCB for Boom I&T, Boom EMC, BO & Final Boom I&T) | milestone | 0d | 2004-07-27 | 2004-07-27 | 178 |  |  | 2004-05-28 | 2004-05-28 | 0d | 19d | 4d |  | MS-BOOM |
| 161 | 1.4.2 | **Flight Software** |  | 237d | 2003-05-05 A | 2004-04-13 |  | 89% | 25.62d | 2003-05-05 | 2004-04-13 | 237d | 83d |  |  |  |
| 162 | 1.4.2.1 | IDPU S/W Build #2.5 |  | 131d | 2003-05-05 A | 2003-11-07 A |  | 100% |  | 2003-05-05 | 2003-11-07 | 131d |  |  | start no earlier than 2003-05-05 |  |
| 163 | 1.4.2.2 | IDPU S/W Build #3 (also goes to UNH) |  | 165d | 2003-08-15 A | 2004-04-13 |  | 81% | 32d | 2003-08-15 | 2004-04-13 | 165d | 83d | 64d | start no earlier than 2003-08-15 | MS-BOOM |
| 164 | 1.4.3 | **GSE** |  | 301d | 2003-06-30 A | 2004-09-07 |  | 72% | 83.78d | 2003-06-30 | 2004-09-07 | 301d | 0d |  |  |  |
| 165 | 1.4.3.1 | STE Science Display |  | 27d | 2003-10-23 A | 2003-12-02 A |  | 100% |  | 2003-10-23 | 2003-12-02 | 27d |  |  | start no earlier than 2003-10-23 |  |
| 166 | 1.4.3.2 | SWEA Science Display |  | 167d | 2003-06-30 A | 2004-03-01 A |  | 100% |  | 2003-06-30 | 2004-02-23 | 162d |  |  | start no earlier than 2003-06-30 |  |
| 167 | 1.4.3.3 | GSE Continued Development (LOE) |  | 291d | 2003-07-15 A | 2004-09-07 |  | 54% | 135d | 2003-07-15 | 2004-09-07 | 291d | 0d |  | must start on 2003-07-15 |  |

| ID | WBS | Task | Type | Duration | Start | Finish | Predecessors | Complete | Remaining | Baseline start | Baseline finish | Baseline duration | Total slack | Free slack | Constraint | Calendar | Text1 |
| --- | --- | --- | --- | --- | --- | --- | --- | --- | --- | --- | --- | --- | --- | --- | --- | --- | --- |
| 168 | 1.4.4 | **Integration & Test** |  | 203d | 2003-10-07 A | 2004-07-27 |  | 38% | 124.92d | 2003-10-07 | 2004-05-28 | 162d | 19d |  |  |  |  |
| 169 | 1.4.4.1 | IDPU DCB FM 2 Board Level Testing |  | 15d | 2003-10-07 A | 2003-10-28 A |  | 100% |  | 2003-10-07 | 2003-10-28 | 15d |  |  | start no earlier than 2003-10-07 |  |  |
| 170 | 1.4.4.2 | IDPU DCB Clean/Stake/Coat (FM 1 & FM 2) |  | 10d | 2003-12-26 A | 2004-01-09 A | 169 | 100% |  | 2003-12-26 | 2004-01-09 | 10d |  |  | start no earlier than 2003-12-26 |  |  |
| 171 | 1.4.4.3 | **FM 1** |  | 20d | 2004-05-18 | 2004-06-15 |  |  |  | 2004-04-26 | 2004-05-21 | 20d | 13d |  |  |  |  |
| 172 | 1.4.4.3.1 | IDPU FM 1 I & T |  | 5d | 2004-05-18 | 2004-05-24 | 162, 67, 237, 281, 170 |  |  | 2004-04-26 | 2004-04-30 | 5d | 13d | 0d |  |  | MS-BOOM |
| 173 | 1.4.4.3.2 | IDPU FM 1 Vibration |  | 5d | 2004-05-25 | 2004-06-01 | 172 |  |  | 2004-05-03 | 2004-05-07 | 5d | 13d | 0d |  |  |  |
| 174 | 1.4.4.3.3 | IDPU FM 1 Thermal Vacuum & Bake Out |  | 10d | 2004-06-02 | 2004-06-15 | 173 |  |  | 2004-05-10 | 2004-05-21 | 10d | 13d | 0d |  |  |  |
| 175 | 1.4.4.4 | **FM 2** |  | 20d | 2004-06-30 | 2004-07-27 |  |  |  | 2004-05-03 | 2004-05-28 | 20d | 19d |  |  |  |  |
| 176 | 1.4.4.4.1 | IDPU FM 2 I & T |  | 5d | 2004-06-30 | 2004-07-06 | 73, 238, 282, 169, 170 |  |  | 2004-05-03 | 2004-05-07 | 5d | 19d | 0d |  |  |  |
| 177 | 1.4.4.4.2 | IDPU FM 2 Vibration |  | 5d | 2004-07-07 | 2004-07-13 | 176 |  |  | 2004-05-10 | 2004-05-14 | 5d | 19d | 0d |  |  |  |
| 178 | 1.4.4.4.3 | IDPU FM 2 Thermal Vacuum & Bake Out |  | 10d | 2004-07-14 | 2004-07-27 | 163, 177 |  |  | 2004-05-17 | 2004-05-28 | 10d | 19d | 0d |  |  |  |
| 179 | 1.5 | **BOOM Suite - UCB** |  | 321d | 2003-07-01 A | 2004-10-06 |  | 72% | 88.47d | 2003-07-01 | 2004-09-28 | 315d | 14d |  |  |  |  |
| 180 | 1.5.1 | **BOOM Structure - UCB** |  | 216d | 2003-09-10 A | 2004-07-19 |  | 85% | 31.33d | 2003-09-10 | 2004-06-18 | 195d | 49d |  |  |  |  |
| 181 | 1.5.1.1 | **Deliveries** |  | 133d | 2004-01-09 A | 2004-07-19 |  |  | 133d | 2004-01-09 | 2004-06-18 | 112d | 49d |  |  |  |  |
| 182 | 1.5.1.1.1 | Protoflight Boom available for I&T (if needed) | milestone | 0d | 2004-01-09 A | 2004-01-09 A | 187 | 100% |  | 2004-01-09 | 2004-01-09 | 0d |  |  |  |  |  |
| 183 | 1.5.1.1.2 | Deliver Boom Structure FM 1 (stays at UCB for Boom Suite FM 1 I&T) | milestone | 0d | 2004-06-02 | 2004-06-02 | 212 |  |  | 2004-05-27 | 2004-05-27 | 0d | 20d | 13d |  |  | MS-BOOM |
| 184 | 1.5.1.1.3 | Deliver Boom Structure FM 2 (stays at UCB for Boom Suite FM 2 I&T) | milestone | 0d | 2004-07-19 | 2004-07-19 | 234 |  |  | 2004-06-18 | 2004-06-18 | 0d | 49d | 35d |  |  | MS-BOOM |
| 185 | 1.5.1.2 | **Protoflight** |  | 79d | 2003-09-16 A | 2004-01-09 A |  | 100% |  | 2003-09-16 | 2004-01-09 | 79d |  |  |  |  |  |
| 186 | 1.5.1.2.1 | Protoflight Boom Post Environmental Deployment Test |  | 35d | 2003-09-16 A | 2003-11-04 A |  | 100% |  | 2003-09-16 | 2003-11-04 | 35d |  |  | start no earlier than 2003-09-16 |  |  |
| 187 | 1.5.1.2.2 | Document Protoflight Boom Test Results |  | 44d | 2003-11-05 A | 2004-01-09 A | 186 | 100% |  | 2003-11-05 | 2004-01-09 | 44d |  |  |  |  |  |
| 188 | 1.5.1.3 | **Flight Procurements** |  | 40d | 2003-09-10 A | 2003-11-05 A |  | 100% |  | 2003-09-10 | 2003-11-05 | 40d |  |  |  |  |  |
| 189 | 1.5.1.3.1 | Receive and Inspect Flight Boom Structure Tubes (FM 1) |  | 32d | 2003-09-10 A | 2003-10-24 A |  | 100% |  | 2003-09-10 | 2003-10-24 | 32d |  |  | start no earlier than 2003-09-10 |  |  |
| 190 | 1.5.1.3.2 | Receive and Inspect Flight Boom Structure Tubes (FM 2) |  | 40d | 2003-09-10 A | 2003-11-05 A |  | 100% |  | 2003-09-10 | 2003-11-05 | 40d |  |  | start no earlier than 2003-09-10 |  |  |
| 191 | 1.5.1.4 | **FM 1** |  | 170d | 2003-09-29 A | 2004-06-02 |  | 79% | 35.75d | 2003-09-29 | 2004-05-27 | 167d | 20d |  |  |  |  |
| 192 | 1.5.1.4.1 | **Telescoping** |  | 84d | 2003-10-27 A | 2004-02-29 A |  | 100% |  | 2003-10-27 | 2004-02-29 | 84d |  |  |  |  |  |
| 193 | 1.5.1.4.1.1 | **Fabrication, Assembly & Test** |  | 84d | 2003-10-27 A | 2004-02-29 A |  | 100% |  | 2003-10-27 | 2004-02-29 | 84d |  |  |  |  |  |
| 194 | 1.5.1.4.1.1.1 | Machine FM 1 Boom Structure Tubes as necessary |  | 5d | 2003-10-27 A | 2003-10-31 A | 189 | 100% |  | 2003-10-27 | 2003-10-31 | 5d |  |  |  |  |  |
| 195 | 1.5.1.4.1.1.2 | Machine FM 1 Boom Structure Parts (Rings) |  | 38d | 2003-11-07 A | 2004-01-05 A | 189FF+47d | 100% |  | 2003-11-07 | 2004-01-05 | 38d |  |  |  |  |  |
| 196 | 1.5.1.4.1.1.3 | Assemble FM 1 Boom Structure Telescoping Assembly |  | 5d | 2004-02-23 A | 2004-02-27 A | 194, 195 | 100% |  | 2004-02-23 | 2004-02-27 | 5d |  |  | start no earlier than 2004-02-23 |  |  |
| 197 | 1.5.1.4.1.1.4 | Test FM 1 Boom Structure Telescoping Assembly |  | 2d | 2004-02-28 A | 2004-02-29 A | 196 | 100% |  | 2004-02-28 | 2004-02-29 | 2d |  |  |  | Boom Test Calendar |  |

| ID | WBS | Task | Duration | Start | Finish | Predecessors | Complete | Remaining | Baseline start | Baseline finish | Baseline duration | Total slack | Free slack | Constraint | Calendar | Text1 |
| --- | --- | --- | --- | --- | --- | --- | --- | --- | --- | --- | --- | --- | --- | --- | --- | --- |
| 198 | 1.5.1.4.2 | **Harness** | 109d | 2003-09-29 A | 2004-03-08 A |  | 100% |  | 2003-09-29 | 2004-03-08 | 109d |  |  |  |  |  |
| 199 | 1.5.1.4.2.1 | **Fabrication** | 103d | 2003-09-29 A | 2004-02-27 A |  | 100% |  | 2003-09-29 | 2004-02-27 | 103d |  |  |  |  |  |
| 200 | 1.5.1.4.2.1.1 | Machine FM 1 Harness Parts | 103d | 2003-09-29 A | 2004-02-27 A |  | 100% |  | 2003-09-29 | 2004-02-27 | 103d |  |  | start no earlier than 2003-09-29 |  |  |
| 201 | 1.5.1.4.2.2 | **Assembly & Test** | 6d | 2004-03-01 A | 2004-03-08 A |  | 100% |  | 2004-03-01 | 2004-03-08 | 6d |  |  |  |  |  |
| 202 | 1.5.1.4.2.2.1 | Assemble FM 1 Harness subassembly | 7d | 2004-03-01 A | 2004-03-07 A | 200 | 100% |  | 2004-03-01 | 2004-03-07 | 7d |  |  | start no earlier than 2004-03-01 | Boom Test Calendar |  |
| 203 | 1.5.1.4.2.2.2 | FM1 Harness Test | 1d | 2004-03-08 A | 2004-03-08 A | 202 | 100% |  | 2004-03-08 | 2004-03-08 | 1d |  |  |  |  |  |
| 204 | 1.5.1.4.3 | **Mounting** | 38d | 2003-09-29 A | 2003-11-21 A |  | 100% |  | 2003-09-29 | 2003-11-21 | 38d |  |  |  |  |  |
| 205 | 1.5.1.4.3.1 | FM 1Boom Structure Mounting Fabrication | 28d | 2003-09-29 A | 2003-11-06 A |  | 100% |  | 2003-09-29 | 2003-11-06 | 28d |  |  | start no earlier than 2003-09-29 |  |  |
| 206 | 1.5.1.4.3.2 | FM 1Boom Structure Mounting Assembly | 10d | 2003-11-07 A | 2003-11-21 A | 205 | 100% |  | 2003-11-07 | 2003-11-21 | 10d |  |  |  |  |  |
| 207 | 1.5.1.4.4 | **Integration & Test** | 57d | 2004-03-15 | 2004-06-02 |  |  |  | 2004-03-09 | 2004-05-27 | 58d | 20d |  |  |  |  |
| 208 | 1.5.1.4.4.1 | Integrate FM 1 Boom Structure subassemblies & Harness Completion | 20d | 2004-03-15 | 2004-04-09 | 197, 203, 230FS-5d |  |  | 2004-03-09 | 2004-04-05 | 20d | 20d | 0d |  |  | MS-BOOM |
| 209 | 1.5.1.4.4.2 | FM 1 Boom Structure Deployment Test | 10d | 2004-04-12 | 2004-04-23 | 208 |  |  | 2004-04-06 | 2004-04-19 | 10d | 20d | 0d |  |  | MS-BOOM |
| 210 | 1.5.1.4.4.3 | FM 1 Boom Structure Vibration Test | 4d | 2004-04-30 | 2004-05-05 | 209, 348 |  |  | 2004-04-27 | 2004-04-30 | 4d | 20d | 0d |  |  |  |
| 211 | 1.5.1.4.4.4 | FM 1 Boom Structure Themal Vac & Bake Out | 15d | 2004-05-06 | 2004-05-26 | 210 |  |  | 2004-05-03 | 2004-05-21 | 15d | 20d | 0d |  |  |  |
| 212 | 1.5.1.4.4.5 | FM 1 Boom Structure Post Environmental Deployment Test | 4d | 2004-05-27 | 2004-06-02 | 211 |  |  | 2004-05-24 | 2004-05-27 | 4d | 20d | 0d |  |  |  |
| 213 | 1.5.1.5 | **FM 2** | 203d | 2003-09-29 A | 2004-07-19 |  | 83% | 33.97d | 2003-09-29 | 2004-06-18 | 182d | 49d |  |  |  |  |
| 214 | 1.5.1.5.1 | **Telescoping** | 78d | 2003-11-06 A | 2004-03-02 A |  | 100% |  | 2003-11-06 | 2004-03-16 | 88d |  |  |  |  |  |
| 215 | 1.5.1.5.1.1 | **Fabrication, Assembly & Test** | 78d | 2003-11-06 A | 2004-03-02 A |  | 100% |  | 2003-11-06 | 2004-03-16 | 88d |  |  |  |  |  |
| 216 | 1.5.1.5.1.1.1 | Machine FM 2 Boom Structure Tubes as necessary | 11d | 2003-11-06 A | 2003-11-21 A | 190 | 100% |  | 2003-11-06 | 2003-11-21 | 11d |  |  |  |  |  |
| 217 | 1.5.1.5.1.1.2 | Machine FM 2 Boom Structure Parts (Rings) | 38d | 2003-11-07 A | 2004-01-05 A | 195SS | 100% |  | 2003-11-07 | 2004-01-05 | 38d |  |  |  |  |  |
| 218 | 1.5.1.5.1.1.3 | Assemble FM 2 Boom Structure Telescoping Assembly | 5d | 2004-02-23 A | 2004-02-27 A | 216, 217, 196SS | 100% |  | 2004-02-23 | 2004-02-27 | 5d |  |  |  |  |  |
| 219 | 1.5.1.5.1.1.4 | Test FM 2 Boom Structure Telescoping Assembly | 2d | 2004-03-01 A | 2004-03-02 A | 218 | 100% |  | 2004-03-15 | 2004-03-16 | 2d |  |  |  |  |  |
| 220 | 1.5.1.5.2 | **Harness** | 110d | 2003-09-29 A | 2004-03-09 A |  | 100% |  | 2003-09-29 | 2004-03-16 | 115d |  |  |  |  |  |
| 221 | 1.5.1.5.2.1 | **Fabrication** | 103d | 2003-09-29 A | 2004-02-27 A |  | 100% |  | 2003-09-29 | 2004-02-27 | 103d |  |  |  |  |  |
| 222 | 1.5.1.5.2.1.1 | Machine FM 2 Harness Parts | 103d | 2003-09-29 A | 2004-02-27 A | 200SS | 100% |  | 2003-09-29 | 2004-02-27 | 103d |  |  |  |  |  |

| ID | WBS | Task | Duration | Start | Finish | Predecessors | Complete | Remaining | Baseline start | Baseline finish | Baseline duration | Total slack | Free slack | Constraint | Text1 |
| --- | --- | --- | --- | --- | --- | --- | --- | --- | --- | --- | --- | --- | --- | --- | --- |
| 223 | 1.5.1.5.2.2 | **Assembly & Test** | 7d | 2004-03-01 A | 2004-03-09 A |  | 100% |  | 2004-03-01 | 2004-03-16 | 12d |  |  |  |  |
| 224 | 1.5.1.5.2.2.1 | Assemble FM 2 Harness subassembly | 6d | 2004-03-01 A | 2004-03-08 A | 222 | 100% |  | 2004-03-01 | 2004-03-15 | 11d |  |  |  |  |
| 225 | 1.5.1.5.2.2.2 | FM 2 Harness Test | 1d | 2004-03-09 A | 2004-03-09 A | 224 | 100% |  | 2004-03-16 | 2004-03-16 | 1d |  |  |  |  |
| 226 | 1.5.1.5.3 | **Mounting** | 38d | 2003-09-29 A | 2003-11-21 A |  | 100% |  | 2003-09-29 | 2003-11-21 | 38d |  |  |  |  |
| 227 | 1.5.1.5.3.1 | FM 2 Boom Structure Mountings Fabrication | 28d | 2003-09-29 A | 2003-11-06 A | 205SS | 100% |  | 2003-09-29 | 2003-11-06 | 28d |  |  |  |  |
| 228 | 1.5.1.5.3.2 | FM 2 Boom Structure Mountings Assembly | 10d | 2003-11-07 A | 2003-11-21 A | 227 | 100% |  | 2003-11-07 | 2003-11-21 | 10d |  |  |  |  |
| 229 | 1.5.1.5.4 | **Integration & Test** | 93d | 2004-03-10 | 2004-07-19 |  |  |  | 2004-03-17 | 2004-06-18 | 67d | 20d |  |  |  |
| 230 | 1.5.1.5.4.1 | Integrate FM 2 Boom Structure subassemblies & Harness Completion | 8d | 2004-03-10 | 2004-03-19 | 219, 225 |  |  | 2004-03-17 | 2004-04-13 | 20d | 20d | 0d |  |  |
| 231 | 1.5.1.5.4.2 | FM 2 Boom Structure Deployment Test | 10d | 2004-03-22 | 2004-04-02 | 230 |  |  | 2004-04-14 | 2004-04-27 | 10d | 97d | 48d |  |  |
| 232 | 1.5.1.5.4.3 | FM 2 Boom Structure Vibration Test | 4d | 2004-06-17 | 2004-06-22 | 231, 353 |  |  | 2004-05-17 | 2004-05-20 | 4d | 49d | 0d |  |  |
| 233 | 1.5.1.5.4.4 | FM 2 Boom Structure Themal Vac & Bake Out | 15d | 2004-06-23 | 2004-07-13 | 232, 211 |  |  | 2004-05-24 | 2004-06-14 | 15d | 49d | 0d |  |  |
| 234 | 1.5.1.5.4.5 | FM 2 Boom Structure Post Environmental Deployment Test | 4d | 2004-07-14 | 2004-07-19 | 233 |  |  | 2004-06-15 | 2004-06-18 | 4d | 49d | 0d |  |  |
| 235 | 1.5.2 | **MAG - GSFC** | 27d | 2004-02-20 A | 2004-03-29 |  | 22% | 21d | 2004-02-20 | 2004-03-29 | 27d | 84d |  |  |  |
| 236 | 1.5.2.1 | **Deliveries** | 2d | 2004-03-26 | 2004-03-29 |  |  |  | 2004-03-26 | 2004-03-29 | 2d | 39d |  |  |  |
| 237 | 1.5.2.1.1 | Deliver MAG FM 1 (to UCB for IDPU/BOOM Suite FM 1 I&T) | 2d | 2004-03-26 | 2004-03-29 | 241 |  |  | 2004-03-26 | 2004-03-29 | 2d | 39d | 19d |  | MS-BOOM |
| 238 | 1.5.2.1.2 | Deliver MAG FM 2 (to UCB for IDPU/BOOM Suite FM 2 I&T) | 2d | 2004-03-26 | 2004-03-29 | 244 |  |  | 2004-03-26 | 2004-03-29 | 2d | 84d | 52d |  | MS-BOOM |
| 239 | 1.5.2.2 | **FM 1** | 25d | 2004-02-20 A | 2004-03-25 |  | 24% | 19d | 2004-02-20 | 2004-03-25 | 25d | 39d |  |  |  |
| 240 | 1.5.2.2.1 | FM 1 MAG Testing | 10d | 2004-02-20 A | 2004-03-04 |  | 60% | 4d | 2004-02-20 | 2004-03-04 | 10d | 39d | 0d | start no earlier than 2004-02-20 |  |
| 241 | 1.5.2.2.2 | MAG FM 1 Calibration | 15d | 2004-03-05 | 2004-03-25 | 240 |  |  | 2004-03-05 | 2004-03-25 | 15d | 39d | 0d |  |  |
| 242 | 1.5.2.3 | **FM 2** | 25d | 2004-02-20 A | 2004-03-25 |  | 24% | 19d | 2004-02-20 | 2004-03-25 | 25d | 84d |  |  |  |
| 243 | 1.5.2.3.1 | FM 2 MAG Testing | 10d | 2004-02-20 A | 2004-03-04 |  | 60% | 4d | 2004-02-20 | 2004-03-04 | 10d | 84d | 0d | start no earlier than 2004-02-20 |  |
| 244 | 1.5.2.3.2 | MAG FM 2 Calibration | 15d | 2004-03-05 | 2004-03-25 | 243 |  |  | 2004-03-05 | 2004-03-25 | 15d | 84d | 0d |  |  |
| 245 | 1.5.3 | **SWEA - CESR** | 104d | 2003-12-08 A | 2004-05-05 |  | 27% | 76.27d | 2003-12-08 | 2004-04-20 | 93d | 56d |  |  |  |
| 246 | 1.5.3.1 | **Deliveries** | 104d | 2003-12-08 A | 2004-05-05 |  | 50% | 52d | 2003-12-08 | 2004-04-20 | 93d | 56d |  |  |  |
| 247 | 1.5.3.1.1 | SWEA FM 1 Delivery to UCB | 3d | 2003-12-08 A | 2003-12-10 A |  | 100% |  | 2003-12-08 | 2003-12-10 | 3d |  |  | start no earlier than 2003-12-08 |  |
| 248 | 1.5.3.1.2 | SWEA FM 2 Delivery to UCB | 3d | 2004-05-03 | 2004-05-05 | 251 |  |  | 2004-04-16 | 2004-04-20 | 3d | 56d | 42d |  | MS-BOOM |

| ID | WBS | Task | Type | Duration | Start | Finish | Predecessors | Complete | Remaining | Baseline start | Baseline finish | Baseline duration | Total slack | Free slack | Constraint | Text1 |
| --- | --- | --- | --- | --- | --- | --- | --- | --- | --- | --- | --- | --- | --- | --- | --- | --- |
| 249 | 1.5.3.2 | **FM 2** |  | 35d | 2004-03-15 A | 2004-04-30 |  | 21% | 27.71d | 2004-02-10 | 2004-04-15 | 47d | 56d |  |  |  |
| 250 | 1.5.3.2.1 | SWEA FM 2 Final Assembly (Block 2) |  | 5d | 2004-03-15 A | 2004-03-19 A |  | 100% |  | 2004-02-10 | 2004-02-12 | 3d |  |  | start no earlier than 2004-03-15 |  |
| 251 | 1.5.3.2.2 | SWEA FM 2 Calibration |  | 19d | 2004-04-06 | 2004-04-30 | 250FS+11d |  |  | 2004-02-13 | 2004-04-15 | 44d | 56d | 0d |  | MS-BOOM |
| 252 | 1.5.4 | **STE - UCB** |  | 196d | 2003-08-29 A | 2004-06-10 |  | 70% | 58.4d | 2003-08-29 | 2004-05-10 | 174d | 49d |  |  |  |
| 253 | 1.5.4.1 | **Deliveries** |  | 38d | 2004-04-16 | 2004-06-10 |  |  |  | 2004-04-14 | 2004-05-10 | 18d | 22d |  |  |  |
| 254 | 1.5.4.1.1 | Deliver STE-D FM 1 (stays at UCB for SWEA/STE-D FM 1 I&T) | milestone | 0d | 2004-04-16 | 2004-04-16 | 269 |  |  | 2004-04-14 | 2004-04-14 | 0d | 22d | 15d |  | MS-BOOM |
| 255 | 1.5.4.1.2 | Deliver STE-D FM 2 (stays at UCB for SWEA/STE-D FM 2 I&T) | milestone | 0d | 2004-06-10 | 2004-06-10 | 277 |  |  | 2004-05-10 | 2004-05-10 | 0d | 31d | 17d |  | MS-BOOM |
| 256 | 1.5.4.1.3 | Deliver STE-U FM 1 (stays at UCB for BOOM Suite FM 1 I&T) | milestone | 0d | 2004-04-22 | 2004-04-22 | 270 |  |  | 2004-04-20 | 2004-04-20 | 0d | 21d | 1d |  | MS-BOOM |
| 257 | 1.5.4.1.4 | Deliver STE-U FM 2 (stays at UCB for BOOM Suite FM 2 I&T) | milestone | 0d | 2004-06-10 | 2004-06-10 | 278 |  |  | 2004-05-10 | 2004-05-10 | 0d | 49d | 0d |  | MS-BOOM |
| 258 | 1.5.4.2 | **STE-U/D Housing** |  | 53d | 2003-11-21 A | 2004-02-09 A |  | 100% |  | 2003-11-21 | 2004-02-09 | 53d |  |  |  |  |
| 259 | 1.5.4.2.1 | Fabricate STE FM 1 Box |  | 53d | 2003-11-21 A | 2004-02-09 A |  | 100% |  | 2003-11-21 | 2004-02-09 | 53d |  |  | start no earlier than 2003-11-21 |  |
| 260 | 1.5.4.2.2 | Fabricate STE FM 2 Box |  | 53d | 2003-11-21 A | 2004-02-09 A |  | 100% |  | 2003-11-21 | 2004-02-09 | 53d |  |  | start no earlier than 2003-11-21 |  |
| 261 | 1.5.4.3 | **STE-U/D Detector Boards** |  | 196d | 2003-08-29 A | 2004-06-10 |  | 61% | 76.77d | 2003-08-29 | 2004-05-10 | 174d | 49d |  |  |  |
| 262 | 1.5.4.3.1 | Coupon Test STE FM 1 & FM 2 Detector Printed Wiring Board |  | 17d | 2003-10-10 A | 2003-11-04 A | 264, 272 | 100% |  | 2003-10-10 | 2003-11-04 | 17d |  |  | start no earlier than 2003-10-10 |  |
| 263 | 1.5.4.3.2 | **FM 1** |  | 162d | 2003-08-29 A | 2004-04-22 |  | 64% | 57.93d | 2003-08-29 | 2004-04-20 | 160d | 21d |  |  |  |
| 264 | 1.5.4.3.2.1 | Fabrication STE FM 1 Detector Printed Wiring Board |  | 29d | 2003-08-29 A | 2003-10-09 A |  | 100% |  | 2003-08-29 | 2003-10-09 | 29d |  |  | start no earlier than 2003-08-29 |  |
| 265 | 1.5.4.3.2.2 | Load STE FM 1 Detector Printed Wiring Board |  | 60d | 2003-11-05 A | 2004-02-03 A | 262 | 100% |  | 2003-11-05 | 2004-02-03 | 60d |  |  |  |  |
| 266 | 1.5.4.3.2.3 | Test STE FM 1 Detector Printed Wiring Board |  | 10d | 2004-02-04 A | 2004-02-18 A | 265 | 100% |  | 2004-02-04 | 2004-02-18 | 10d |  |  |  |  |
| 267 | 1.5.4.3.2.4 | **Integration & Test** |  | 46d | 2004-02-19 A | 2004-04-22 |  | 11% | 41.12d | 2004-02-19 | 2004-04-20 | 44d | 21d |  |  |  |
| 268 | 1.5.4.3.2.4.1 | Integrate & Test STE-U/D FM 1 Detectors W/ FM 1 Housings |  | 34d | 2004-02-19 A | 2004-04-06 | 259, 266 | 21% | 27d | 2004-02-19 | 2004-03-17 | 20d | 21d | 0d |  |  |
| 269 | 1.5.4.3.2.4.2 | Calibrate STE-U/D FM 1 |  | 18d | 2004-03-24 | 2004-04-16 | 268FS-10d |  |  | 2004-03-18 | 2004-04-14 | 20d | 21d | 0d |  |  |
| 270 | 1.5.4.3.2.4.3 | STE-U FM 1 Thermal Vacuum/Balance/Bake Out |  | 14d | 2004-04-05 | 2004-04-22 | 269FS-10d |  |  | 2004-04-01 | 2004-04-20 | 14d | 21d | 0d |  |  |
| 271 | 1.5.4.3.3 | **FM 2** |  | 196d | 2003-08-29 A | 2004-06-10 |  | 53% | 92.31d | 2003-08-29 | 2004-05-10 | 174d | 49d |  |  |  |
| 272 | 1.5.4.3.3.1 | Fabricate STE FM 2 Detector Printed Wiring Board |  | 29d | 2003-08-29 A | 2003-10-09 A |  | 100% |  | 2003-08-29 | 2003-10-09 | 29d |  |  | start no earlier than 2003-08-29 |  |
| 273 | 1.5.4.3.3.2 | Load STE FM 2 Detector Printed Wiring Board |  | 63d | 2003-11-05 A | 2004-03-12 | 262, 266FF+17d | 84% | 10d | 2003-11-05 | 2004-03-17 | 63d | 51d | 0d |  |  |
| 274 | 1.5.4.3.3.3 | Test STE FM 2 Detector Printed Wiring Board |  | 5d | 2004-03-15 | 2004-03-19 | 273 |  |  | 2004-03-18 | 2004-03-31 | 10d | 51d | 20d |  |  |

| ID | WBS | Task | Type | Duration | Start | Finish | Predecessors | Complete | Remaining | Baseline start | Baseline finish | Baseline duration | Total slack | Free slack | Constraint | Text1 |
| --- | --- | --- | --- | --- | --- | --- | --- | --- | --- | --- | --- | --- | --- | --- | --- | --- |
| 275 | 1.5.4.3.3.4 | **Integration & Test** |  | 38d | 2004-04-19 | 2004-06-10 |  |  |  | 2004-04-01 | 2004-05-10 | 28d | 31d |  |  |  |
| 276 | 1.5.4.3.3.4.1 | Integrate & Test STE-U/D FM 2 Detectors W/ FM 2 Housings |  | 20d | 2004-04-19 | 2004-05-14 | 260, 274, 268FS-10d, 269 |  |  | 2004-04-01 | 2004-04-14 | 10d | 31d | 0d |  |  |
| 277 | 1.5.4.3.3.4.2 | Calibrate STE-U/D FM 2 |  | 28d | 2004-05-03 | 2004-06-10 | 276FS-10d |  |  | 2004-04-15 | 2004-05-10 | 18d | 31d | 0d |  |  |
| 278 | 1.5.4.3.3.4.3 | STE-U FM 2 Thermal Vacuum/Bake Out |  | 10d | 2004-05-27 | 2004-06-10 | 277FS-10d |  |  | 2004-04-27 | 2004-05-10 | 10d | 49d | 0d |  |  |
| 279 | 1.5.5 | **STE and SWEA - UCB** |  | 300d | 2003-07-01 A | 2004-09-07 |  | 72% | 83.15d | 2003-07-01 | 2004-08-27 | 294d | 14d |  |  |  |
| 280 | 1.5.5.1 | **Deliveries** |  | 115d | 2004-03-26 | 2004-09-07 |  |  |  | 2004-02-27 | 2004-08-27 | 129d | 14d |  |  |  |
| 281 | 1.5.5.1.1 | Deliver STE-U FM 1 Interface (stays at UCB for IDPU FM 1 I&T) | milestone | 0d | 2004-03-26 | 2004-03-26 | 330 |  |  | 2004-02-27 | 2004-02-27 | 0d | 49d | 36d |  | MS-BOOM |
| 282 | 1.5.5.1.2 | Deliver STE-U FM 2 Interface (stays at UCB for IDPU FM 2 I&T) | milestone | 0d | 2004-04-02 | 2004-04-02 | 339 |  |  | 2004-03-01 | 2004-03-01 | 0d | 80d | 61d |  | MS-BOOM |
| 283 | 1.5.5.1.3 | Deliver SWEA/STE-D FM 1 (stays at UCB for Boom Suite FM 1 I&T) | milestone | 0d | 2004-06-21 | 2004-06-21 | 336 |  |  | 2004-06-11 | 2004-06-11 | 0d | 7d | 0d |  | MS-BOOM |
| 284 | 1.5.5.1.4 | Deliver SWEA/STE-D FM 2 (stays at UCB for Boom Suite FM 2 I&T) | milestone | 0d | 2004-09-07 | 2004-09-07 | 345 |  |  | 2004-08-27 | 2004-08-27 | 0d | 14d | 0d |  | MS-BOOM |
| 285 | 1.5.5.2 | **SWEA Pedestal** |  | 152d | 2003-07-01 A | 2004-02-09 A |  | 100% |  | 2003-07-01 | 2004-02-09 | 152d |  |  |  |  |
| 286 | 1.5.5.2.1 | Fabricate SWEA FM 1 Baseplate |  | 152d | 2003-07-01 A | 2004-02-09 A |  | 100% |  | 2003-07-01 | 2004-02-09 | 152d |  |  | start no earlier than 2003-07-01 |  |
| 287 | 1.5.5.2.2 | Fabricate SWEA FM 2 Baseplate |  | 152d | 2003-07-01 A | 2004-02-09 A |  | 100% |  | 2003-07-01 | 2004-02-09 | 152d |  |  | start no earlier than 2003-07-01 |  |
| 288 | 1.5.5.3 | **STE-D Pre-Amp Board** |  | 119d | 2003-09-22 A | 2004-03-15 |  | 89% | 12.8d | 2003-09-22 | 2004-02-23 | 104d | 63d |  |  |  |
| 289 | 1.5.5.3.1 | **FM 1** |  | 119d | 2003-09-22 A | 2004-03-15 |  | 87% | 15.26d | 2003-09-22 | 2004-02-23 | 104d | 16d |  |  |  |
| 290 | 1.5.5.3.1.1 | Fabricate STE-D FM 1 Preamp Printed Wiring Board |  | 34d | 2003-09-22 A | 2003-11-07 A |  | 100% |  | 2003-09-22 | 2003-11-07 | 34d |  |  | start no earlier than 2003-09-22 |  |
| 291 | 1.5.5.3.1.2 | Load STE-D FM 1 Preamp Printed Wiring Board |  | 5d | 2004-03-09 | 2004-03-15 | 295 |  |  | 2004-02-17 | 2004-02-23 | 5d | 16d | 0d | start no earlier than 2004-03-09 |  |
| 292 | 1.5.5.3.2 | **FM 2** |  | 119d | 2003-09-22 A | 2004-03-15 |  | 87% | 15.26d | 2003-09-22 | 2004-02-23 | 104d | 63d |  |  |  |
| 293 | 1.5.5.3.2.1 | Fabricate STE-D FM 2 Preamp Printed Wiring Board |  | 34d | 2003-09-22 A | 2003-11-07 A |  | 100% |  | 2003-09-22 | 2003-11-07 | 34d |  |  | start no earlier than 2003-09-22 |  |
| 294 | 1.5.5.3.2.2 | Load STE-D FM 2 Preamp Printed Wiring Board |  | 5d | 2004-03-09 | 2004-03-15 | 291SS |  |  | 2004-02-17 | 2004-02-23 | 5d | 63d | 49d |  |  |
| 295 | 1.5.5.3.3 | Coupon Test STE-D FM 1 & FM 2 Pre-Amp Printed Wiring Boards |  | 15d | 2003-11-10 A | 2003-12-02 A | 290, 293 | 100% |  | 2003-11-10 | 2003-12-02 | 15d |  |  |  |  |
| 296 | 1.5.5.4 | **STE-D Shaper Board** |  | 118d | 2003-12-04 A | 2004-05-21 |  | 78% | 26.22d | 2003-12-04 | 2004-05-13 | 112d | 14d |  |  |  |
| 297 | 1.5.5.4.1 | **FM 1** |  | 67d | 2003-12-04 A | 2004-03-11 |  | 67% | 22.33d | 2003-12-04 | 2004-02-20 | 53d | 18d |  |  |  |
| 298 | 1.5.5.4.1.1 | Fabricate STE-D FM 1 Shaper Printed Wiring Board |  | 10d | 2003-12-04 A | 2003-12-17 A |  | 100% |  | 2003-12-04 | 2003-12-17 | 10d |  |  | start no earlier than 2003-12-04 |  |
| 299 | 1.5.5.4.1.2 | Load STE-D FM 1 Shaper Printed Wiring Board |  | 5d | 2004-03-05 | 2004-03-11 | 303 |  |  | 2004-02-13 | 2004-02-20 | 5d | 18d | 0d | start no earlier than 2004-03-05 |  |

| ID | WBS | Task | Duration | Start | Finish | Predecessors | Complete | Remaining | Baseline start | Baseline finish | Baseline duration | Total slack | Free slack | Constraint |
| --- | --- | --- | --- | --- | --- | --- | --- | --- | --- | --- | --- | --- | --- | --- |
| 300 | 1.5.5.4.2 | **FM 2** | 118d | 2003-12-04 A | 2004-05-21 |  | 67% | 39.33d | 2003-12-04 | 2004-05-13 | 112d | 14d |  |  |
| 301 | 1.5.5.4.2.1 | Fabricate STE-D FM 2 Shaper Printed Wiring Board | 10d | 2003-12-04 A | 2003-12-17 A |  | 100% |  | 2003-12-04 | 2003-12-17 | 10d |  |  | start no earlier than 2003-12-04 |
| 302 | 1.5.5.4.2.2 | Load STE-D FM 2 Shaper Printed Wiring Board | 5d | 2004-05-17 | 2004-05-21 | 303, 334 |  |  | 2004-05-07 | 2004-05-13 | 5d | 14d | 0d |  |
| 303 | 1.5.5.4.3 | Coupon Test STE-D FM 1 & FM 2 Shaper Printed Wiring Boards | 15d | 2003-12-18 A | 2004-01-09 A | 298, 301 | 100% |  | 2003-12-18 | 2004-01-09 | 15d |  |  |  |
| 304 | 1.5.5.5 | **STE-D Interface Board** | 118d | 2003-12-04 A | 2004-05-21 |  | 78% | 26.22d | 2003-12-04 | 2004-05-13 | 112d | 14d |  |  |
| 305 | 1.5.5.5.1 | **FM 1** | 67d | 2003-12-04 A | 2004-03-11 |  | 67% | 22.33d | 2003-12-04 | 2004-02-20 | 53d | 18d |  |  |
| 306 | 1.5.5.5.1.1 | Fabricate SWEA / STE-D FM 1 Digital to Analog Converter Printed Wiring Board | 10d | 2003-12-04 A | 2003-12-17 A |  | 100% |  | 2003-12-04 | 2003-12-17 | 10d |  |  | start no earlier than 2003-12-04 |
| 307 | 1.5.5.5.1.2 | Load SWEA / STE-D FM 1 Digital to Analog Converter Printed Wiring Board | 5d | 2004-03-05 | 2004-03-11 | 299SS |  |  | 2004-02-13 | 2004-02-20 | 5d | 18d | 2d |  |
| 308 | 1.5.5.5.2 | **FM 2** | 118d | 2003-12-04 A | 2004-05-21 |  | 67% | 39.33d | 2003-12-04 | 2004-05-13 | 112d | 14d |  |  |
| 309 | 1.5.5.5.2.1 | Fabricate SWEA / STE-D FM 2 Digital to Analog Converter Printed Wiring Board | 10d | 2003-12-04 A | 2003-12-17 A |  | 100% |  | 2003-12-04 | 2003-12-17 | 10d |  |  | start no earlier than 2003-12-04 |
| 310 | 1.5.5.5.2.2 | Load SWEA / STE-D FM 2 Digital to Analog Converter Printed Wiring Board | 5d | 2004-05-17 | 2004-05-21 | 302SS |  |  | 2004-05-07 | 2004-05-13 | 5d | 14d | 0d |  |
| 311 | 1.5.5.5.3 | Coupon Test STE-D FM 1 & FM 2 D/A Converter Printed Wiring Boards | 15d | 2003-12-18 A | 2004-01-09 A | 306, 309 | 100% |  | 2003-12-18 | 2004-01-09 | 15d |  |  |  |
| 312 | 1.5.5.6 | **STE-U Pre-Amp Board** | 119d | 2003-09-22 A | 2004-03-15 |  | 95% | 6.47d | 2003-09-22 | 2004-02-23 | 104d | 89d |  |  |
| 313 | 1.5.5.6.1 | **FM 1** | 79d | 2003-09-22 A | 2004-01-15 A |  | 100% |  | 2003-09-22 | 2004-01-15 | 79d |  |  |  |
| 314 | 1.5.5.6.1.1 | Fabricate STE-U FM 1 Preamp Printed Wiring Board | 34d | 2003-09-22 A | 2003-11-07 A |  | 100% |  | 2003-09-22 | 2003-11-07 | 34d |  |  | start no earlier than 2003-09-22 |
| 315 | 1.5.5.6.1.2 | Load STE-U FM 1 Preamp Printed Wiring Board | 4d | 2004-01-12 A | 2004-01-15 A | 319 | 100% |  | 2004-01-12 | 2004-01-15 | 4d |  |  | start no earlier than 2004-01-12 |
| 316 | 1.5.5.6.2 | **FM 2** | 119d | 2003-09-22 A | 2004-03-15 |  | 87% | 15.26d | 2003-09-22 | 2004-02-23 | 104d | 89d |  |  |
| 317 | 1.5.5.6.2.1 | Fabricate STE-U FM 2 Preamp Printed Wiring Board | 34d | 2003-09-22 A | 2003-11-07 A |  | 100% |  | 2003-09-22 | 2003-11-07 | 34d |  |  | start no earlier than 2003-09-22 |
| 318 | 1.5.5.6.2.2 | Load STE-U FM 2 Preamp Printed Wiring Board | 5d | 2004-03-09 | 2004-03-15 | 319 |  |  | 2004-02-17 | 2004-02-23 | 5d | 89d | 9d | start no earlier than 2004-03-09 |
| 319 | 1.5.5.6.3 | Coupon Test STE-U FM 1 & FM 2 Pre-Amp Printed Wiring Boards | 15d | 2003-11-10 A | 2003-12-02 A | 314, 317 | 100% |  | 2003-11-10 | 2003-12-02 | 15d |  |  |  |
| 320 | 1.5.5.7 | **STE-U Shaper & Interface Board** | 78d | 2003-12-04 A | 2004-03-26 |  | 66% | 26.49d | 2003-12-04 | 2004-02-20 | 53d | 80d |  |  |
| 321 | 1.5.5.7.1 | **FM 1** | 73d | 2003-12-04 A | 2004-03-19 |  | 43% | 41.26d | 2003-12-04 | 2004-02-20 | 53d | 49d |  |  |
| 322 | 1.5.5.7.1.1 | Fabricate STE-U FM 1Shaper & Interface Printed Wiring Board | 10d | 2003-12-04 A | 2003-12-17 A |  | 100% |  | 2003-12-04 | 2003-12-17 | 10d |  |  | start no earlier than 2003-12-04 |
| 323 | 1.5.5.7.1.2 | Load STE-U FM 1 Shaper & Interface Printed Wiring Board | 13d | 2004-03-03 | 2004-03-19 | 327 |  |  | 2004-02-13 | 2004-02-20 | 5d | 49d | 0d | start no earlier than 2004-03-03 |

| ID | WBS | Task | Duration | Start | Finish | Predecessors | Complete | Remaining | Baseline start | Baseline finish | Baseline duration | Total slack | Free slack | Constraint | Text1 |
| --- | --- | --- | --- | --- | --- | --- | --- | --- | --- | --- | --- | --- | --- | --- | --- |
| 324 | 1.5.5.7.2 | **FM 2** | 78d | 2003-12-04 A | 2004-03-26 |  | 67% | 26d | 2003-12-04 | 2004-02-20 | 53d | 80d |  |  |  |
| 325 | 1.5.5.7.2.1 | Fabricate STE-U FM 2 Shaper & Interface Printed Wiring Board | 10d | 2003-12-04 A | 2003-12-17 A |  | 100% |  | 2003-12-04 | 2003-12-17 | 10d |  |  | start no earlier than 2003-12-04 |  |
| 326 | 1.5.5.7.2.2 | Load STE-U FM 2 Shaper & Interface Printed Wiring Board | 5d | 2004-03-22 | 2004-03-26 | 323 |  |  | 2004-02-13 | 2004-02-20 | 5d | 80d | 0d |  |  |
| 327 | 1.5.5.7.3 | Coupon Test STE-U FM 1 & FM 2 Shaper & Interface Printed Wiring Boards | 15d | 2003-12-18 A | 2004-01-09 A | 322, 325 | 100% |  | 2003-12-18 | 2004-01-09 | 15d |  |  |  |  |
| 328 | 1.5.5.8 | **Integration & Test** | 124d | 2004-03-16 | 2004-09-07 |  |  |  | 2004-02-23 | 2004-08-27 | 134d | 14d |  |  |  |
| 329 | 1.5.5.8.1 | **FM 1** | 124d | 2004-03-16 | 2004-09-07 |  |  |  | 2004-02-23 | 2004-07-30 | 114d | 11d |  |  |  |
| 330 | 1.5.5.8.1.1 | Integrate & Test STE-U FM 1 Interface Boards | 5d | 2004-03-22 | 2004-03-26 | 315, 323 |  |  | 2004-02-23 | 2004-02-27 | 5d | 49d | 0d |  |  |
| 331 | 1.5.5.8.1.2 | Integrate & Test SWEA/STE-D FM 1 Interface Boards | 20d | 2004-03-16 | 2004-04-12 | 286, 291, 299, 307 |  |  | 2004-02-24 | 2004-03-22 | 20d | 16d | 0d |  |  |
| 332 | 1.5.5.8.1.3 | Integrate & Test SWEA/STE-D FM 1 Interface with SWEA/STE-D FM 1 LVPS | 10d | 2004-04-26 | 2004-05-07 | 331, 69 |  |  | 2004-04-16 | 2004-04-29 | 10d | 7d | 0d |  |  |
| 333 | 1.5.5.8.1.4 | Clean/Coat/Stake SWEA/STE-D Interface | 10d | 2004-04-13 | 2004-04-26 | 331 |  |  | 2004-03-23 | 2004-04-05 | 10d | 16d | 9d |  |  |
| 334 | 1.5.5.8.1.5 | Integrate & Test SWEA/STE-D FM 1 Combined | 5d | 2004-05-10 | 2004-05-14 | 332, 333, 247, 254 |  |  | 2004-04-30 | 2004-05-06 | 5d | 7d | 0d |  |  |
| 335 | 1.5.5.8.1.6 | Calibrate SWEA/STE FM 1 | 20d | 2004-05-17 | 2004-06-14 | 334 |  |  | 2004-05-07 | 2004-06-04 | 20d | 7d | 0d |  |  |
| 336 | 1.5.5.8.1.7 | SWEA/STE FM 1 Vibration | 5d | 2004-06-15 | 2004-06-21 | 335 |  |  | 2004-06-07 | 2004-06-11 | 5d | 7d | 0d |  |  |
| 337 | 1.5.5.8.1.8 | SWEA/STE-D FM 1 Thermal Vac/Thermal Balance/Bake Out | 14d | 2004-08-18 | 2004-09-07 | 19 |  |  | 2004-07-13 | 2004-07-30 | 14d | 11d | 0d |  |  |
| 338 | 1.5.5.8.2 | **FM 2** | 115d | 2004-03-29 | 2004-09-07 |  |  |  | 2004-02-24 | 2004-08-27 | 133d | 14d |  |  |  |
| 339 | 1.5.5.8.2.1 | Integrate & Test STE-U FM 2 Interface Boards | 5d | 2004-03-29 | 2004-04-02 | 318, 326 |  |  | 2004-02-24 | 2004-03-01 | 5d | 80d | 0d |  |  |
| 340 | 1.5.5.8.2.2 | Integrate & Test SWEA/STE-D FM 2 Interface Boards | 20d | 2004-05-24 | 2004-06-21 | 287, 294, 302, 310 |  |  | 2004-05-14 | 2004-06-11 | 20d | 14d | 0d |  |  |
| 341 | 1.5.5.8.2.3 | Integrate & Test SWEA/STE-D FM 2 Interface with SWEA/STE-D FM 2 LVPS | 10d | 2004-06-22 | 2004-07-05 | 340, 75 |  |  | 2004-06-14 | 2004-06-25 | 10d | 14d | 0d |  |  |
| 342 | 1.5.5.8.2.4 | Integrate & Test SWEA/STE-D FM 2 Combined | 10d | 2004-07-06 | 2004-07-19 | 341, 248, 255 |  |  | 2004-06-28 | 2004-07-09 | 10d | 14d | 0d |  |  |
| 343 | 1.5.5.8.2.5 | Calibrate SWEA/STE FM 2 | 20d | 2004-07-20 | 2004-08-16 | 342 |  |  | 2004-07-12 | 2004-08-06 | 20d | 14d | 0d |  |  |
| 344 | 1.5.5.8.2.6 | SWEA/STE FM 2 Vibration | 5d | 2004-08-17 | 2004-08-23 | 343 |  |  | 2004-08-09 | 2004-08-13 | 5d | 14d | 0d |  |  |
| 345 | 1.5.5.8.2.7 | SWEA/STE-D FM 2 Thermal Vac & bake Out | 10d | 2004-08-24 | 2004-09-07 | 344 |  |  | 2004-08-16 | 2004-08-27 | 10d | 14d | 0d |  |  |
| 346 | 1.5.6 | **Boom Suite I&T - UCB** | 116d | 2004-04-26 | 2004-10-06 |  |  |  | 2004-04-21 | 2004-09-28 | 113d | 14d |  |  |  |
| 347 | 1.5.6.1 | **FM 1** | 105d | 2004-04-26 | 2004-09-21 |  |  |  | 2004-04-21 | 2004-08-13 | 82d | 11d |  |  |  |
| 348 | 1.5.6.1.1 | FM 1 Boom/MAG/STE-U I&T | 4d | 2004-04-26 | 2004-04-29 | 209, 237, 256 |  |  | 2004-04-21 | 2004-04-26 | 4d | 20d | 0d |  | MS-BOOM |
| 349 | 1.5.6.1.2 | FM 1 Boom/SWEA/STE/MAG I&T | 2d | 2004-06-22 | 2004-06-23 | 283, 183 |  |  | 2004-06-14 | 2004-06-15 | 2d | 7d | 0d |  |  |
| 350 | 1.5.6.1.3 | FM 1 Integrated Boom/IDPU I&T | 4d | 2004-06-24 | 2004-06-29 | 349, 183, 159 |  |  | 2004-06-16 | 2004-06-21 | 4d | 7d |  |  |  |
| 351 | 1.5.6.1.4 | Final BOOM Suite FM 1 I & T | 10d | 2004-09-08 | 2004-09-21 | 350, 337 |  |  | 2004-08-02 | 2004-08-13 | 10d | 11d | 0d |  |  |

| ID | WBS | Task | Duration | Start | Finish | Predecessors | Complete | Remaining | Baseline start | Baseline finish | Baseline duration | Total slack | Free slack | Constraint | Text1 |
| --- | --- | --- | --- | --- | --- | --- | --- | --- | --- | --- | --- | --- | --- | --- | --- |
| 352 | 1.5.6.2 | **FM 2** | 83d | 2004-06-11 | 2004-10-06 |  |  |  | 2004-05-11 | 2004-09-28 | 99d | 14d |  |  |  |
| 353 | 1.5.6.2.1 | FM 2 Boom/MAG/STE-U I&T | 4d | 2004-06-11 | 2004-06-16 | 231, 238, 257 |  |  | 2004-05-11 | 2004-05-14 | 4d | 49d | 0d |  | MS-BOOM |
| 354 | 1.5.6.2.2 | FM 2 Boom/SWEA/STE/MAG I&T | 2d | 2004-09-08 | 2004-09-09 | 284, 184 |  |  | 2004-08-30 | 2004-08-31 | 2d | 14d | 0d |  |  |
| 355 | 1.5.6.2.3 | FM 2 Integrated Boom/IDPU I&T | 4d | 2004-09-10 | 2004-09-15 | 354, 184, 762 |  |  | 2004-09-01 | 2004-09-07 | 4d | 14d | 0d |  |  |
| 356 | 1.5.6.2.4 | Boom Suite FM 2 EMC | 5d | 2004-09-16 | 2004-09-22 | 355 |  |  | 2004-09-08 | 2004-09-14 | 5d | 14d | 0d |  | MS-BOOM |
| 357 | 1.5.6.2.5 | Final BOOM Suite FM 2 I & T | 10d | 2004-09-23 | 2004-10-06 | 356 |  |  | 2004-09-15 | 2004-09-28 | 10d | 14d | 0d |  |  |
| 358 | 1.6 | **SEP Suite - CIT** | 355d | 2003-06-02 A | 2004-10-26 |  | 56% | 156.46d | 2003-06-02 | 2004-10-21 | 352d | 277d |  |  |  |
| 359 | 1.6.1 | **SEP Mechanical - Sandy Shuman (GSFC)** | 115d | 2004-01-27 A | 2004-07-07 |  | 27% | 84.42d | 2004-01-27 | 2004-06-02 | 90d | 26d |  |  |  |
| 360 | 1.6.1.1 | **SIT Electronics Enclosure (Priority 1)** | 59d | 2004-02-09 A | 2004-04-30 |  | 37% | 37.15d | 2004-02-09 | 2004-03-16 | 26d | 28d |  |  |  |
| 361 | 1.6.1.1.1 | Complete Design/Drawings for SIT Enclosure | 10d | 2004-02-09 A | 2004-02-23 A |  | 100% |  | 2004-02-09 | 2004-02-23 | 10d |  |  | start no earlier than 2004-02-09 |  |
| 362 | 1.6.1.1.2 | Fabrication of SIT Enclosure | 10d | 2004-04-08 | 2004-04-21 | 361FS+32d |  |  | 2004-02-24 | 2004-03-08 | 10d | 28d | 0d |  |  |
| 363 | 1.6.1.1.3 | Inspection and Final Assembly of SIT Enclosure | 6d | 2004-04-22 | 2004-04-29 | 362 |  |  | 2004-03-09 | 2004-03-15 | 5d | 28d | 0d |  |  |
| 364 | 1.6.1.1.4 | Deliver SIT Enclosure to UMD | 1d | 2004-04-30 | 2004-04-30 | 363 |  |  | 2004-03-16 | 2004-03-16 | 1d | 28d | 27d |  |  |
| 365 | 1.6.1.2 | **SEP FM 1 & FM 2 LVPS Boxes (Priority 2)** | 57d | 2004-02-09 A | 2004-04-28 |  | 75% | 13.98d | 2004-02-09 | 2004-03-11 | 23d | 13d |  |  |  |
| 366 | 1.6.1.2.1 | Complete Design/Drawings for SEP LVPS Boxes | 5d | 2004-02-09 A | 2004-02-13 A | 361SS | 100% |  | 2004-02-09 | 2004-02-13 | 5d |  |  |  |  |
| 367 | 1.6.1.2.2 | Fabrication of SEP LVPS Boxes | 35d | 2004-02-17 A | 2004-04-05 A | 366 | 100% |  | 2004-02-17 | 2004-03-01 | 10d |  |  |  |  |
| 368 | 1.6.1.2.3 | Inspection and Final Assembly of SEP LVPS Boxes | 10d | 2004-04-12 | 2004-04-23 | 367FS+4d |  |  | 2004-03-02 | 2004-03-08 | 5d | 13d | 0d |  |  |
| 369 | 1.6.1.2.4 | Deliver SEP LVPS Boxes to UCB | 3d | 2004-04-26 | 2004-04-28 | 368 |  |  | 2004-03-09 | 2004-03-11 | 3d | 13d | 0d | start no earlier than 2004-04-07 |  |
| 370 | 1.6.1.3 | **SEP Electronics Enclosure (Priority 3)** | 69d | 2004-02-17 A | 2004-05-21 |  | 46% | 37d | 2004-02-17 | 2004-03-30 | 31d | 24d |  |  |  |
| 371 | 1.6.1.3.1 | Complete Design/Drawings for SEP Enclosure | 45d | 2004-02-17 A | 2004-04-19 | 366 | 71% | 13d | 2004-02-17 | 2004-03-04 | 13d | -10d | 0d |  |  |
| 372 | 1.6.1.3.2 | Fabrication of SEP Enclosure | 15d | 2004-04-20 | 2004-05-10 | 371 |  |  | 2004-03-05 | 2004-03-18 | 10d | 24d | 0d |  |  |
| 373 | 1.6.1.3.3 | Inspection and Final Assembly of SEP Enclosure | 6d | 2004-05-11 | 2004-05-18 | 372 |  |  | 2004-03-19 | 2004-03-25 | 5d | 24d | 0d |  |  |
| 374 | 1.6.1.3.4 | Deliver SEP Enclosure to CIT | 3d | 2004-05-19 | 2004-05-21 | 373 |  |  | 2004-03-26 | 2004-03-30 | 3d | 24d | 20d |  | MS-SEP |
| 375 | 1.6.1.4 | **SEP Central Bias Supply Shields (Priority 4)** | 20d | 2004-04-15 | 2004-05-12 |  |  |  | 2004-03-05 | 2004-04-01 | 20d | -10d | 0d |  |  |
| 376 | 1.6.1.4.1 | Complete Design/Drawings for Bias Supply Shields | 5d | 2004-04-15 | 2004-04-21 | 371FS-3d |  |  | 2004-03-05 | 2004-03-11 | 5d | -10d | 0d |  |  |
| 377 | 1.6.1.4.2 | Fabrication of Bias Supply Shields | 10d | 2004-04-22 | 2004-05-05 | 376 |  |  | 2004-03-12 | 2004-03-25 | 10d | -10d | 0d |  |  |
| 378 | 1.6.1.4.3 | Inspection and Delivery (to CIT) of Bias Supply Shields | 5d | 2004-05-06 | 2004-05-12 | 377 |  |  | 2004-03-26 | 2004-04-01 | 5d | -10d | 0d |  |  |

| ID | WBS | Task | Type | Duration | Start | Finish | Predecessors | Complete | Remaining | Baseline start | Baseline finish | Baseline duration | Total slack | Free slack | Constraint | Text1 |
| --- | --- | --- | --- | --- | --- | --- | --- | --- | --- | --- | --- | --- | --- | --- | --- | --- |
| 379 | 1.6.1.5 | **LET Telescope (Priority 5)** |  | 29d | 2004-04-22 | 2004-06-02 |  |  |  | 2004-03-12 | 2004-04-16 | 26d | 0d |  |  |  |
| 380 | 1.6.1.5.1 | Complete Design/Drawings for LET Telescope |  | 8d | 2004-04-22 | 2004-05-03 | 376 |  |  | 2004-03-12 | 2004-03-23 | 8d | 0d |  |  |  |
| 381 | 1.6.1.5.2 | Fabrication of LET Telescope |  | 10d | 2004-05-04 | 2004-05-17 | 380 |  |  | 2004-03-24 | 2004-04-06 | 10d | 3d | 0d |  |  |
| 382 | 1.6.1.5.3 | Inspection and Final Assembly of LET Telescope (CIT has detectors) |  | 8d | 2004-05-18 | 2004-05-27 | 381 |  |  | 2004-04-07 | 2004-04-13 | 5d | 3d | 0d |  |  |
| 383 | 1.6.1.5.4 | Deliver LET Telescope to CIT |  | 3d | 2004-05-28 | 2004-06-02 | 382 |  |  | 2004-04-14 | 2004-04-16 | 3d | 3d |  |  |  |
| 384 | 1.6.1.6 | **HET Electronics Enclosure (Priority 6)** |  | 47d | 2004-03-22 A | 2004-05-25 |  | 21% | 37.11d | 2004-03-24 | 2004-04-23 | 23d | -3d | 0d |  |  |
| 385 | 1.6.1.6.1 | Complete Design/Drawings for HET Enclosure |  | 23d | 2004-03-22 A | 2004-05-04 | 380FS-14d | 35% | 15d | 2004-03-24 | 2004-04-02 | 8d | 0d |  |  |  |
| 386 | 1.6.1.6.2 | Fabrication of HET Enclosure |  | 10d | 2004-05-05 | 2004-05-18 | 385 |  |  | 2004-04-05 | 2004-04-16 | 10d | -3d | 0d |  |  |
| 387 | 1.6.1.6.3 | Inspection and Final Assembly of HET Enclosure |  | 5d | 2004-05-19 | 2004-05-25 | 386 |  |  | 2004-04-19 | 2004-04-23 | 5d | -3d | 0d |  |  |
| 388 | 1.6.1.6.4 | Deliver HET Enclosure (stays at GSFC) | milestone | 0d | 2004-05-25 | 2004-05-25 | 387 |  |  | 2004-04-23 | 2004-04-23 | 0d | -3d | 0d |  |  |
| 389 | 1.6.1.7 | **HET Telescope (Priority 7)** |  | 92d | 2004-01-27 A | 2004-06-04 |  | 32% | 63.01d | 2004-01-27 | 2004-04-30 | 68d | -3d | 0d |  |  |
| 390 | 1.6.1.7.1 | On Going work for HET Telescope (Complete Design/Drawings & Prep for Fab) |  | 56d | 2004-01-27 A | 2004-04-14 |  | 41% | 33d | 2004-01-27 | 2004-03-31 | 46d | 1d | 0d | start no earlier than 2004-01-27 |  |
| 391 | 1.6.1.7.2 | Fabrication of HET Telescope |  | 10d | 2004-04-15 | 2004-04-28 | 390 |  |  | 2004-04-01 | 2004-04-14 | 10d | 16d |  |  |  |
| 392 | 1.6.1.7.3 | Inspection and Final Assembly of HET Telescope |  | 7d | 2004-05-26 | 2004-06-04 | 391, 388 |  |  | 2004-04-26 | 2004-04-30 | 5d | -3d | 0d |  | MS-SEP |
| 393 | 1.6.1.7.4 | Deliver HET Telescope (stays at GSFC) | milestone | 0d | 2004-06-04 | 2004-06-04 | 392 |  |  | 2004-04-30 | 2004-04-30 | 0d | -3d | 0d |  | MS-SEP |
| 394 | 1.6.1.8 | **SIT Telescope (Priority 8)** |  | 39d | 2004-04-15 | 2004-06-09 |  |  |  | 2004-04-01 | 2004-05-18 | 34d | 1d |  |  |  |
| 395 | 1.6.1.8.1 | Complete Design/Drawings for SIT Telescope |  | 18d | 2004-04-15 | 2004-05-10 | 390 |  |  | 2004-04-01 | 2004-04-26 | 18d | 1d | 0d |  |  |
| 396 | 1.6.1.8.2 | Fabrication of SIT Telescope |  | 10d | 2004-05-11 | 2004-05-24 | 395 |  |  | 2004-04-27 | 2004-05-10 | 10d | 1d | 0d |  |  |
| 397 | 1.6.1.8.3 | Inspection and Final Assembly of SIT Telescope |  | 10d | 2004-05-25 | 2004-06-08 | 396 |  |  | 2004-05-11 | 2004-05-17 | 5d | 1d | 0d |  |  |
| 398 | 1.6.1.8.4 | Deliver SIT Telescope to UMD (Includes the Foils and Detectors) |  | 1d | 2004-06-09 | 2004-06-09 | 397 |  |  | 2004-05-18 | 2004-05-18 | 1d | 1d | 0d |  |  |
| 399 | 1.6.1.9 | **Shipping Containers for HET, SIT & SEP Central (Priority 9)** |  | 23d | 2004-05-11 | 2004-06-11 |  |  |  | 2004-04-27 | 2004-05-27 | 23d | 3d |  |  |  |
| 400 | 1.6.1.9.1 | Design |  | 5d | 2004-05-11 | 2004-05-17 | 395 |  |  | 2004-04-27 | 2004-05-03 | 5d | 3d | 0d |  |  |
| 401 | 1.6.1.9.2 | Fabrication/Machining |  | 10d | 2004-05-18 | 2004-06-01 | 400 |  |  | 2004-05-04 | 2004-05-17 | 10d | 17d | 0d |  |  |
| 402 | 1.6.1.9.3 | Inspection and Assembly |  | 5d | 2004-06-02 | 2004-06-08 | 401 |  |  | 2004-05-18 | 2004-05-24 | 5d | 17d | 0d |  |  |
| 403 | 1.6.1.9.4 | HET Container stays at GSFC | milestone | 0d | 2004-06-08 | 2004-06-08 | 402 |  |  | 2004-05-24 | 2004-05-24 | 0d | 17d |  |  |  |
| 404 | 1.6.1.9.5 | SIT Container to UMD |  | 1d | 2004-06-09 | 2004-06-09 | 402 |  |  | 2004-05-25 | 2004-05-25 | 1d | 19d |  |  |  |
| 405 | 1.6.1.9.6 | SEP Central Container to CIT |  | 3d | 2004-06-09 | 2004-06-11 | 402 |  |  | 2004-05-25 | 2004-05-27 | 3d | 34d |  |  |  |

| ID | WBS | Task | Type | Duration | Start | Finish | Predecessors | Complete | Remaining | Baseline start | Baseline finish | Baseline duration | Total slack | Free slack | Constraint | Text1 |
| --- | --- | --- | --- | --- | --- | --- | --- | --- | --- | --- | --- | --- | --- | --- | --- | --- |
| 406 | 1.6.1.10 | **SIT Door (Priority 10)** |  | 27d | 2004-05-18 | 2004-06-24 |  |  |  | 2004-05-18 | 2004-06-24 | 27d | 3d |  |  |  |
| 407 | 1.6.1.10.1 | Complete Design/Drawings for SIT Door |  | 10d | 2004-05-18 | 2004-06-01 | 400 |  |  | 2004-05-18 | 2004-06-01 | 10d | 3d | 0d |  |  |
| 408 | 1.6.1.10.2 | Fabrication |  | 10d | 2004-06-02 | 2004-06-15 | 407 |  |  | 2004-06-02 | 2004-06-15 | 10d | 35d | 0d |  |  |
| 409 | 1.6.1.10.3 | Inspection |  | 5d | 2004-06-16 | 2004-06-22 | 408 |  |  | 2004-06-16 | 2004-06-22 | 5d | 35d | 0d |  |  |
| 410 | 1.6.1.10.4 | Final Assembly |  | 1d | 2004-06-23 | 2004-06-23 | 409 |  |  | 2004-06-23 | 2004-06-23 | 1d | 35d | 0d |  |  |
| 411 | 1.6.1.10.5 | Deliver SIT Door (stay at GSFC for Environmental Testing) |  | 1d | 2004-06-24 | 2004-06-24 | 410 |  |  | 2004-06-24 | 2004-06-24 | 1d | 35d |  |  |  |
| 412 | 1.6.1.11 | **LET Radiation Test Fixture (Priority 11)** |  | 26d | 2004-06-02 | 2004-07-07 |  |  |  | 2004-05-04 | 2004-06-02 | 21d | 3d |  |  |  |
| 413 | 1.6.1.11.1 | Design |  | 5d | 2004-06-02 | 2004-06-08 | 407 |  |  | 2004-05-04 | 2004-05-10 | 5d | 3d | 0d |  |  |
| 414 | 1.6.1.11.2 | Fabrication |  | 10d | 2004-06-09 | 2004-06-22 | 413 |  |  | 2004-05-11 | 2004-05-24 | 10d | 3d | 0d |  |  |
| 415 | 1.6.1.11.3 | Inspection and Assembly |  | 10d | 2004-06-23 | 2004-07-06 | 414 |  |  | 2004-05-25 | 2004-06-01 | 5d | 3d | 0d |  |  |
| 416 | 1.6.1.11.4 | Deliver to CIT for SEP I&T |  | 1d | 2004-07-07 | 2004-07-07 | 415 |  |  | 2004-06-02 | 2004-06-02 | 1d | 3d |  |  |  |
| 417 | 1.6.2 | **SEP Central - CIT** |  | 223d | 2003-08-01 A | 2004-06-21 |  | 56% | 97.13d | 2003-08-01 | 2004-06-03 | 211d | 37d |  |  |  |
| 418 | 1.6.2.1 | **Deliveries** |  | 47d | 2004-04-14 | 2004-06-21 |  |  |  | 2004-04-14 | 2004-06-03 | 35d | 37d |  |  |  |
| 419 | 1.6.2.1.1 | Deliver all SEP Cen FM 1 Boards to SEP I&T (stays at CIT) | milestone | 0d | 2004-06-21 | 2004-06-21 | 443 |  |  | 2004-05-10 | 2004-05-10 | 0d | 4d | 0d |  | MS-SEP |
| 420 | 1.6.2.1.2 | Deliver all SEP Cen FM 2 Boards & FM 2 LVPS to SEP I&T (stays at CIT) | milestone | 0d | 2004-06-21 | 2004-06-21 | 443 |  |  | 2004-05-10 | 2004-05-10 | 0d | 37d | 0d |  | MS-SEP |
| 421 | 1.6.2.1.3 | SEP Central Build 3 Software Complete | milestone | 0d | 2004-04-14 | 2004-04-14 | 445 |  |  | 2004-04-14 | 2004-04-14 | 0d | 51d | 47d |  |  |
| 422 | 1.6.2.1.4 | Final SEP Central Flight Software Complete | milestone | 0d | 2004-06-03 | 2004-06-03 | 446 |  |  | 2004-06-03 | 2004-06-03 | 0d | 30d |  |  |  |
| 423 | 1.6.2.2 | **Logic Board** |  | 30d | 2004-02-13 A | 2004-03-26 |  | 33% | 20d | 2004-02-13 | 2004-03-26 | 30d | 33d |  |  |  |
| 424 | 1.6.2.2.1 | **Assembly** |  | 10d | 2004-02-13 A | 2004-02-27 A |  | 100% |  | 2004-02-13 | 2004-02-27 | 10d |  |  |  |  |
| 425 | 1.6.2.2.1.1 | Assemble FM 1 SEP Central Logic board |  | 10d | 2004-02-13 A | 2004-02-27 A |  | 100% |  | 2004-02-13 | 2004-02-27 | 10d |  |  | start no earlier than 2004-02-13 | MS-SEP |
| 426 | 1.6.2.2.1.2 | Assemble FM 2 SEP Central Logic board |  | 10d | 2004-02-13 A | 2004-02-27 A | 425SS | 100% |  | 2004-02-13 | 2004-02-27 | 10d |  |  |  | MS-SEP |
| 427 | 1.6.2.2.2 | **Test** |  | 20d | 2004-03-01 | 2004-03-26 |  |  |  | 2004-03-01 | 2004-03-26 | 20d | 33d |  |  |  |
| 428 | 1.6.2.2.2.1 | Test FM 1 SEP Central Logic board (initial) |  | 20d | 2004-03-01 | 2004-03-26 | 425 |  |  | 2004-03-01 | 2004-03-26 | 20d | 33d |  |  |  |
| 429 | 1.6.2.2.2.2 | Test FM 2 SEP Central Logic board (initial) |  | 20d | 2004-03-01 | 2004-03-26 | 426 |  |  | 2004-03-01 | 2004-03-26 | 20d | 33d |  |  |  |

| ID | WBS | Task | Type | Duration | Start | Finish | Predecessors | Complete | Remaining | Baseline start | Baseline finish | Baseline duration | Total slack | Free slack | Constraint | Text1 |
| --- | --- | --- | --- | --- | --- | --- | --- | --- | --- | --- | --- | --- | --- | --- | --- | --- |
| 430 | 1.6.2.3 | **Analog/Post-Reg Board** |  | 0d | 2004-01-27 A | 2004-01-27 A |  | 100% |  | 2004-01-27 | 2004-01-27 | 0d |  |  |  |  |
| 431 | 1.6.2.3.1 | FM 1 Analog/Post-Reg Board Complete Test and awaiting Conformal Coat with other SEP Central Boards | milestone | 0d | 2004-01-27 A | 2004-01-27 A |  | 100% |  | 2004-01-27 | 2004-01-27 | 0d |  |  | start no earlier than 2004-01-27 |  |
| 432 | 1.6.2.3.2 | FM 2 Analog/Post-Reg Board Complete Test and awaiting Conformal Coat with other SEP Central Boards | milestone | 0d | 2004-01-27 A | 2004-01-27 A |  | 100% |  | 2004-01-27 | 2004-01-27 | 0d |  |  | start no earlier than 2004-01-27 |  |
| 433 | 1.6.2.4 | **SEP Solid State Detector Bias Supply Board** |  | 91d | 2004-01-20 A | 2004-05-26 |  | 56% | 40.04d | 2004-01-20 | 2004-04-15 | 62d | -10d | 0d |  |  |
| 434 | 1.6.2.4.1 | **Assembly & Initial Test** |  | 40d | 2004-01-20 A | 2004-03-16 |  | 70% | 12d | 2004-01-20 | 2004-03-16 | 40d | 31d |  |  |  |
| 435 | 1.6.2.4.1.1 | Assemble and Initial Test FM 1 SSD Bias Supply Board |  | 40d | 2004-01-20 A | 2004-03-16 |  | 70% | 12d | 2004-01-20 | 2004-03-16 | 40d | 31d | 0d | start no earlier than 2004-01-20 |  |
| 436 | 1.6.2.4.1.2 | Assemble and Initial Test FM 2 SSD Bias Supply Board |  | 40d | 2004-01-20 A | 2004-03-16 | 435SS | 70% | 12d | 2004-01-20 | 2004-03-16 | 40d | 31d |  |  |  |
| 437 | 1.6.2.4.2 | **Final Test** |  | 10d | 2004-05-13 | 2004-05-26 |  |  |  | 2004-04-02 | 2004-04-15 | 10d | -10d | 0d |  |  |
| 438 | 1.6.2.4.2.1 | Final Test FM 1 SSD Bias Supply Board |  | 10d | 2004-05-13 | 2004-05-26 | 435, 378 |  |  | 2004-04-02 | 2004-04-15 | 10d | -10d | 0d |  |  |
| 439 | 1.6.2.4.2.2 | Final Test FM 2 SSD Bias Supply Board |  | 10d | 2004-05-13 | 2004-05-26 | 436, 378 |  |  | 2004-04-02 | 2004-04-15 | 10d | -10d | 0d |  |  |
| 440 | 1.6.2.5 | **Conformal Coat, Mass Properties and Bake Out (SEP Central, LET, SEP LVPS)** |  | 17d | 2004-05-27 | 2004-06-21 |  |  |  | 2004-04-16 | 2004-05-10 | 17d | -10d | 0d |  |  |
| 441 | 1.6.2.5.1 | Stake/Conformal Coat All SEP Central and LET Boards |  | 10d | 2004-05-27 | 2004-06-10 | 428, 429, 431, 432, 438, 439, 513, 514 |  |  | 2004-04-16 | 2004-04-29 | 10d | -10d | 0d |  |  |
| 442 | 1.6.2.5.2 | Mass Properties/Photo All SEP Central and LET Boards |  | 4d | 2004-06-11 | 2004-06-16 | 441 |  |  | 2004-04-30 | 2004-05-05 | 4d | -10d | 0d |  |  |
| 443 | 1.6.2.5.3 | Bake Out All SEP Central/LET Boards and SEP LVPS (FM 1 & 2) |  | 3d | 2004-06-17 | 2004-06-21 | 442, 74, 68 |  |  | 2004-05-06 | 2004-05-10 | 3d | -10d | 0d |  |  |
| 444 | 1.6.2.6 | **Flight Software** |  | 211d | 2003-08-01 A | 2004-06-03 |  | 68% | 68d | 2003-08-01 | 2004-06-03 | 211d | 30d |  |  |  |
| 445 | 1.6.2.6.1 | SEP Central Build 3 |  | 176d | 2003-08-01 A | 2004-04-14 |  | 81% | 33d | 2003-08-01 | 2004-04-14 | 176d | 30d | 0d | start no earlier than 2003-08-01 |  |
| 446 | 1.6.2.6.2 | Final Flight S/W Build |  | 35d | 2004-04-15 | 2004-06-03 | 445 |  |  | 2004-04-15 | 2004-06-03 | 35d | 30d | 0d |  |  |
| 447 | 1.6.3 | **HET - Tycho (GSFC)** |  | 145d | 2004-01-06 A | 2004-07-29 |  | 48% | 75.35d | 2004-01-06 | 2004-06-23 | 119d | 15d |  |  |  |
| 448 | 1.6.3.1 | **Deliveries** |  | 52d | 2004-05-18 | 2004-07-29 |  |  |  | 2004-04-30 | 2004-06-23 | 38d | 15d |  |  |  |
| 449 | 1.6.3.1.1 | Deliver HET FM 1 (to CIT for SEP Suite I&T) |  | 2d | 2004-07-07 | 2004-07-08 | 403, 494 |  |  | 2004-06-01 | 2004-06-02 | 2d | -3d | 0d |  | MS-SEP |
| 450 | 1.6.3.1.2 | Deliver HET FM 2 (to CIT for SEP Suite I&T) |  | 2d | 2004-07-28 | 2004-07-29 | 498, 403 |  |  | 2004-06-22 | 2004-06-23 | 2d | 15d | 0d |  | MS-SEP |
| 451 | 1.6.3.1.3 | Deliver Final HET Flight Software to SEP I&T |  | 2d | 2004-05-18 | 2004-05-19 | 488 |  |  | 2004-04-30 | 2004-05-03 | 2d | 32d |  |  |  |
| 452 | 1.6.3.2 | **Detectors (Batch 1)** |  | 40d | 2004-01-06 A | 2004-03-03 A |  | 100% |  | 2004-01-06 | 2004-03-31 | 60d |  |  |  |  |
| 453 | 1.6.3.2.1 | Receive & Inspect HET Flight Detectors |  | 40d | 2004-01-06 A | 2004-03-03 A |  | 100% |  | 2004-01-06 | 2004-03-03 | 40d |  |  | start no earlier than 2004-01-06 |  |

| ID | WBS | Task | Type | Duration | Start | Finish | Predecessors | Complete | Remaining | Baseline start | Baseline finish | Baseline duration | Total slack | Free slack | Constraint | Text1 |
| --- | --- | --- | --- | --- | --- | --- | --- | --- | --- | --- | --- | --- | --- | --- | --- | --- |
| 454 | 1.6.3.2.2 | **Detector Testing** |  | 40d | 2004-01-06 A | 2004-03-03 A |  | 100% |  | 2004-01-06 | 2004-03-31 | 60d |  |  |  |  |
| 455 | 1.6.3.2.2.1 | Capacitance, Current, Depletion, Alpha Resolution Testing |  | 40d | 2004-01-06 A | 2004-03-03 A | 453SS | 100% |  | 2004-01-06 | 2004-03-31 | 60d |  |  |  | MS-SEP |
| 456 | 1.6.3.2.2.2 | Life Test HET Detectors |  | 40d | 2004-01-06 A | 2004-03-03 A | 455SS | 100% |  | 2004-01-06 | 2004-03-31 | 60d |  |  |  | MS-SEP |
| 457 | 1.6.3.3 | **Replacement HET Detectors (Batch 2)** |  | 66d | 2004-03-12 A | 2004-06-14 |  |  | 66d | 2004-03-12 | 2004-06-14 | 66d | 11d |  |  |  |
| 458 | 1.6.3.3.1 | Receive H1 Detector Mounts | milestone | 0d | 2004-03-12 A | 2004-03-12 A |  | 100% |  | 2004-03-12 | 2004-03-12 | 0d |  |  | start no earlier than 2004-03-12 |  |
| 459 | 1.6.3.3.2 | Receive H3 Detector Mounts | milestone | 0d | 2004-03-26 A | 2004-03-26 A |  | 100% |  | 2004-03-26 | 2004-03-26 | 0d |  |  | start no earlier than 2004-03-26 |  |
| 460 | 1.6.3.3.3 | Detector Mounting at Micron |  | 20d | 2004-04-15 | 2004-05-12 | 458, 459 |  |  | 2004-04-15 | 2004-05-12 | 20d | 11d | 0d | start no earlier than 2004-04-15 |  |
| 461 | 1.6.3.3.4 | Detector Delivery to GSFC |  | 2d | 2004-05-13 | 2004-05-14 | 460 |  |  | 2004-05-13 | 2004-05-14 | 2d | 11d | 0d |  |  |
| 462 | 1.6.3.3.5 | Detector Testing at GSFC |  | 20d | 2004-05-17 | 2004-06-14 | 461 |  |  | 2004-05-17 | 2004-06-14 | 20d | 11d |  |  |  |
| 463 | 1.6.3.4 | **Electronics Board** |  | 78d | 2004-01-22 A | 2004-05-11 |  | 42% | 45.2d | 2004-01-22 | 2004-05-13 | 80d | 48d |  |  | MS-SEP |
| 464 | 1.6.3.4.1 | **Assembly** |  | 38d | 2004-01-22 A | 2004-03-16 |  | 50% | 19d | 2004-01-22 | 2004-03-12 | 36d | 59d |  |  |  |
| 465 | 1.6.3.4.1.1 | Install Socket on HET Electronics FM 1 Board for ETU ACTEL |  | 1d | 2004-01-22 A | 2004-01-22 A |  | 100% |  | 2004-01-22 | 2004-01-22 | 1d |  |  | start no earlier than 2004-01-22 |  |
| 466 | 1.6.3.4.1.2 | Complete Population of HET Electronics FM 1 Board (ETU ACTEL) |  | 1d | 2004-01-23 A | 2004-01-23 A | 465 | 100% |  | 2004-01-23 | 2004-01-23 | 1d |  |  |  |  |
| 467 | 1.6.3.4.1.3 | Complete Population of HET Electronics FM 2 Board (Flight ACTEL) |  | 2d | 2004-03-15 | 2004-03-16 | 466, 473, 507 |  |  | 2004-03-11 | 2004-03-12 | 2d | 59d | 0d |  |  |
| 468 | 1.6.3.4.2 | **Test** |  | 76d | 2004-01-26 A | 2004-05-11 |  | 42% | 44.33d | 2004-01-26 | 2004-05-13 | 78d | 48d |  |  |  |
| 469 | 1.6.3.4.2.1 | **FM 1** |  | 44d | 2004-01-26 A | 2004-03-26 |  | 55% | 20d | 2004-01-26 | 2004-03-22 | 40d | 46d |  |  |  |
| 470 | 1.6.3.4.2.1.1 | Test HET FM 1 Electronics Board w/ETU ACTEL |  | 23d | 2004-01-26 A | 2004-02-26 A | 466 | 100% |  | 2004-01-26 | 2004-02-23 | 20d |  |  |  |  |
| 471 | 1.6.3.4.2.1.2 | Remove ETU ACTEL and socket from HET FM 1 Electronics Board |  | 0.5d | 2004-02-27 A | 2004-02-27 A | 470 | 100% |  | 2004-02-24 | 2004-02-24 | 1d |  |  |  |  |
| 472 | 1.6.3.4.2.1.3 | Install Flight ACTEL on HET FM 1 Electronics Board |  | 0.5d | 2004-02-27 A | 2004-02-27 A | 471 | 100% |  | 2004-02-25 | 2004-02-25 | 1d |  |  |  |  |
| 473 | 1.6.3.4.2.1.4 | Retest HET FM 1 Electronics Board w/Flight ACTEL |  | 10d | 2004-03-01 | 2004-03-12 | 472 |  |  | 2004-02-26 | 2004-03-10 | 10d | 46d | 0d |  |  |
| 474 | 1.6.3.4.2.1.5 | Clean, Bake, Conformal Coat HET FM 1 Electronics Board |  | 5d | 2004-03-15 | 2004-03-19 | 473 |  |  | 2004-03-11 | 2004-03-12 | 2d | 46d | 0d |  |  |
| 475 | 1.6.3.4.2.1.6 | Retest Conformal Coated HET FM 1 Electronics Board |  | 5d | 2004-03-22 | 2004-03-26 | 474 |  |  | 2004-03-15 | 2004-03-16 | 2d | 46d | 27d |  |  |
| 476 | 1.6.3.4.2.2 | **FM 2** |  | 40d | 2004-03-17 A | 2004-05-11 |  | 28% | 29d | 2004-03-23 | 2004-05-13 | 38d | 48d |  |  |  |
| 477 | 1.6.3.4.2.2.1 | Test HET FM 2 Electronics Board |  | 30d | 2004-03-17 A | 2004-04-27 | 467, 470 | 37% | 19d | 2004-03-23 | 2004-05-03 | 30d | 48d | 0d |  |  |
| 478 | 1.6.3.4.2.2.2 | Clean, Bake, Conformal Coat HET FM 2 Electronics Board |  | 5d | 2004-04-28 | 2004-05-04 | 477 |  |  | 2004-05-04 | 2004-05-05 | 2d | 48d | 0d |  |  |
| 479 | 1.6.3.4.2.2.3 | Retest Conformal Coated HET FM 2 Electronics Board |  | 5d | 2004-05-05 | 2004-05-11 | 478, 475 |  |  | 2004-05-06 | 2004-05-07 | 2d | 48d | 22d |  |  |

Notes:
- 477: During removal of a temporary commercial ACTEL (U200) several pads(29) were lifted. We will build a new board, and repair the other board. One will become a Flight Spare. Continue with testing and switch out boards later on. 5d hit to the schedule.

| ID | WBS | Task | Type | Duration | Start | Finish | Predecessors | Complete | Remaining | Baseline start | Baseline finish | Baseline duration | Total slack | Free slack | Constraint | Text1 |
| --- | --- | --- | --- | --- | --- | --- | --- | --- | --- | --- | --- | --- | --- | --- | --- | --- |
| 480 | 1.6.3.5 | **Flight Software** |  | 82d | 2004-01-22 A | 2004-05-17 |  | 32% | 56d | 2004-01-22 | 2004-04-29 | 70d | 10d |  |  |  |
| 481 | 1.6.3.5.1 | **Design** |  | 22d | 2004-01-22 A | 2004-02-23 A |  | 100% |  | 2004-01-22 | 2004-02-04 | 10d |  |  |  |  |
| 482 | 1.6.3.5.1.1 | Complete Definition of HET PH Event Processing |  | 22d | 2004-01-22 A | 2004-02-23 A |  | 100% |  | 2004-01-22 | 2004-02-04 | 10d |  |  | start no earlier than 2004-01-22 |  |
| 483 | 1.6.3.5.2 | **Coding** |  | 20d | 2004-02-24 A | 2004-03-22 |  | 20% | 16d | 2004-02-05 | 2004-03-04 | 20d | 10d |  |  |  |
| 484 | 1.6.3.5.2.1 | Code HET PH Event Processing Update for Flight |  | 10d | 2004-02-24 A | 2004-03-08 | 482 | 40% | 6d | 2004-02-05 | 2004-02-19 | 10d | 10d | 0d |  |  |
| 485 | 1.6.3.5.2.2 | Code HET Telemetry Formatting Update for Flight |  | 10d | 2004-03-09 | 2004-03-22 | 484 |  |  | 2004-02-20 | 2004-03-04 | 10d | 10d | 0d |  |  |
| 486 | 1.6.3.5.3 | **Test** |  | 40d | 2004-03-23 | 2004-05-17 |  |  |  | 2004-03-05 | 2004-04-29 | 40d | 10d |  |  |  |
| 487 | 1.6.3.5.3.1 | Test Integrated HET S/W with Simulated Data |  | 15d | 2004-03-23 | 2004-04-12 | 485 |  |  | 2004-03-05 | 2004-03-25 | 15d | 10d | 0d |  |  |
| 488 | 1.6.3.5.3.2 | Verify HET On-Board Software |  | 25d | 2004-04-13 | 2004-05-17 | 487 |  |  | 2004-03-26 | 2004-04-29 | 25d | 10d | 0d |  |  |
| 489 | 1.6.3.6 | **Integration & Test** |  | 37d | 2004-06-07 | 2004-07-27 |  |  |  | 2004-05-03 | 2004-06-21 | 35d | -3d | 0d |  |  |
| 490 | 1.6.3.6.1 | **FM 1** |  | 22d | 2004-06-07 | 2004-07-06 |  |  |  | 2004-05-03 | 2004-05-28 | 20d | -3d | 0d |  |  |
| 491 | 1.6.3.6.1.1 | Integrate HET FM 1 Electronics Telescope (Ahead) |  | 5d | 2004-06-07 | 2004-06-11 | 456, 488, 393, 475 |  |  | 2004-05-03 | 2004-05-07 | 5d | -3d | 0d |  |  |
| 492 | 1.6.3.6.1.2 | Test HET FM 1 Telescope (Ahead) |  | 15d | 2004-06-14 | 2004-07-02 | 491 |  |  | 2004-05-10 | 2004-05-28 | 15d | -3d | 0d |  |  |
| 493 | 1.6.3.6.1.3 | Install new HET Flight Detectors in FM 1 |  | 1d | 2004-07-05 | 2004-07-05 | 462, 492 |  |  | 2004-06-16 | 2004-06-16 | 1d | -3d | 0d |  |  |
| 494 | 1.6.3.6.1.4 | Performance Test FM 1 with New Flight Detectors |  | 1d | 2004-07-06 | 2004-07-06 | 493 |  |  | 2004-06-17 | 2004-06-17 | 1d | -3d | 0d |  |  |
| 495 | 1.6.3.6.2 | **FM 2** |  | 32d | 2004-06-14 | 2004-07-27 |  |  |  | 2004-05-14 | 2004-06-21 | 26d | 15d |  |  |  |
| 496 | 1.6.3.6.2.1 | Integrate HET FM 2 Electronics Telescope (Behind) |  | 5d | 2004-06-14 | 2004-06-18 | 491, 456, 488, 393, 479 |  |  | 2004-05-14 | 2004-05-20 | 5d | 26d | 11d |  |  |
| 497 | 1.6.3.6.2.2 | Install new HET Flight Detectors in FM 2 |  | 1d | 2004-07-06 | 2004-07-06 | 496, 462, 493 |  |  | 2004-06-17 | 2004-06-17 | 1d | 15d | 0d |  |  |
| 498 | 1.6.3.6.2.3 | Test HET FM 2 Telescope (Behind) |  | 15d | 2004-07-07 | 2004-07-27 | 497 |  |  | 2004-06-01 | 2004-06-21 | 15d | 15d | 0d |  |  |
| 499 | 1.6.4 | **LET - CIT** |  | 257d | 2003-07-14 A | 2004-07-19 |  | 76% | 61.27d | 2003-07-14 | 2004-06-08 | 228d | 23d |  |  |  |
| 500 | 1.6.4.1 | **Deliveries** |  | 53d | 2004-05-04 | 2004-07-19 |  |  |  | 2004-05-04 | 2004-06-08 | 24d | 23d |  |  |  |
| 501 | 1.6.4.1.1 | Deliver LET FM 1 (stays at CIT for SEP I&T) | milestone | 0d | 2004-07-19 | 2004-07-19 | 519 |  |  | 2004-06-08 | 2004-06-08 | 0d | -10d | 0d |  | MS-SEP |
| 502 | 1.6.4.1.2 | Deliver LET FM 2 (stays at CIT for SEP I&T) | milestone | 0d | 2004-07-19 | 2004-07-19 | 521 |  |  | 2004-06-08 | 2004-06-08 | 0d | 23d | 0d |  | MS-SEP |
| 503 | 1.6.4.1.3 | Deliver LET Flight Software Build 3 | milestone | 0d | 2004-05-04 | 2004-05-04 | 516 |  |  | 2004-05-04 | 2004-05-04 | 0d | 43d |  |  |  |

| ID | WBS | Task | Duration | Start | Finish | Predecessors | Complete | Remaining | Baseline start | Baseline finish | Baseline duration | Total slack | Free slack | Constraint | Text1 |
| --- | --- | --- | --- | --- | --- | --- | --- | --- | --- | --- | --- | --- | --- | --- | --- |
| 504 | 1.6.4.2 | **Detectors** | 167d | 2003-07-14 A | 2004-03-12 |  | 94% | 10d | 2003-07-14 | 2004-03-12 | 167d | 60d |  |  |  |
| 505 | 1.6.4.2.1 | Complete LET Flight Detector Testing | 167d | 2003-07-14 A | 2004-03-12 |  | 94% | 10d | 2003-07-14 | 2004-03-12 | 167d | 60d |  | start no earlier than 2003-07-14 | MS-SEP |
| 506 | 1.6.4.3 | **Hybrids** | 144d | 2003-08-01 A | 2004-03-01 A |  | 100% |  | 2003-08-01 | 2004-03-01 | 144d |  |  |  |  |
| 507 | 1.6.4.3.1 | Complete Test of Flight Hybrids (LET and to GSFC for HET FM 2) | 144d | 2003-08-01 A | 2004-03-01 A |  | 100% |  | 2003-08-01 | 2004-03-01 | 144d |  |  | start no earlier than 2003-08-01 |  |
| 508 | 1.6.4.4 | **Detector/Misc Board** | 21d | 2004-03-02 | 2004-03-30 |  |  |  | 2004-03-02 | 2004-03-30 | 21d | 31d |  |  |  |
| 509 | 1.6.4.4.1 | **Assembly** | 10d | 2004-03-02 | 2004-03-15 |  |  |  | 2004-03-02 | 2004-03-15 | 10d | 31d |  |  |  |
| 510 | 1.6.4.4.1.1 | Assemble LET FM 1 Detector Board | 10d | 2004-03-02 | 2004-03-15 | 507 |  |  | 2004-03-02 | 2004-03-15 | 10d | 31d | 0d |  |  |
| 511 | 1.6.4.4.1.2 | Assemble LET FM 2 Detector Board | 10d | 2004-03-02 | 2004-03-15 | 507 |  |  | 2004-03-02 | 2004-03-15 | 10d | 31d | 0d |  |  |
| 512 | 1.6.4.4.2 | **Test** | 11d | 2004-03-16 | 2004-03-30 |  |  |  | 2004-03-16 | 2004-03-30 | 11d | 31d |  |  |  |
| 513 | 1.6.4.4.2.1 | Test LET FM 1 Detector Board | 11d | 2004-03-16 | 2004-03-30 | 510 |  |  | 2004-03-16 | 2004-03-30 | 11d | 31d |  |  |  |
| 514 | 1.6.4.4.2.2 | Test LET FM 2 Detector Board | 11d | 2004-03-16 | 2004-03-30 | 511 |  |  | 2004-03-16 | 2004-03-30 | 11d | 31d |  |  |  |
| 515 | 1.6.4.5 | **Flight Software** | 190d | 2003-08-01 A | 2004-05-04 |  | 75% | 47d | 2003-08-01 | 2004-05-04 | 190d | 43d |  |  |  |
| 516 | 1.6.4.5.1 | Let Flight Software Build 3 | 190d | 2003-08-01 A | 2004-05-04 |  | 75% | 47d | 2003-08-01 | 2004-05-04 | 190d | 43d | 0d | start no earlier than 2003-08-01 |  |
| 517 | 1.6.4.6 | **Integration & Test** | 20d | 2004-06-22 | 2004-07-19 |  |  |  | 2004-05-11 | 2004-06-08 | 20d | -10d | 0d |  |  |
| 518 | 1.6.4.6.1 | **FM 1** | 20d | 2004-06-22 | 2004-07-19 |  |  |  | 2004-05-11 | 2004-06-08 | 20d | -10d | 0d |  |  |
| 519 | 1.6.4.6.1.1 | Integrate LET FM 1 Housing With Detectors | 20d | 2004-06-22 | 2004-07-19 | 505, 443, 383 |  |  | 2004-05-11 | 2004-06-08 | 20d | -10d | 0d |  | MS-SEP |
| 520 | 1.6.4.6.2 | **FM 2** | 20d | 2004-06-22 | 2004-07-19 |  |  |  | 2004-05-11 | 2004-06-08 | 20d | 23d |  |  |  |
| 521 | 1.6.4.6.2.1 | Integrate LET FM 2 Housing With Detectors | 20d | 2004-06-22 | 2004-07-19 | 505, 443, 383 |  |  | 2004-05-11 | 2004-06-08 | 20d | 23d | 0d |  | MS-SEP |
| 522 | 1.6.5 | **SEPT - Kiel/ESTEC** | 271d | 2003-08-08 A | 2004-09-02 |  | 90% | 28.26d | 2003-08-08 | 2004-07-28 | 245d | 23d |  |  |  |
| 523 | 1.6.5.1 | **Deliveries** | 123d | 2004-03-15 | 2004-09-02 |  |  |  | 2004-03-11 | 2004-07-28 | 99d | 23d |  |  |  |
| 524 | 1.6.5.1.1 | Deliver SEPT-NS FM 1 to CIT for SEP I&T and Suite EMC | 5d | 2004-03-15 | 2004-03-19 | 563, 564 |  |  | 2004-03-11 | 2004-03-17 | 5d | 73d | 0d |  | MS-SEP |
| 525 | 1.6.5.1.2 | Deliver SEPT-E FM 1 to CIT for SEP I&T and Suite EMC | 5d | 2004-03-15 | 2004-03-19 | 571, 570 |  |  | 2004-03-11 | 2004-03-17 | 5d | 73d | 0d |  | MS-SEP |
| 526 | 1.6.5.1.3 | Final Delivery of SEPT FM 1 to APL (after Therm Bal @ GSFC) | 2d | 2004-09-01 | 2004-09-02 | 565, 572, 556 |  |  | 2004-07-27 | 2004-07-28 | 2d | 23d |  |  |  |
| 527 | 1.6.5.1.4 | Deliver SEPT-NS FM 2 to CIT for SEP I&T and Suite EMC | 5d | 2004-03-18 | 2004-03-24 | 578, 579 |  |  | 2004-03-22 | 2004-03-26 | 5d | 103d | 0d |  | MS-SEP |
| 528 | 1.6.5.1.5 | Deliver SEPT-E FM 2 to CIT for SEP I&T and Suite EMC | 5d | 2004-03-18 | 2004-03-24 | 584, 585 |  |  | 2004-03-22 | 2004-03-26 | 5d | 103d | 0d |  | MS-SEP |

| ID | WBS | Task | Duration | Start | Finish | Predecessors | Complete | Remaining | Baseline start | Baseline finish | Baseline duration | Total slack | Free slack | Constraint |
| --- | --- | --- | --- | --- | --- | --- | --- | --- | --- | --- | --- | --- | --- | --- |
| 529 | 1.6.5.2 | **Mechanical Assembly** | 46d | 2003-12-22 A | 2004-02-27 A |  | 100% |  | 2003-12-22 | 2004-02-27 | 46d |  |  |  |
| 530 | 1.6.5.2.1 | **FM 1** | 13d | 2003-12-22 A | 2004-01-09 A |  | 100% |  | 2003-12-22 | 2004-01-09 | 13d |  |  |  |
| 531 | 1.6.5.2.1.1 | Assemble SEPT-NS FM 1 Sensor and E-Box Housing | 13d | 2003-12-22 A | 2004-01-09 A |  | 100% |  | 2003-12-22 | 2004-01-09 | 13d |  |  | start no earlier than 2003-12-22 |
| 532 | 1.6.5.2.1.2 | Assemble SEPT-E FM 1 Sensor and E-Box Housing | 13d | 2003-12-22 A | 2004-01-09 A |  | 100% |  | 2003-12-22 | 2004-01-09 | 13d |  |  | start no earlier than 2003-12-22 |
| 533 | 1.6.5.2.2 | **FM 2** | 14d | 2003-12-29 A | 2004-01-16 A |  | 100% |  | 2003-12-29 | 2004-01-16 | 14d |  |  |  |
| 534 | 1.6.5.2.2.1 | Assemble SEPT-NS FM 2 Sensor and E-Box Housing | 14d | 2003-12-29 A | 2004-01-16 A | 531SS+4d | 100% |  | 2003-12-29 | 2004-01-16 | 14d |  |  |  |
| 535 | 1.6.5.2.2.2 | Assemble SEPT-E FM 2 Sensor and E-Box Housing | 14d | 2003-12-29 A | 2004-01-16 A | 532SS+4d | 100% |  | 2003-12-29 | 2004-01-16 | 14d |  |  |  |
| 536 | 1.6.5.2.3 | **Spare** | 28d | 2004-01-20 A | 2004-02-27 A |  | 100% |  | 2004-01-20 | 2004-02-27 | 28d |  |  |  |
| 537 | 1.6.5.2.3.1 | Assemble SEPT Spare Sensor and E-Box Housing | 28d | 2004-01-20 A | 2004-02-27 A | 534, 535 | 100% |  | 2004-01-20 | 2004-02-27 | 28d |  |  |  |
| 538 | 1.6.5.3 | **Electronics** | 198d | 2003-08-08 A | 2004-05-21 |  | 94% | 12.26d | 2003-08-08 | 2004-05-21 | 198d | 94d |  |  |
| 539 | 1.6.5.3.1 | **Assembly** | 172d | 2003-08-08 A | 2004-04-15 |  | 97% | 5.11d | 2003-08-08 | 2004-04-15 | 172d | 105d |  |  |
| 540 | 1.6.5.3.1.1 | **FM 2** | 106d | 2003-08-08 A | 2004-01-12 A |  | 100% |  | 2003-08-08 | 2004-01-12 | 106d |  |  |  |
| 541 | 1.6.5.3.1.1.1 | Assemble SEPT-NS FM 2 Electronics | 106d | 2003-08-08 A | 2004-01-12 A |  | 100% |  | 2003-08-08 | 2004-01-12 | 106d |  |  | start no earlier than 2003-08-08 |
| 542 | 1.6.5.3.1.1.2 | Assemble SEPT-E FM 2 Electronics | 92d | 2003-08-08 A | 2003-12-19 A |  | 100% |  | 2003-08-08 | 2003-12-19 | 92d |  |  | start no earlier than 2003-08-08 |
| 543 | 1.6.5.3.1.2 | **Spare** | 172d | 2003-08-08 A | 2004-04-15 |  | 94% | 11d | 2003-08-08 | 2004-04-15 | 172d | 105d |  |  |
| 544 | 1.6.5.3.1.2.1 | Assemble SEPT FS Electronics | 172d | 2003-08-08 A | 2004-04-15 | 541SS | 94% | 11d | 2003-08-08 | 2004-04-15 | 172d | 105d | 6d |  |
| 545 | 1.6.5.3.2 | **Test** | 113d | 2003-12-11 A | 2004-05-21 |  | 70% | 33.9d | 2003-12-11 | 2004-05-21 | 113d | 94d |  |  |
| 546 | 1.6.5.3.2.1 | **FM 2** | 34d | 2003-12-11 A | 2004-01-30 A |  | 100% |  | 2003-12-11 | 2004-01-30 | 34d |  |  |  |
| 547 | 1.6.5.3.2.1.1 | SEPT-NS FM 2 Electronics Test | 4d | 2004-01-13 A | 2004-01-16 A | 541 | 100% |  | 2004-01-13 | 2004-01-16 | 4d |  |  |  |
| 548 | 1.6.5.3.2.1.2 | SEPT-E FM 2 Electronics Test | 4d | 2003-12-11 A | 2003-12-16 A | 542FS-7d | 100% |  | 2003-12-11 | 2003-12-16 | 4d |  |  |  |
| 549 | 1.6.5.3.2.1.3 | Coat SEPT-NS FM 2 Electronics Board | 4d | 2004-01-20 A | 2004-01-23 A | 547 | 100% |  | 2004-01-20 | 2004-01-23 | 4d |  |  |  |
| 550 | 1.6.5.3.2.1.4 | Coat SEPT-E FM 2 Electronics Board | 5d | 2003-12-17 A | 2003-12-23 A | 548 | 100% |  | 2003-12-17 | 2003-12-23 | 5d |  |  |  |
| 551 | 1.6.5.3.2.1.5 | SEPT-NS FM 2 Mechanical Integration | 5d | 2004-01-26 A | 2004-01-30 A | 549 | 100% |  | 2004-01-26 | 2004-01-30 | 5d |  |  |  |
| 552 | 1.6.5.3.2.1.6 | SEPT-E FM 2 Mechanical Integration | 13d | 2003-12-24 A | 2004-01-13 A | 550 | 100% |  | 2003-12-24 | 2004-01-13 | 13d |  |  |  |

| ID | WBS | Task | Duration | Start | Finish | Predecessors | Complete | Remaining | Baseline start | Baseline finish | Baseline duration | Total slack | Free slack | Constraint | Text1 |
| --- | --- | --- | --- | --- | --- | --- | --- | --- | --- | --- | --- | --- | --- | --- | --- |
| 553 | 1.6.5.3.2.2 | **Spare** | 20d | 2004-04-26 | 2004-05-21 |  |  |  | 2004-04-26 | 2004-05-21 | 20d | 94d |  |  |  |
| 554 | 1.6.5.3.2.2.1 | SEPT Flight Spare Electronics Test | 5d | 2004-04-26 | 2004-04-30 | 544 |  |  | 2004-04-26 | 2004-04-30 | 5d | 99d | 5d | start no earlier than 2004-04-26 |  |
| 555 | 1.6.5.3.2.2.2 | Coat SEPT FS Electronics Board | 5d | 2004-05-10 | 2004-05-14 | 554 |  |  | 2004-05-10 | 2004-05-14 | 5d | 94d | 0d | start no earlier than 2004-05-10 |  |
| 556 | 1.6.5.3.2.2.3 | SEPT FS Mechanical Integration | 5d | 2004-05-17 | 2004-05-21 | 555 |  |  | 2004-05-17 | 2004-05-21 | 5d | 94d | 71d |  |  |
| 557 | 1.6.5.4 | **Integration & Test** | 164d | 2004-01-12 A | 2004-08-31 |  | 84% | 25.62d | 2004-01-12 | 2004-07-26 | 138d | 23d |  |  |  |
| 558 | 1.6.5.4.1 | **FM 1** | 164d | 2004-01-12 A | 2004-08-31 |  | 73% | 44.32d | 2004-01-12 | 2004-07-26 | 138d | 23d |  |  |  |
| 559 | 1.6.5.4.1.1 | **SEPT-NS** | 155d | 2004-01-26 A | 2004-08-31 |  | 73% | 41.89d | 2004-01-26 | 2004-07-26 | 129d | 23d |  |  |  |
| 560 | 1.6.5.4.1.1.1 | SEPT-NS FM 1 Integration & Test | 5d | 2004-01-26 A | 2004-01-30 A | 531 | 100% |  | 2004-01-26 | 2004-01-30 | 5d |  |  | start no earlier than 2004-01-26 |  |
| 561 | 1.6.5.4.1.1.2 | Muon and Radioactive Source Test | 5d | 2004-02-02 A | 2004-02-06 A | 560 | 100% |  | 2004-02-02 | 2004-02-06 | 5d |  |  |  |  |
| 562 | 1.6.5.4.1.1.3 | SEPT-NS FM 1 Vibration | 4d | 2004-02-19 A | 2004-02-24 A | 561 | 100% |  | 2004-02-17 | 2004-02-20 | 4d |  |  | start no earlier than 2004-02-19 | MS-SEP |
| 563 | 1.6.5.4.1.1.4 | SEPT-NS FM 1 Thermal Vac | 11d | 2004-02-27 A | 2004-03-12 A | 562FS+2d | 100% |  | 2004-02-25 | 2004-03-08 | 9d |  |  |  |  |
| 564 | 1.6.5.4.1.1.5 | SEPT-NS FM 1 Bake Out | 2d | 2004-03-05 A | 2004-03-08 A | 563FS-6d | 100% |  | 2004-03-09 | 2004-03-10 | 2d |  |  |  |  |
| 565 | 1.6.5.4.1.1.6 | SEPT-NS FM 1 Thermal Balance (at GSFC after Suite EMC) | 10d | 2004-08-18 | 2004-08-31 | 19 |  |  | 2004-07-13 | 2004-07-26 | 10d | 23d | 0d |  |  |
| 566 | 1.6.5.4.1.2 | **SEPT-E** | 164d | 2004-01-12 A | 2004-08-31 |  | 73% | 44.32d | 2004-01-12 | 2004-07-26 | 138d | 23d |  |  |  |
| 567 | 1.6.5.4.1.2.1 | SEPT-E FM 1 Integration & Test | 5d | 2004-01-12 A | 2004-01-16 A | 532 | 100% |  | 2004-01-12 | 2004-01-16 | 5d |  |  |  |  |
| 568 | 1.6.5.4.1.2.2 | Muon and Radioactive Source Test | 5d | 2004-01-29 A | 2004-02-04 A | 567 | 100% |  | 2004-01-29 | 2004-02-04 | 5d |  |  | start no earlier than 2004-01-29 |  |
| 569 | 1.6.5.4.1.2.3 | SEPT-E FM 1 Vibration | 4d | 2004-02-19 A | 2004-02-24 A | 568, 562SS | 100% |  | 2004-02-21 | 2004-02-24 | 4d |  |  |  |  |
| 570 | 1.6.5.4.1.2.4 | SEPT-E FM 1 Thermal Vac | 11d | 2004-02-27 A | 2004-03-12 A | 569, 563SS | 100% |  | 2004-02-25 | 2004-03-08 | 9d |  |  |  |  |
| 571 | 1.6.5.4.1.2.5 | SEPT-E FM 1 Bake Out | 2d | 2004-03-05 A | 2004-03-08 A | 570FS-6d | 100% |  | 2004-03-09 | 2004-03-10 | 2d |  |  |  |  |
| 572 | 1.6.5.4.1.2.6 | SEPT-E FM 1 Thermal Balance (at GSFC after Suite EMC) | 10d | 2004-08-18 | 2004-08-31 | 19 |  |  | 2004-07-13 | 2004-07-26 | 10d | 23d | 0d |  |  |
| 573 | 1.6.5.4.2 | **FM 2** | 46d | 2004-01-12 A | 2004-03-17 A |  | 100% |  | 2004-01-12 | 2004-03-19 | 48d |  |  |  |  |
| 574 | 1.6.5.4.2.1 | **SEPT-NS** | 41d | 2004-01-20 A | 2004-03-17 A |  | 100% |  | 2004-01-20 | 2004-03-19 | 43d |  |  |  |  |
| 575 | 1.6.5.4.2.1.1 | SEPT-NS FM 2 Integration & Test | 8d | 2004-01-20 A | 2004-01-29 A | 534 | 100% |  | 2004-01-20 | 2004-01-29 | 8d |  |  |  |  |
| 576 | 1.6.5.4.2.1.2 | Muon and Radioactive Source Test | 6d | 2004-01-30 A | 2004-02-06 A | 575 | 100% |  | 2004-01-30 | 2004-02-06 | 6d |  |  |  |  |
| 577 | 1.6.5.4.2.1.3 | SEPT-NS FM 2 Vibration | 4d | 2004-02-19 A | 2004-02-24 A | 576, 562SS | 100% |  | 2004-02-17 | 2004-02-20 | 4d |  |  |  |  |
| 578 | 1.6.5.4.2.1.4 | SEPT-NS FM 2 Thermal Vac | 9d | 2004-03-05 A | 2004-03-17 A | 577 | 100% |  | 2004-03-09 | 2004-03-17 | 9d |  |  | start no earlier than 2004-03-05 |  |
| 579 | 1.6.5.4.2.1.5 | SEPT-NS FM 2 Bake Out | 2d | 2004-03-12 A | 2004-03-15 A | 578FS-4d | 100% |  | 2004-03-18 | 2004-03-19 | 2d |  |  |  |  |

Notes:
- 562: There was a failure on the SEPT door during Vibration Test. Vibration Test will be repeated once the fix to the door is implemented. Time and place is TBD.
- 569: There was a failure on the SEPT door during Vibration Test. Vibration Test will be repeated once the fix to the door is implemented. Time and place is TBD.
- 577: There was a failure on the SEPT door during Vibration Test. Vibration Test will be repeated once the fix to the door is implemented. Time and place is TBD.

| ID | WBS | Task | Type | Duration | Start | Finish | Predecessors | Complete | Remaining | Baseline start | Baseline finish | Baseline duration | Total slack | Free slack | Constraint | Text1 |
| --- | --- | --- | --- | --- | --- | --- | --- | --- | --- | --- | --- | --- | --- | --- | --- | --- |
| 580 | 1.6.5.4.2.2 | **SEPT-E** |  | 46d | 2004-01-12 A | 2004-03-17 A |  | 100% |  | 2004-01-12 | 2004-03-19 | 48d |  |  |  |  |
| 581 | 1.6.5.4.2.2.1 | SEPT-E FM 2 Integration & Test |  | 5d | 2004-01-12 A | 2004-01-16 A | 567SS | 100% |  | 2004-01-12 | 2004-01-16 | 5d |  |  |  |  |
| 582 | 1.6.5.4.2.2.2 | Muon and Radioactive Source Test |  | 5d | 2004-01-29 A | 2004-02-04 A | 581, 568SS | 100% |  | 2004-01-29 | 2004-02-04 | 5d |  |  |  |  |
| 583 | 1.6.5.4.2.2.3 | SEPT-E FM 2 Vibration |  | 4d | 2004-02-19 A | 2004-02-24 A | 582, 562SS | 100% |  | 2004-02-21 | 2004-02-24 | 4d |  |  |  |  |
| 584 | 1.6.5.4.2.2.4 | SEPT-E FM 2 Thermal Vac |  | 9d | 2004-03-05 A | 2004-03-17 A | 583, 578SS | 100% |  | 2004-03-09 | 2004-03-17 | 9d |  |  |  |  |
| 585 | 1.6.5.4.2.2.5 | SEPT-E FM 2 Bake Out |  | 2d | 2004-03-12 A | 2004-03-15 A | 584FS-4d | 100% |  | 2004-03-18 | 2004-03-19 | 2d |  |  |  |  |
| 586 | 1.6.6 | **SIT - UMD** |  | 353d | 2003-06-02 A | 2004-10-22 |  | 51% | 173.06d | 2003-06-02 | 2004-10-20 | 351d | 279d |  |  |  |
| 587 | 1.6.6.1 | **Deliveries** |  | 63d | 2004-07-26 | 2004-10-22 |  |  |  | 2004-06-18 | 2004-10-12 | 81d | -13d | 0d |  |  |
| 588 | 1.6.6.1.1 | Deliver SIT FM 1 to CIT for SEP I&T and Suite EMC |  | 2d | 2004-07-26 | 2004-07-27 | 404, 681 |  |  | 2004-06-18 | 2004-06-21 | 2d | -13d | 0d |  | MS-SEP |
| 589 | 1.6.6.1.2 | Deliver SIT FM 1 back to GSFC for Environmental Testing (after EMC Test) |  | 2d | 2004-08-18 | 2004-08-19 | 19, 411 |  |  | 2004-07-13 | 2004-07-14 | 2d | -3d | 0d |  | MS-SEP |
| 590 | 1.6.6.1.3 | Final Delivery of SIT FM 1 to APL |  | 1d | 2004-10-12 | 2004-10-12 | 715 |  |  | 2004-09-01 | 2004-09-01 | 1d | -3d | 0d |  | MS-SEP |
| 591 | 1.6.6.1.4 | Deliver SIT FM 2 to CIT for SEP I&T |  | 2d | 2004-08-13 | 2004-08-16 | 686, 404 |  |  | 2004-07-23 | 2004-07-26 | 2d | 1d | 0d |  | MS-SEP |
| 592 | 1.6.6.1.5 | Deliver SIT FM 2 back to GSFC for Environmental Testing |  | 2d | 2004-08-31 | 2004-09-01 | 777 |  |  | 2004-08-19 | 2004-08-20 | 2d | 3d | 0d |  | MS-SEP |
| 593 | 1.6.6.1.6 | Final Delivery of SIT FM 2 to APL |  | 1d | 2004-10-22 | 2004-10-22 | 724, 730 |  |  | 2004-10-12 | 2004-10-12 | 1d | 3d | 0d |  | MS-SEP |
| 594 | 1.6.6.2 | **ACTEL - for SIT Logic Board** |  | 11d | 2004-05-17 | 2004-06-01 |  |  |  | 2004-02-27 | 2004-03-12 | 11d | 8d |  |  |  |
| 595 | 1.6.6.2.1 | Burn Final SIT ACTEL Chip (at GSFC) |  | 1d | 2004-05-17 | 2004-05-17 |  |  |  | 2004-02-27 | 2004-02-27 | 1d | 8d | 0d | start no earlier than 2004-05-17 |  |
| 596 | 1.6.6.2.2 | Evaluate (Test) SIT Final ACTEL Chip |  | 10d | 2004-05-18 | 2004-06-01 | 595 |  |  | 2004-03-01 | 2004-03-12 | 10d | 8d |  |  |  |
| 597 | 1.6.6.3 | **TOF Boards** |  | 59d | 2004-02-12 A | 2004-05-05 |  | 38% | 36.88d | 2004-02-12 | 2004-03-11 | 20d | 28d |  |  |  |
| 598 | 1.6.6.3.1 | Receive Analog and Digital TOF Boards (FM 1) | milestone | 0d | 2004-02-12 A | 2004-02-12 A |  | 100% |  | 2004-02-12 | 2004-02-12 | 0d |  |  | start no earlier than 2004-02-12 |  |
| 599 | 1.6.6.3.2 | Receive Analog and Digital TOF Boards (FM 2) |  | 20d | 2004-03-25 | 2004-04-21 | 602 |  |  | 2004-03-15 | 2004-04-09 | 20d | 28d | 0d |  |  |
| 600 | 1.6.6.3.3 | **Test** |  | 48d | 2004-03-01 A | 2004-05-05 |  | 64% | 17.14d | 2004-02-12 | 2004-03-11 | 20d | 28d |  |  |  |
| 601 | 1.6.6.3.3.1 | **FM 1** |  | 18d | 2004-03-01 A | 2004-03-24 A |  | 100% |  | 2004-02-12 | 2004-02-26 | 10d |  |  |  |  |
| 602 | 1.6.6.3.3.1.1 | FM 1 TOF Boards Functional Test |  | 18d | 2004-03-01 A | 2004-03-24 A | 598 | 100% |  | 2004-02-12 | 2004-02-26 | 10d |  |  | start no earlier than 2004-03-01 |  |
| 603 | 1.6.6.3.3.2 | **FM 2** |  | 10d | 2004-04-22 | 2004-05-05 |  |  |  | 2004-02-27 | 2004-03-11 | 10d | 28d |  |  |  |
| 604 | 1.6.6.3.3.2.1 | FM 2 TOF Boards Functional Test |  | 10d | 2004-04-22 | 2004-05-05 | 598, 599 |  |  | 2004-02-27 | 2004-03-11 | 10d | 28d | 27d |  |  |

Notes:
- 583: There was a failure on the SEPT door during Vibration Test. Vibration Test will be repeated once the fix to the door is implemented. Time and place is TBD.

| ID | WBS | Task | Duration | Start | Finish | Predecessors | Complete | Remaining | Baseline start | Baseline finish | Baseline duration | Total slack | Free slack | Constraint |
| --- | --- | --- | --- | --- | --- | --- | --- | --- | --- | --- | --- | --- | --- | --- |
| 605 | 1.6.6.4 | **Energy Board** | 129d | 2003-11-10 A | 2004-05-14 |  | 81% | 25.05d | 2003-11-10 | 2004-04-02 | 99d | 21d |  |  |
| 606 | 1.6.6.4.1 | **Assembly** | 114d | 2003-11-10 A | 2004-04-23 |  | 94% | 6.48d | 2003-11-10 | 2004-02-20 | 69d | 21d |  |  |
| 607 | 1.6.6.4.1.1 | **FM 1** | 92d | 2003-11-10 A | 2004-03-24 A |  | 100% |  | 2003-11-10 | 2004-02-20 | 69d |  |  |  |
| 608 | 1.6.6.4.1.1.1 | Assemble FM 1 Energy Board | 92d | 2003-11-10 A | 2004-03-24 A |  | 100% |  | 2003-11-10 | 2004-02-20 | 69d |  |  | start no earlier than 2003-11-10 |
| 609 | 1.6.6.4.1.2 | **FM 2** | 114d | 2003-11-10 A | 2004-04-23 |  | 88% | 13.57d | 2003-11-10 | 2004-02-20 | 69d | 21d |  |  |
| 610 | 1.6.6.4.1.2.1 | Assemble FM 2 Energy Board | 84d | 2003-11-10 A | 2004-04-23 | 608FF+22d | 88% | 10d | 2003-11-10 | 2004-02-20 | 69d | 21d | 0d |  |
| 611 | 1.6.6.4.2 | **Test** | 37d | 2004-03-25 | 2004-05-14 |  |  |  | 2004-02-23 | 2004-04-02 | 30d | 12d |  |  |
| 612 | 1.6.6.4.2.1 | **FM 1** | 15d | 2004-03-25 | 2004-04-14 |  |  |  | 2004-02-23 | 2004-03-12 | 15d | 12d |  |  |
| 613 | 1.6.6.4.2.1.1 | Bench Test/Calibration | 10d | 2004-03-25 | 2004-04-07 | 608 |  |  | 2004-02-23 | 2004-03-05 | 10d | 12d | 0d |  |
| 614 | 1.6.6.4.2.1.2 | Thermal | 3d | 2004-04-08 | 2004-04-12 | 613 |  |  | 2004-03-08 | 2004-03-10 | 3d | 12d | 0d |  |
| 615 | 1.6.6.4.2.1.3 | Voltage Margin | 2d | 2004-04-13 | 2004-04-14 | 614 |  |  | 2004-03-11 | 2004-03-12 | 2d | 12d | 7d |  |
| 616 | 1.6.6.4.2.2 | **FM 2** | 15d | 2004-04-26 | 2004-05-14 |  |  |  | 2004-03-15 | 2004-04-02 | 15d | 21d |  |  |
| 617 | 1.6.6.4.2.2.1 | FM 2 Energy Board Functional Test | 15d | 2004-04-26 | 2004-05-14 | 610, 615 |  |  | 2004-03-15 | 2004-04-02 | 15d | 21d | 20d |  |
| 618 | 1.6.6.5 | **Logic Board** | 183d | 2003-11-10 A | 2004-07-30 |  | 61% | 71.41d | 2003-11-10 | 2004-07-09 | 168d | 1d |  |  |
| 619 | 1.6.6.5.1 | **Design** | 3d | 2003-11-17 A | 2003-11-19 A |  | 100% |  | 2003-11-17 | 2003-11-19 | 3d |  |  |  |
| 620 | 1.6.6.5.1.1 | Layout new Logic Board Design | 3d | 2003-11-17 A | 2003-11-19 A |  | 100% |  | 2003-11-17 | 2003-11-19 | 3d |  |  | start no earlier than 2003-11-17 |
| 621 | 1.6.6.5.2 | **Fabrication** | 10d | 2004-03-08 A | 2004-03-19 A |  | 100% |  | 2004-02-09 | 2004-02-23 | 10d |  |  |  |
| 622 | 1.6.6.5.2.1 | FM 1 & FM 2 Logic Board Fabrication | 10d | 2004-03-08 A | 2004-03-19 A | 620, 636 | 100% |  | 2004-02-09 | 2004-02-23 | 10d |  |  | start no earlier than 2004-02-02 |
| 623 | 1.6.6.5.3 | **Assembly** | 75d | 2004-04-14 | 2004-07-28 |  |  |  | 2004-03-09 | 2004-07-07 | 86d | -13d | 0d |  |
| 624 | 1.6.6.5.3.1 | **FM 1** | 58d | 2004-04-14 | 2004-07-05 |  |  |  | 2004-03-09 | 2004-05-27 | 58d | -13d | 0d |  |
| 625 | 1.6.6.5.3.1.1 | Assemble FM 1 Logic Board with ETU ACTELs | 11d | 2004-04-14 | 2004-04-28 | 638FS+9d |  |  | 2004-03-09 | 2004-03-23 | 11d | -13d | 0d |  |
| 626 | 1.6.6.5.3.1.2 | Disassembel FM 1 Logic Board with ETU ACTELs | 1d | 2004-06-30 | 2004-06-30 | 695 |  |  | 2004-05-24 | 2004-05-24 | 1d | -13d | 0d |  |
| 627 | 1.6.6.5.3.1.3 | Retrofit/Inspect FM 1 Flight ACTELs | 2d | 2004-07-01 | 2004-07-02 | 626, 596 |  |  | 2004-05-25 | 2004-05-26 | 2d | -13d | 0d |  |
| 628 | 1.6.6.5.3.1.4 | Reassemble FM 1 Logic Board with Flight ACTELs | 1d | 2004-07-05 | 2004-07-05 | 627 |  |  | 2004-05-27 | 2004-05-27 | 1d | -13d | 0d |  |

| ID | WBS | Task | Duration | Start | Finish | Predecessors | Complete | Remaining | Baseline start | Baseline finish | Baseline duration | Total slack | Free slack | Constraint |
| --- | --- | --- | --- | --- | --- | --- | --- | --- | --- | --- | --- | --- | --- | --- |
| 629 | 1.6.6.5.3.2 | **FM 2** | 75d | 2004-04-14 | 2004-07-28 |  |  |  | 2004-03-09 | 2004-07-07 | 86d | 1d |  |  |
| 630 | 1.6.6.5.3.2.1 | Assemble FM 2 Logic Board with ETU ACTELS | 11d | 2004-04-14 | 2004-04-28 | 638FS+9d |  |  | 2004-03-09 | 2004-03-23 | 11d | 18d | 15d |  |
| 631 | 1.6.6.5.3.2.2 | Disassemble FM 2 Logic Boards | 1d | 2004-07-23 | 2004-07-23 | 704, 626SS |  |  | 2004-07-02 | 2004-07-02 | 1d | 1d | 0d |  |
| 632 | 1.6.6.5.3.2.3 | Retrofit/Inspect Flight ACTELS | 2d | 2004-07-26 | 2004-07-27 | 631, 596 |  |  | 2004-07-05 | 2004-07-06 | 2d | 1d | 0d |  |
| 633 | 1.6.6.5.3.2.4 | Reassemble FM 2 Logic Boards | 1d | 2004-07-28 | 2004-07-28 | 632 |  |  | 2004-07-07 | 2004-07-07 | 1d | 1d | 0d |  |
| 634 | 1.6.6.5.4 | **Test** | 183d | 2003-11-10 A | 2004-07-30 |  | 72% | 51.42d | 2003-11-10 | 2004-07-09 | 168d | 1d |  |  |
| 635 | 1.6.6.5.4.1 | **ETU** | 79d | 2003-11-10 A | 2004-03-05 A |  | 100% |  | 2003-11-10 | 2004-02-06 | 60d |  |  |  |
| 636 | 1.6.6.5.4.1.1 | Test New ETU Logic Board | 79d | 2003-11-10 A | 2004-03-05 A |  | 100% |  | 2003-11-10 | 2004-02-06 | 60d |  |  | start no earlier than 2003-11-10 |
| 637 | 1.6.6.5.4.2 | **FM1 & FM 2** | 8d | 2004-03-22 A | 2004-03-31 A |  | 100% |  | 2004-02-24 | 2004-03-08 | 10d |  |  |  |
| 638 | 1.6.6.5.4.2.1 | Coupon Testing | 8d | 2004-03-22 A | 2004-03-31 A | 622 | 100% |  | 2004-02-24 | 2004-03-08 | 10d |  |  |  |
| 639 | 1.6.6.5.4.3 | **FM 1** | 49d | 2004-04-29 | 2004-07-07 |  |  |  | 2004-03-24 | 2004-06-01 | 49d | -13d | 0d |  |
| 640 | 1.6.6.5.4.3.1 | Functional Test of FM 1 Logic Board w/ETU ACTELS | 15d | 2004-04-29 | 2004-05-19 | 625 |  |  | 2004-03-24 | 2004-04-13 | 15d | -13d | 0d |  |
| 641 | 1.6.6.5.4.3.2 | Funtional Test of FM 1 Logic Board w/Flight ACTELS | 2d | 2004-07-06 | 2004-07-07 | 628 |  |  | 2004-05-28 | 2004-06-01 | 2d | -13d | 0d |  |
| 642 | 1.6.6.5.4.4 | **FM 2** | 51d | 2004-05-20 | 2004-07-30 |  |  |  | 2004-04-14 | 2004-07-09 | 62d | 1d |  |  |
| 643 | 1.6.6.5.4.4.1 | Functional Test of FM 2 Logic Board w/ETU ACTELS | 15d | 2004-05-20 | 2004-06-10 | 630, 640 |  |  | 2004-04-14 | 2004-05-04 | 15d | 3d | 2d |  |
| 644 | 1.6.6.5.4.4.2 | Functional Test of FM 2 Logic Board w/Flight ACTELS | 2d | 2004-07-29 | 2004-07-30 | 633 |  |  | 2004-07-08 | 2004-07-09 | 2d | 1d | 0d |  |
| 645 | 1.6.6.6 | **Mother Board** | 107d | 2003-12-22 A | 2004-05-24 |  | 57% | 45.73d | 2003-12-22 | 2004-03-25 | 65d | 2d |  |  |
| 646 | 1.6.6.6.1 | **Design** | 67d | 2003-12-22 A | 2004-03-29 A |  | 100% |  | 2003-12-22 | 2004-02-04 | 30d |  |  |  |
| 647 | 1.6.6.6.1.1 | **FM 1 & FM 2** | 67d | 2003-12-22 A | 2004-03-29 A |  | 100% |  | 2003-12-22 | 2004-02-04 | 30d |  |  |  |
| 648 | 1.6.6.6.1.1.1 | Finalize Mother Board Layout | 30d | 2003-12-22 A | 2004-02-04 A |  | 100% |  | 2003-12-22 | 2004-02-04 | 30d |  |  | start no earlier than 2003-12-22 |
| 649 | 1.6.6.6.1.1.2 | Redesign Mother Board Layout | 17d | 2004-03-05 A | 2004-03-29 A | 648, 659 | 100% |  | 2004-03-05 | 2004-03-29 | 17d |  |  |  |
| 650 | 1.6.6.6.2 | **Fabrication** | 52d | 2004-02-05 A | 2004-04-19 |  | 50% | 26d | 2004-02-05 | 2004-02-26 | 15d | -11d | 0d |  |
| 651 | 1.6.6.6.2.1 | **FM 1 & FM 2** | 52d | 2004-02-05 A | 2004-04-19 |  | 50% | 26d | 2004-02-05 | 2004-02-26 | 15d | -11d | 0d |  |
| 652 | 1.6.6.6.2.1.1 | Fabricate FM 1 & FM 2 Mother Boards | 15d | 2004-02-05 A | 2004-02-26 A |  | 100% |  | 2004-02-05 | 2004-02-26 | 15d |  |  |  |
| 653 | 1.6.6.6.2.1.2 | Refabricate FM1 & FM2 Mother Boards | 15d | 2004-03-30 | 2004-04-19 | 659, 649 |  |  | 2004-03-30 | 2004-04-19 | 15d | -11d | 0d |  |

| ID | WBS | Task | Duration | Start | Finish | Predecessors | Complete | Remaining | Baseline start | Baseline finish | Baseline duration | Total slack | Free slack | Constraint |
| --- | --- | --- | --- | --- | --- | --- | --- | --- | --- | --- | --- | --- | --- | --- |
| 654 | 1.6.6.6.3 | **Assembly** | 10d | 2004-04-27 | 2004-05-10 |  |  |  | 2004-02-27 | 2004-03-11 | 10d | -11d | 0d |  |
| 655 | 1.6.6.6.3.1 | Assemble FM 1 Mother Board | 10d | 2004-04-27 | 2004-05-10 | 652, 660 |  |  | 2004-02-27 | 2004-03-11 | 10d | -11d | 0d | start no earlier than 2004-03-15 |
| 656 | 1.6.6.6.3.2 | Assemble FM 2 Mother Board | 10d | 2004-04-27 | 2004-05-10 | 655SS |  |  | 2004-02-27 | 2004-03-11 | 10d | 7d | 5d |  |
| 657 | 1.6.6.6.4 | **Test** | 62d | 2004-02-27 A | 2004-05-24 |  | 25% | 46.5d | 2004-02-27 | 2004-03-25 | 20d | 2d |  |  |
| 658 | 1.6.6.6.4.1 | **FM 1 & FM 2** | 42d | 2004-02-27 A | 2004-04-26 |  | 50% | 21d | 2004-02-27 | 2004-03-18 | 15d | -11d | 0d |  |
| 659 | 1.6.6.6.4.1.1 | Coupon Testing of Mother Boards | 5d | 2004-02-27 A | 2004-03-04 A |  | 100% |  | 2004-02-27 | 2004-03-18 | 15d |  |  |  |
| 660 | 1.6.6.6.4.1.2 | Coupon Testing of 2nd Mother Boards | 5d | 2004-04-20 | 2004-04-26 | 653 |  |  | 2004-04-20 | 2004-04-26 | 5d | -11d | 0d |  |
| 661 | 1.6.6.6.4.2 | **FM 1** | 5d | 2004-05-11 | 2004-05-17 |  |  |  | 2004-03-12 | 2004-03-18 | 5d | -11d | 0d |  |
| 662 | 1.6.6.6.4.2.1 | Functional Test FM 1 Mother Board | 5d | 2004-05-11 | 2004-05-17 | 655 |  |  | 2004-03-12 | 2004-03-18 | 5d | -11d | 0d |  |
| 663 | 1.6.6.6.4.3 | **FM 2** | 5d | 2004-05-18 | 2004-05-24 |  |  |  | 2004-03-19 | 2004-03-25 | 5d | 2d |  |  |
| 664 | 1.6.6.6.4.3.1 | Functional Test FM 2 Mother Board | 5d | 2004-05-18 | 2004-05-24 | 656, 662 |  |  | 2004-03-19 | 2004-03-25 | 5d | 2d | 0d |  |
| 665 | 1.6.6.7 | **HVPS** | 104d | 2004-01-12 A | 2004-06-08 |  | 75% | 26d | 2004-01-12 | 2004-04-27 | 75d | 2d |  |  |
| 666 | 1.6.6.7.1 | **Test** | 104d | 2004-01-12 A | 2004-06-08 |  | 75% | 26d | 2004-01-12 | 2004-04-27 | 75d | 2d |  |  |
| 667 | 1.6.6.7.1.1 | **FM 1** | 30d | 2004-01-12 A | 2004-02-24 A |  | 100% |  | 2004-01-12 | 2004-02-09 | 20d |  |  |  |
| 668 | 1.6.6.7.1.1.1 | Functional Test SIT FM 1 HVPS | 30d | 2004-01-12 A | 2004-02-24 A | 71 | 100% |  | 2004-01-12 | 2004-02-09 | 20d |  |  | start no earlier than 2004-01-12 |
| 669 | 1.6.6.7.1.2 | **FM 2** | 10d | 2004-05-25 | 2004-06-08 |  |  |  | 2004-04-14 | 2004-04-27 | 10d | 2d |  |  |
| 670 | 1.6.6.7.1.2.1 | Functional Test SIT FM 2 HVPS | 10d | 2004-05-25 | 2004-06-08 | 77, 664 |  |  | 2004-04-14 | 2004-04-27 | 10d | 2d | 1d |  |
| 671 | 1.6.6.8 | **Flight Software** | 210d | 2003-06-02 A | 2004-04-01 |  | 89% | 24d | 2003-06-02 | 2004-04-01 | 210d | 48d |  |  |
| 672 | 1.6.6.8.1 | **Test** | 210d | 2003-06-02 A | 2004-04-01 |  | 89% | 24d | 2003-06-02 | 2004-04-01 | 210d | 48d |  |  |
| 673 | 1.6.6.8.1.1 | **FM 1 & FM 2** | 210d | 2003-06-02 A | 2004-04-01 |  | 89% | 24d | 2003-06-02 | 2004-04-01 | 210d | 48d |  |  |
| 674 | 1.6.6.8.1.1.1 | Validate SIT On-Board Code | 210d | 2003-06-02 A | 2004-04-01 |  | 89% | 24d | 2003-06-02 | 2004-04-01 | 210d | 48d |  | start no earlier than 2003-06-02 |
| 675 | 1.6.6.9 | **Integration & Test (using ETU Telescope for FM 1)** | 121d | 2004-02-25 A | 2004-08-12 |  | 4% | 116.63d | 2004-03-31 | 2004-07-22 | 81d | 1d |  |  |
| 676 | 1.6.6.9.1 | **FM 1 (Flight Telescope)** | 12d | 2004-07-08 | 2004-07-23 |  |  |  | 2004-06-02 | 2004-06-17 | 12d | -13d | 0d |  |
| 677 | 1.6.6.9.1.1 | Disassemble SIT FM 1 | 1d | 2004-07-08 | 2004-07-08 | 641 |  |  | 2004-06-02 | 2004-06-02 | 1d | -13d | 0d |  |
| 678 | 1.6.6.9.1.2 | Conformal Coat SIT FM 1 Boards (includes FM 1 LVPS) | 2d | 2004-07-09 | 2004-07-12 | 677 |  |  | 2004-06-03 | 2004-06-04 | 2d | -13d | 0d |  |
| 679 | 1.6.6.9.1.3 | Reassemble SIT FM 1 with Flight Telescope | 1d | 2004-07-13 | 2004-07-13 | 678, 398, 364 |  |  | 2004-06-07 | 2004-06-07 | 1d | -13d | 0d |  |
| 680 | 1.6.6.9.1.4 | Bench Calibration SIT FM 1 w/Flight Telescope | 3d | 2004-07-14 | 2004-07-16 | 679 |  |  | 2004-06-08 | 2004-06-10 | 3d | -13d | 0d |  |
| 681 | 1.6.6.9.1.5 | Vacuum Test SIT FM 1 w/Flight Telescope | 5d | 2004-07-19 | 2004-07-23 | 680 |  |  | 2004-06-11 | 2004-06-17 | 5d | -13d | 0d |  |

Notes:
- 659: After Coupon testing a Mechnical Interface error was found in the board. The design was changed and sent out for Fabrication again.

| ID | WBS | Task | Duration | Start | Finish | Predecessors | Complete | Remaining | Baseline start | Baseline finish | Baseline duration | Total slack | Free slack | Text1 |
| --- | --- | --- | --- | --- | --- | --- | --- | --- | --- | --- | --- | --- | --- | --- |
| 682 | 1.6.6.9.2 | **FM 2** | 9d | 2004-08-02 | 2004-08-12 |  |  |  | 2004-07-12 | 2004-07-22 | 9d | 1d |  |  |
| 683 | 1.6.6.9.2.1 | Disassemble SIT FM 2 | 1d | 2004-08-02 | 2004-08-02 | 644 |  |  | 2004-07-12 | 2004-07-12 | 1d | 1d | 0d |  |
| 684 | 1.6.6.9.2.2 | Conformal Coat SIT FM 2 Boards | 2d | 2004-08-03 | 2004-08-04 | 683 |  |  | 2004-07-13 | 2004-07-14 | 2d | 1d | 0d |  |
| 685 | 1.6.6.9.2.3 | Reassemble SIT FM 2 | 1d | 2004-08-05 | 2004-08-05 | 684 |  |  | 2004-07-15 | 2004-07-15 | 1d | 1d | 0d |  |
| 686 | 1.6.6.9.2.4 | Post-Coat Retest SIT FM 2 | 5d | 2004-08-06 | 2004-08-12 | 685 |  |  | 2004-07-16 | 2004-07-22 | 5d | 1d | 0d |  |
| 687 | 1.6.6.9.3 | **FM 1 (ETU Telescope)** | 89d | 2004-02-25 A | 2004-06-29 |  | 10% | 80.39d | 2004-03-31 | 2004-05-21 | 38d | -13d | 0d |  |
| 688 | 1.6.6.9.3.1 | Integrate SIT FM 1 HVPS and SIT ETU Telescope Without Electronics | 3d | 2004-02-25 A | 2004-02-27 A | 668 | 100% |  | 2004-03-31 | 2004-04-02 | 3d |  |  | MS-SEP |
| 689 | 1.6.6.9.3.2 | Integrate Electronics to SIT ETU Telescope | 2d | 2004-05-20 | 2004-05-21 | 640, 602, 662, 615, 688 |  |  | 2004-04-14 | 2004-04-15 | 2d | -13d | 0d |  |
| 690 | 1.6.6.9.3.3 | SIT FM 1 Debug | 5d | 2004-05-24 | 2004-05-28 | 689 |  |  | 2004-04-16 | 2004-04-22 | 5d | -13d | 0d |  |
| 691 | 1.6.6.9.3.4 | SIT FM 1 Bench Test | 5d | 2004-06-01 | 2004-06-07 | 690 |  |  | 2004-04-23 | 2004-04-29 | 5d | -13d | 0d |  |
| 692 | 1.6.6.9.3.5 | SIT FM 1 Alpha TEST | 5d | 2004-06-08 | 2004-06-14 | 691 |  |  | 2004-04-30 | 2004-05-06 | 5d | -13d | 0d |  |
| 693 | 1.6.6.9.3.6 | SIT FM 1 Noise Removal | 5d | 2004-06-15 | 2004-06-21 | 692 |  |  | 2004-05-07 | 2004-05-13 | 5d | -13d | 0d |  |
| 694 | 1.6.6.9.3.7 | SIT FM 1 Thermal Test | 5d | 2004-06-22 | 2004-06-28 | 693 |  |  | 2004-05-14 | 2004-05-20 | 5d | -13d | 0d |  |
| 695 | 1.6.6.9.3.8 | SIT FM 1 Functional Test | 1d | 2004-06-29 | 2004-06-29 | 694, 674 |  |  | 2004-05-21 | 2004-05-21 | 1d | -13d | 0d |  |
| 696 | 1.6.6.9.4 | **FM 2** | 31d | 2004-06-10 | 2004-07-22 |  |  |  | 2004-05-19 | 2004-07-01 | 31d | 1d |  |  |
| 697 | 1.6.6.9.4.1 | Integrate SIT FM 2 HVPS and SIT FM 2 Telescope Without Electronics | 3d | 2004-06-10 | 2004-06-14 | 670, 398, 364 |  |  | 2004-05-19 | 2004-05-21 | 3d | 1d | 0d | MS-SEP |
| 698 | 1.6.6.9.4.2 | Integrate Electronics to SIT FM 2 Telescope | 2d | 2004-06-15 | 2004-06-16 | 643, 604, 664, 617, 697 |  |  | 2004-05-24 | 2004-05-25 | 2d | 1d | 0d |  |
| 699 | 1.6.6.9.4.3 | SIT FM 2 Debug | 5d | 2004-06-17 | 2004-06-23 | 698 |  |  | 2004-05-26 | 2004-06-02 | 5d | 1d | 0d |  |
| 700 | 1.6.6.9.4.4 | SIT FM 2 Bench Test | 5d | 2004-06-24 | 2004-06-30 | 699 |  |  | 2004-06-03 | 2004-06-09 | 5d | 1d | 0d |  |
| 701 | 1.6.6.9.4.5 | SIT FM 2 Alpha Test | 5d | 2004-07-01 | 2004-07-07 | 700 |  |  | 2004-06-10 | 2004-06-16 | 5d | 1d | 0d |  |
| 702 | 1.6.6.9.4.6 | SIT FM 2 Noise Removal | 5d | 2004-07-08 | 2004-07-14 | 701, 693 |  |  | 2004-06-17 | 2004-06-23 | 5d | 1d | 0d |  |
| 703 | 1.6.6.9.4.7 | SIT FM 2 Thermal Test | 5d | 2004-07-15 | 2004-07-21 | 702 |  |  | 2004-06-24 | 2004-06-30 | 5d | 1d | 0d |  |
| 704 | 1.6.6.9.4.8 | SIT FM 2 Functional Test | 1d | 2004-07-22 | 2004-07-22 | 703 |  |  | 2004-07-01 | 2004-07-01 | 1d | 1d | 0d |  |
| 705 | 1.6.6.10 | Integrate SIT Door FM 1 | 1d | 2004-08-20 | 2004-08-20 | 589, 411 |  |  | 2004-08-20 | 2004-08-20 | 1d | -3d | 0d |  |
| 706 | 1.6.6.11 | Integrate SIT Door FM 2 | 1d | 2004-09-02 | 2004-09-02 | 592, 705 |  |  | 2004-09-01 | 2004-09-01 | 1d | 313d |  |  |

| ID | WBS | Task | Duration | Start | Finish | Predecessors | Complete | Remaining | Baseline start | Baseline finish | Baseline duration | Total slack | Free slack | Constraint |
| --- | --- | --- | --- | --- | --- | --- | --- | --- | --- | --- | --- | --- | --- | --- |
| 707 | 1.6.6.12 | **Environmental Testing at GSFC (FM 1)** | 34d | 2004-08-23 | 2004-10-08 |  |  |  | 2004-07-15 | 2004-08-31 | 34d | -3d | 0d |  |
| 708 | 1.6.6.12.1 | SIT FM 1 Vibration and Acoustics | 10d | 2004-08-23 | 2004-09-03 | 589, 705 |  |  | 2004-07-15 | 2004-07-28 | 10d | -3d | 0d | start no earlier than 2004-08-23 |
| 709 | 1.6.6.12.2 | Functional Test | 1d | 2004-09-07 | 2004-09-07 | 708 |  |  | 2004-07-29 | 2004-07-29 | 1d | -3d | 0d |  |
| 710 | 1.6.6.12.3 | SIT FM 1 Thermal Balance | 5d | 2004-09-08 | 2004-09-14 | 709 |  |  | 2004-07-30 | 2004-08-05 | 5d | -3d | 0d |  |
| 711 | 1.6.6.12.4 | SIT FM 1 Thermal Vac | 10d | 2004-09-15 | 2004-09-28 | 710 |  |  | 2004-08-06 | 2004-08-19 | 10d | -3d | 0d |  |
| 712 | 1.6.6.12.5 | Disassemble SIT Instruments | 2d | 2004-09-29 | 2004-09-30 | 711 |  |  | 2004-08-20 | 2004-08-23 | 2d | -3d | 0d |  |
| 713 | 1.6.6.12.6 | Bake Out | 3d | 2004-10-01 | 2004-10-05 | 712 |  |  | 2004-08-24 | 2004-08-26 | 3d | -3d | 0d |  |
| 714 | 1.6.6.12.7 | Reassemble Instruments | 2d | 2004-10-06 | 2004-10-07 | 713 |  |  | 2004-08-27 | 2004-08-30 | 2d | -3d | 0d |  |
| 715 | 1.6.6.12.8 | Functional Test | 1d | 2004-10-08 | 2004-10-08 | 714 |  |  | 2004-08-31 | 2004-08-31 | 1d | -3d | 0d |  |
| 716 | 1.6.6.13 | **Environmental Testing at GSFC (FM 2)** | 34d | 2004-09-02 | 2004-10-21 |  |  |  | 2004-08-23 | 2004-10-08 | 34d | 3d |  |  |
| 717 | 1.6.6.13.1 | SIT FM 2 Vibration and Acoustics | 10d | 2004-09-02 | 2004-09-16 | 592 |  |  | 2004-08-23 | 2004-09-03 | 10d | 3d | 0d | start no earlier than 2004-09-02 |
| 718 | 1.6.6.13.2 | Functional Test | 1d | 2004-09-17 | 2004-09-17 | 717 |  |  | 2004-09-07 | 2004-09-07 | 1d | 3d | 0d |  |
| 719 | 1.6.6.13.3 | SIT FM 2 Thermal Balance | 5d | 2004-09-20 | 2004-09-24 | 718 |  |  | 2004-09-08 | 2004-09-14 | 5d | 3d | 0d |  |
| 720 | 1.6.6.13.4 | SIT FM 2 Thermal Vac | 10d | 2004-09-27 | 2004-10-08 | 719 |  |  | 2004-09-15 | 2004-09-28 | 10d | 3d | 0d |  |
| 721 | 1.6.6.13.5 | Disassemble SIT Instruments | 2d | 2004-10-12 | 2004-10-13 | 720 |  |  | 2004-09-29 | 2004-09-30 | 2d | 3d | 0d |  |
| 722 | 1.6.6.13.6 | Bake Out | 3d | 2004-10-14 | 2004-10-18 | 721 |  |  | 2004-10-01 | 2004-10-05 | 3d | 3d | 0d |  |
| 723 | 1.6.6.13.7 | Reassemble Instruments | 2d | 2004-10-19 | 2004-10-20 | 722 |  |  | 2004-10-06 | 2004-10-07 | 2d | 3d | 0d |  |
| 724 | 1.6.6.13.8 | Functional Test | 1d | 2004-10-21 | 2004-10-21 | 723 |  |  | 2004-10-08 | 2004-10-08 | 1d | 3d | 0d |  |
| 725 | 1.6.6.14 | **Emulators/Simulators/GSE** | 209d | 2003-12-17 A | 2004-10-13 |  | 10% | 187.26d | 2003-12-17 | 2004-10-20 | 214d | 9d |  |  |
| 726 | 1.6.6.14.1 | **Simulators** | 80d | 2003-12-17 A | 2004-04-12 |  | 13% | 69.6d | 2003-12-17 | 2004-04-12 | 80d | 98d |  |  |
| 727 | 1.6.6.14.1.1 | Labview CPU Ready | 80d | 2003-12-17 A | 2004-04-12 |  | 13% | 69.6d | 2003-12-17 | 2004-04-12 | 80d | 0d |  | must start on 2003-12-17 |
| 728 | 1.6.6.14.1.2 | Test Simulator | 80d | 2003-12-17 A | 2004-04-12 | 727SS | 13% | 69.6d | 2003-12-17 | 2004-04-12 | 80d | 98d | 89d |  |
| 729 | 1.6.6.14.2 | **GSE** | 40d | 2004-08-17 | 2004-10-13 |  |  |  | 2004-07-27 | 2004-10-20 | 60d | 9d |  |  |
| 730 | 1.6.6.14.2.1 | Pulse Generator | 40d | 2004-08-17 | 2004-10-13 | 588, 591, 728 |  |  | 2004-07-27 | 2004-10-20 | 60d | 9d | 6d |  |

| ID | WBS | Task | Duration | Start | Finish | Predecessors | Complete | Remaining | Baseline start | Baseline finish | Baseline duration | Total slack | Free slack | Constraint | Text1 |
| --- | --- | --- | --- | --- | --- | --- | --- | --- | --- | --- | --- | --- | --- | --- | --- |
| 731 | 1.6.7 | **SEP Suite I&T - CIT** | 312d | 2003-08-01 A | 2004-10-26 |  | 39% | 190.49d | 2003-08-01 | 2004-10-21 | 309d | 2d |  |  |  |
| 732 | 1.6.7.1 | **ETU** | 5d | 2004-01-26 A | 2004-01-30 A |  | 100% |  | 2004-01-26 | 2004-01-30 | 5d |  |  |  |  |
| 733 | 1.6.7.1.1 | Complete Integration/Test of SEP Central EM with Sensors | 5d | 2004-01-26 A | 2004-01-30 A |  | 100% |  | 2004-01-26 | 2004-01-30 | 5d |  |  | start no earlier than 2004-01-26 |  |
| 734 | 1.6.7.2 | **FM 1 & FM 2** | 97d | 2004-03-09 | 2004-07-22 |  |  |  | 2004-03-05 | 2004-10-21 | 162d | -8d | 0d |  |  |
| 735 | 1.6.7.2.1 | Generate SEPT integration & test procedure | 5d | 2004-03-09 | 2004-03-15 | 744FS-10d |  |  | 2004-03-05 | 2004-03-11 | 5d | 78d | 74d |  |  |
| 736 | 1.6.7.2.2 | Generate LET integration & test procedure | 5d | 2004-06-16 | 2004-06-22 | 745FS-10d |  |  | 2004-05-05 | 2004-05-11 | 5d | 9d |  |  |  |
| 737 | 1.6.7.2.3 | Generate HET integration & test procedure | 5d | 2004-06-28 | 2004-07-02 | 747FS-10d |  |  | 2004-05-20 | 2004-05-26 | 5d | 2d |  |  |  |
| 738 | 1.6.7.2.4 | Generate SIT integration & test procedure | 5d | 2004-07-15 | 2004-07-21 | 751FS-10d |  |  | 2004-06-09 | 2004-06-15 | 5d | -8d | 0d |  |  |
| 739 | 1.6.7.2.5 | Generate SEP system test procedure | 5d | 2004-07-16 | 2004-07-22 | 752FS-10d |  |  | 2004-06-10 | 2004-06-16 | 5d | -8d | 0d |  |  |
| 740 | 1.6.7.2.6 | Generate SEP-IDPU integration procedure | 5d | 2004-07-08 | 2004-07-14 | 748FS-10d |  |  | 2004-05-27 | 2004-06-03 | 5d | -9d | 0d |  |  |
| 741 | 1.6.7.2.7 | Generate SEP-IDPU test procedure | 5d | 2004-07-15 | 2004-07-21 | 740 |  |  | 2004-06-04 | 2004-06-10 | 5d | -9d | 0d |  |  |
| 742 | 1.6.7.3 | **FM 1** | 96d | 2004-03-22 | 2004-08-03 |  |  |  | 2004-03-18 | 2004-06-28 | 72d | -13d | 0d |  | MS-SEP |
| 743 | 1.6.7.3.1 | Integrate/test SEP Central FM 1 | 5d | 2004-06-22 | 2004-06-28 | 419, 421, 374 |  |  | 2004-05-11 | 2004-05-17 | 5d | 4d | 0d |  |  |
| 744 | 1.6.7.3.2 | Receive & inspect SEPT FM 1 | 1d | 2004-03-22 | 2004-03-22 | 524, 525 |  |  | 2004-03-18 | 2004-03-18 | 1d | 73d | 0d |  |  |
| 745 | 1.6.7.3.3 | Integrate & test SEPT FM 1 | 1d | 2004-06-29 | 2004-06-29 | 735, 743, 744 |  |  | 2004-05-18 | 2004-05-18 | 1d | 4d | 0d |  |  |
| 746 | 1.6.7.3.4 | Integrate & test LET FM 1 | 1d | 2004-07-20 | 2004-07-20 | 736, 745, 501, 503 |  |  | 2004-06-09 | 2004-06-09 | 1d | -10d | 0d |  |  |
| 747 | 1.6.7.3.5 | Receive & inspect HET FM 1 | 1d | 2004-07-09 | 2004-07-09 | 449, 451 |  |  | 2004-06-03 | 2004-06-03 | 1d | -3d | 0d |  |  |
| 748 | 1.6.7.3.6 | Integrate & test HET FM 1 | 1d | 2004-07-21 | 2004-07-21 | 737, 746, 747 |  |  | 2004-06-10 | 2004-06-10 | 1d | -10d | 0d |  |  |
| 749 | 1.6.7.3.7 | Integrate SEP FM 1 - IDPU FM 1 | 1d | 2004-07-22 | 2004-07-22 | 740, 748 |  |  | 2004-06-11 | 2004-06-11 | 1d | -10d | 0d |  |  |
| 750 | 1.6.7.3.8 | Test SEP FM 1 - IDPU FM 1 | 1d | 2004-07-23 | 2004-07-23 | 741, 749, 350 |  |  | 2004-06-22 | 2004-06-22 | 1d | -10d | 0d |  |  |
| 751 | 1.6.7.3.9 | Receive & inspect SIT FM 1 | 1d | 2004-07-28 | 2004-07-28 | 588 |  |  | 2004-06-22 | 2004-06-22 | 1d | -13d | 0d |  |  |
| 752 | 1.6.7.3.10 | Integrate & test SIT FM 1 | 1d | 2004-07-29 | 2004-07-29 | 738, 748, 751, 750 |  |  | 2004-06-23 | 2004-06-23 | 1d | -13d | 0d |  |  |
| 753 | 1.6.7.3.11 | SEP system test FM 1 | 3d | 2004-07-30 | 2004-08-03 | 739, 752, 416 |  |  | 2004-06-24 | 2004-06-28 | 3d | -13d | 0d |  |  |
| 754 | 1.6.7.4 | **FM 2** | 107d | 2004-03-25 | 2004-08-23 |  |  |  | 2004-03-29 | 2004-08-11 | 97d | 2d |  |  | MS-SEP |
| 755 | 1.6.7.4.1 | Integrate/testSEP Central FM 2 | 5d | 2004-06-22 | 2004-06-28 | 420, 421, 374 |  |  | 2004-05-11 | 2004-05-17 | 5d | 37d | 0d |  |  |
| 756 | 1.6.7.4.2 | Receive & inspect SEPT FM 2 | 1d | 2004-03-25 | 2004-03-25 | 527, 528 |  |  | 2004-03-29 | 2004-03-29 | 1d | 103d | 66d |  |  |
| 757 | 1.6.7.4.3 | Integrate & test SEPT FM 2 | 1d | 2004-06-29 | 2004-06-29 | 735, 755, 756 |  |  | 2004-05-18 | 2004-05-18 | 1d | 37d | 14d |  |  |
| 758 | 1.6.7.4.4 | Integrate & test LET FM 2 | 1d | 2004-07-20 | 2004-07-20 | 736, 757, 502, 503 |  |  | 2004-06-09 | 2004-06-09 | 1d | 23d | 8d |  |  |
| 759 | 1.6.7.4.5 | Receive & inspect HET FM 2 | 1d | 2004-07-30 | 2004-07-30 | 450 |  |  | 2004-06-24 | 2004-06-24 | 1d | 15d | 0d |  |  |
| 760 | 1.6.7.4.6 | Integrate & test HET FM 2 | 1d | 2004-08-02 | 2004-08-02 | 737, 758, 759 |  |  | 2004-06-25 | 2004-06-25 | 1d | 15d | 0d |  |  |
| 761 | 1.6.7.4.7 | Integrate SEP FM 2 - IDPU FM 2 | 1d | 2004-08-03 | 2004-08-03 | 740, 760, 160 |  |  | 2004-06-28 | 2004-06-28 | 1d | 15d | 0d |  |  |
| 762 | 1.6.7.4.8 | Test SEP FM 2 - IDPU FM 2 | 1d | 2004-08-04 | 2004-08-04 | 741, 761 |  |  | 2004-06-29 | 2004-06-29 | 1d | 15d | 9d |  |  |
| 763 | 1.6.7.4.9 | Receive & inspect SIT FM 2 | 1d | 2004-08-17 | 2004-08-17 | 591 |  |  | 2004-07-27 | 2004-07-27 | 1d | 1d | 0d |  |  |
| 764 | 1.6.7.4.10 | Integrate & test SIT FM 2 | 1d | 2004-08-18 | 2004-08-18 | 738, 763 |  |  | 2004-08-06 | 2004-08-06 | 1d | 1d | 0d |  |  |
| 765 | 1.6.7.4.11 | SEP FM 2 system test | 3d | 2004-08-19 | 2004-08-23 | 739, 764 |  |  | 2004-08-09 | 2004-08-11 | 3d | 1d | 0d |  |  |

| ID | WBS | Task | Duration | Start | Finish | Predecessors | Complete | Remaining | Baseline start | Baseline finish | Baseline duration | Total slack | Free slack | Constraint | Text1 |
| --- | --- | --- | --- | --- | --- | --- | --- | --- | --- | --- | --- | --- | --- | --- | --- |
| 766 | 1.6.7.5 | **Environmental Test (at JPL)** | 114d | 2004-05-17 | 2004-10-26 |  |  |  | 2004-05-17 | 2004-09-24 | 93d | 2d |  |  |  |
| 767 | 1.6.7.5.1 | Generate Environmental Test Procedures | 15d | 2004-05-17 | 2004-06-07 |  |  |  | 2004-05-17 | 2004-06-07 | 15d | 46d |  | start no earlier than 2004-05-17 |  |
| 768 | 1.6.7.5.2 | Manufacture test cables (JPL) | 20d | 2004-06-01 | 2004-06-28 |  |  |  | 2004-06-01 | 2004-06-28 | 20d | 31d |  | start no earlier than 2004-06-01 |  |
| 769 | 1.6.7.5.3 | **FM 1** | 40d | 2004-08-30 | 2004-10-26 |  |  |  | 2004-07-23 | 2004-09-24 | 45d | -13d | 0d |  |  |
| 770 | 1.6.7.5.3.1 | FM 1 LET/HET/SEP Central Vibration/Acoustics Test | 10d | 2004-08-30 | 2004-09-13 | 19FS+3d, 767, 768, 784FS+3d |  |  | 2004-07-23 | 2004-08-05 | 10d | -13d | 0d |  |  |
| 771 | 1.6.7.5.3.2 | FM 1 LET/HET/SEP Central Thermal Balance Test | 5d | 2004-09-14 | 2004-09-20 | 770 |  |  | 2004-08-06 | 2004-08-12 | 5d | -13d | 0d |  |  |
| 772 | 1.6.7.5.3.3 | FM 1 LET/HET/SEP Central T/V Test | 15d | 2004-09-21 | 2004-10-12 | 771, 777 |  |  | 2004-08-19 | 2004-09-09 | 15d | -13d | 0d |  |  |
| 773 | 1.6.7.5.3.4 | Evaluate SEP performance | 10d | 2004-10-13 | 2004-10-26 | 772 |  |  | 2004-09-10 | 2004-09-23 | 10d | -13d | 0d |  |  |
| 774 | 1.6.7.5.3.5 | Generate test reports | 11d | 2004-09-23 | 2004-10-07 | 773SS |  |  | 2004-09-10 | 2004-09-24 | 11d | -13d | 0d | finish no later than 2004-10-07 |  |
| 775 | 1.6.7.5.3.6 | Bakeout Clean SEP exterior & prepare for delivery | 3d | 2004-10-13 | 2004-10-15 | 772 |  |  | 2004-09-10 | 2004-09-14 | 3d | -6d | 0d |  |  |
| 776 | 1.6.7.5.4 | **FM 2** | 41d | 2004-08-24 | 2004-10-21 |  |  |  | 2004-07-23 | 2004-09-24 | 45d | 1d |  |  |  |
| 777 | 1.6.7.5.4.1 | FM 2 EMI/EMC Test at CalTech | 5d | 2004-08-24 | 2004-08-30 | 765 |  |  | 2004-08-12 | 2004-08-18 | 5d | 1d | 0d |  | MS-SEP |
| 778 | 1.6.7.5.4.2 | FM 2 LET/HET/SEP Central Vibration/Acoustics Test | 10d | 2004-08-31 | 2004-09-14 | 785FS+3d, 777 |  |  | 2004-07-23 | 2004-08-05 | 10d | 5d | 0d |  |  |
| 779 | 1.6.7.5.4.3 | FM 2 LET/HET/SEP Central T/V Test | 15d | 2004-09-15 | 2004-10-05 | 777, 778 |  |  | 2004-08-19 | 2004-09-09 | 15d | 5d | 0d |  |  |
| 780 | 1.6.7.5.4.4 | Evaluate SEP performance | 10d | 2004-10-06 | 2004-10-20 | 779 |  |  | 2004-09-10 | 2004-09-23 | 10d | 5d | 0d |  |  |
| 781 | 1.6.7.5.4.5 | Generate test reports | 11d | 2004-10-06 | 2004-10-21 | 780SS |  |  | 2004-09-10 | 2004-09-24 | 11d | 5d |  | finish no later than 2004-10-28 |  |
| 782 | 1.6.7.5.4.6 | Bakeout Clean SEP exterior & prepare for delivery | 3d | 2004-10-06 | 2004-10-08 | 779 |  |  | 2004-09-10 | 2004-09-14 | 3d | 12d | 0d |  |  |
| 783 | 1.6.7.6 | **Accelerator Test (at MSU)** | 5d | 2004-08-18 | 2004-08-24 |  |  |  | 2004-07-13 | 2004-07-19 | 5d | -13d | 0d |  |  |
| 784 | 1.6.7.6.1 | FM 1 LET/SEP Cen end-to-end test at Accelerator | 5d | 2004-08-18 | 2004-08-24 | 790, 19, 405 |  |  | 2004-07-13 | 2004-07-19 | 5d | -13d | 0d |  |  |
| 785 | 1.6.7.6.2 | FM 2 LET/SEP Cen end-to-end test at Accelerator | 5d | 2004-08-18 | 2004-08-24 | 784SS, 762 |  |  | 2004-07-13 | 2004-07-19 | 5d | 6d | 0d |  |  |
| 786 | 1.6.7.7 | **GSE** | 305d | 2003-08-01 A | 2004-10-15 |  | 55% | 137.48d | 2003-08-01 | 2004-10-15 | 305d | 9d |  |  |  |
| 787 | 1.6.7.7.1 | **End-to-End Test Equipment** | 218d | 2003-08-11 A | 2004-06-22 |  | 84% | 35.3d | 2003-08-11 | 2004-06-22 | 218d | 27d |  |  |  |
| 788 | 1.6.7.7.1.1 | Design | 192d | 2003-08-11 A | 2004-05-14 |  | 95% | 9.3d | 2003-08-11 | 2004-05-14 | 192d | 27d | 0d | start no earlier than 2003-08-11 |  |
| 789 | 1.6.7.7.1.2 | Assemble | 21d | 2004-05-17 | 2004-06-15 | 788 |  |  | 2004-05-17 | 2004-06-15 | 21d | 27d | 0d |  |  |
| 790 | 1.6.7.7.1.3 | Test | 5d | 2004-06-16 | 2004-06-22 | 789 |  |  | 2004-06-16 | 2004-06-22 | 5d | 27d |  |  |  |

Notes:
- 783: The Accelerator Test Date is still TBD. The actual testing date will depend on availability of the facility at MSU and the readiness of our flight hardware. The date currently reflected in the schedule is therefore subject to change as required.

| ID | WBS | Task | Duration | Start | Finish | Predecessors | Complete | Remaining | Baseline start | Baseline finish | Baseline duration | Total slack | Free slack | Constraint |
| --- | --- | --- | --- | --- | --- | --- | --- | --- | --- | --- | --- | --- | --- | --- |
| 791 | 1.6.7.7.2 | **GSE software** | 305d | 2003-08-01 A | 2004-10-15 |  | 34% | 200.66d | 2003-08-01 | 2004-10-15 | 305d | 9d |  |  |
| 792 | 1.6.7.7.2.1 | Build GSE software release 2 | 157d | 2003-08-01 A | 2004-03-18 |  | 66% | 53d | 2003-08-01 | 2004-03-18 | 157d | 0d |  | must start on 2003-08-01 |
| 793 | 1.6.7.7.2.2 | Write user's guide | 8d | 2004-03-22 | 2004-03-31 | 792 |  |  | 2004-03-22 | 2004-03-31 | 8d | 31d | 22d | start no earlier than 2004-03-22 |
| 794 | 1.6.7.7.2.3 | Build GSE software release 3 | 117d | 2004-05-03 | 2004-10-15 | 793 |  |  | 2004-05-03 | 2004-10-15 | 117d | 9d | 0d | start no earlier than 2004-05-03 |
| 795 | 1.6.7.7.2.4 | Write user's guide supplement | 22d | 2004-09-15 | 2004-10-15 | 794FS-22d |  |  | 2004-09-15 | 2004-10-15 | 22d | 9d |  | finish no later than 2004-10-28 |
| 796 | 1.7 | **SWEA and SIT Refurbishment (after S/C Environmental Testing)** | 40d | 2005-09-27 | 2005-11-21 |  |  |  | 2005-09-27 | 2005-11-18 | 39d | 0d |  |  |
| 797 | 1.7.1 | Ship SWEA FM 1 to UCB | 3d | 2005-09-27 | 2005-09-29 |  |  |  | 2005-09-27 | 2005-09-29 | 3d | 25d | 0d | start no earlier than 2005-09-27 |
| 798 | 1.7.2 | Ship (Hand Carry) SIT FM 1 to UMD | 1d | 2005-09-27 | 2005-09-27 |  |  |  | 2005-09-27 | 2005-09-27 | 1d | 27d | 0d | start no earlier than 2005-09-27 |
| 799 | 1.7.3 | Ship SWEA FM 2 to UCB | 3d | 2005-10-04 | 2005-10-06 |  |  |  | 2005-10-04 | 2005-10-06 | 3d | 20d | 0d | start no earlier than 2005-10-04 |
| 800 | 1.7.4 | Ship (Hand Carry) SIT FM 2 to UMD | 1d | 2005-10-04 | 2005-10-04 |  |  |  | 2005-10-04 | 2005-10-04 | 1d | 22d | 0d | start no earlier than 2005-10-04 |
| 801 | 1.7.5 | Vacuum Testing of SWEA FM 1 @ UCB | 5d | 2005-09-30 | 2005-10-06 | 797 |  |  | 2005-09-30 | 2005-10-06 | 5d | 25d | 5d |  |
| 802 | 1.7.6 | Vacuum Testing of SIT FM 1 @ UMD | 5d | 2005-09-28 | 2005-10-04 | 798 |  |  | 2005-09-28 | 2005-10-04 | 5d | 27d | 5d |  |
| 803 | 1.7.7 | Vacuum Testing of SWEA FM 2 @ UCB | 5d | 2005-10-07 | 2005-10-13 | 799 |  |  | 2005-10-07 | 2005-10-13 | 5d | 20d | 0d |  |
| 804 | 1.7.8 | Vacuum Testing of SIT FM 2 @ UMD | 5d | 2005-10-05 | 2005-10-11 | 800 |  |  | 2005-10-05 | 2005-10-11 | 5d | 22d | 0d |  |
| 805 | 1.7.9 | Ship SWEA FM 1 & 2 to Launch Site for Re-integration to S/C | 3d | 2005-10-14 | 2005-10-18 | 801, 803 |  |  | 2005-10-07 | 2005-10-11 | 3d | 20d | 0d |  |
| 806 | 1.7.10 | Ship SIT FM 1 & 2 to Launch Site for Re-integration to S/C | 3d | 2005-10-12 | 2005-10-14 | 802, 804 |  |  | 2005-10-05 | 2005-10-07 | 3d | 22d | 2d |  |
| 807 | 1.7.11 | Reintegration of SWEA and SIT to S/C (at Launch Site) | 3d | 2005-10-19 | 2005-10-21 | 805, 806 |  |  | 2005-10-12 | 2005-10-14 | 3d | 20d |  |  |
| 808 | 1.7.12 | Target Date for Reintegration to S/C | 1d | 2005-11-19 | 2005-11-21 | 807 |  |  | 2005-11-18 | 2005-11-18 | 1d | 0d |  | must start on 2005-11-19 |
