# IMPACT Master Schedule

Schedule from MS Project, 2003-02-26 to 2005-10-14, status date 2003-12-31, A marks actual dates.
IMPACT Instrument Suites
NASA GSFC - STEREO
This is the IMPACT Consolidated Schedule. Creation began in October 2003 and was then put on hold and subsequently completed in January 2004. Completed tasks, redundant milestones, contingency blocks and obsolete tasks were deleted from this schedule. / Schedule was baselined on

## Calendars

- Standard: Mon-Fri 08:00-12:00, 13:00-17:00; Sat-Sun off. Exceptions (off unless hours are given): 2003-05-26, 2003-07-04, 2003-09-01, 2003-10-13, 2003-11-11, 2003-11-27, 2003-12-25, 2004-01-01, 2004-01-19, 2004-02-16, 2004-05-31, 2004-09-06, 2004-10-11, 2004-11-11, 2004-11-25.

## Schedule

| ID | WBS | Task | Type | Duration | Start | Finish | Predecessors | Complete | Remaining | Total slack | Free slack | Constraint |
| --- | --- | --- | --- | --- | --- | --- | --- | --- | --- | --- | --- | --- |
| 1 | 1 | **IMPACT - Dave Curtis (UCB) & Lil Reichenthal (GSFC)** |  | 673d | 2003-02-26 A | 2005-10-14 |  | 38% | 414.48d | 0d |  |  |
| 2 | 1.1 | **Suite Deliveries to APL** |  | 51d | 2004-08-13 | 2004-10-28 |  |  |  | 0d |  |  |
| 3 | 1.1.1 | FM 1 Target Delivery Date | milestone | 0d | 2004-10-07 | 2004-10-07 | 5, 7 |  |  | 0d |  | must start on 2004-10-07 |
| 4 | 1.1.2 | FM 1 Target Delivery Date | milestone | 0d | 2004-10-28 | 2004-10-28 | 8, 6 |  |  | 0d |  | must start on 2004-10-28 |
| 5 | 1.1.3 | Boom Suite FM 1 Ready for Delivery to APL | milestone | 0d | 2004-08-13 | 2004-08-13 | 360 |  |  | 37d |  |  |
| 6 | 1.1.4 | Boom Suite FM 2 Ready for Delivery to APL | milestone | 0d | 2004-09-09 | 2004-09-09 | 367 |  |  | 33d |  |  |
| 7 | 1.1.5 | SEP Suite FM 1 Ready for Delivery to APL | milestone | 0d | 2004-09-07 | 2004-09-07 | 788, 596, 525 |  |  | 21d |  |  |
| 8 | 1.1.6 | SEP Suite FM 2 Ready for Delivery to APL | milestone | 0d | 2004-10-04 | 2004-10-04 | 795, 599, 528 |  |  | 16d |  |  |
| 9 | 1.2 | **Environmental Testing - PER, Impact Suite EMC, Snapshots of Boom & SEP Suite Test Flows** |  | 181d | 2004-01-14 A | 2004-09-28 |  |  | 180.51d | 270d |  |  |
| 10 | 1.2.1 | **Reviews (PER and TRR's) - TRR Dates are Tentative** |  | 107d | 2004-01-14 A | 2004-06-15 |  | 14% | 91.71d | 344d |  |  |
| 11 | 1.2.1.1 | Instrument PER at UCB |  | 1d | 2004-01-14 A | 2004-01-14 A |  | 100% |  |  |  | start no earlier than 2004-01-14 |
| 12 | 1.2.1.2 | TRR 1 - Prior to FM 1 SEPT Thermal Vac |  | 1d | 2004-02-13 | 2004-02-13 | 41SS-6d |  |  | 179d |  |  |
| 13 | 1.2.1.3 | TRR 2 - Prior to FM 1 IDPU Vibration |  | 1d | 2004-04-14 | 2004-04-14 | 20SS-5d |  |  | 137d |  |  |
| 14 | 1.2.1.4 | TRR 3 - Prior to FM 1 STE-U Thermal Vac/Thermal Balance |  | 1d | 2004-03-10 | 2004-03-10 | 23SS-5d |  |  | 162d |  |  |
| 15 | 1.2.1.5 | TRR 4 - Prior to FM 1 Boom Structure Vibration |  | 1d | 2004-04-08 | 2004-04-08 | 22SS-5d |  |  | 141d |  |  |
| 16 | 1.2.1.6 | TRR 5 - Prior to FM 1 SWEA Vibration |  | 1d | 2004-05-04 | 2004-05-04 | 25SS-5d |  |  | 123d |  |  |
| 17 | 1.2.1.7 | TRR 6 - Prior to FM 1 Impact Suite EMC (for Boom and SEP) |  | 1d | 2004-06-15 | 2004-06-15 | 18SS-5d |  |  | 344d |  |  |
| 18 | 1.2.2 | IMPACT Suite FM 1 EMC Testing at UCB |  | 10d | 2004-06-22 | 2004-07-05 | 358, 766, 426 |  |  | 14d | 0d |  |
| 19 | 1.2.3 | **Boom Suite FM 1 Environmental Test Flow Snapshot - UCB** |  | 97d | 2004-03-17 | 2004-07-30 |  |  |  | 311d |  |  |
| 20 | 1.2.3.1 | IDPU Vibration |  | 5d | 2004-04-21 | 2004-04-27 | 179SS |  |  | 128d | 0d |  |
| 21 | 1.2.3.2 | IDPU Thermal Vac |  | 10d | 2004-04-28 | 2004-05-11 | 180SS |  |  | 118d |  |  |
| 22 | 1.2.3.3 | Boom Structure Vibration |  | 4d | 2004-04-15 | 2004-04-20 | 218SS |  |  | 133d | 0d |  |
| 23 | 1.2.3.4 | STE-U Thermal Vac and Thermal Balance |  | 14d | 2004-03-17 | 2004-04-05 | 278SS |  |  | 144d | 0d |  |
| 24 | 1.2.3.5 | Boom Structure Thermal Vac |  | 15d | 2004-04-21 | 2004-05-11 | 219SS |  |  | 118d |  |  |
| 25 | 1.2.3.6 | SWEA/STE Vibration |  | 5d | 2004-05-11 | 2004-05-17 | 344SS |  |  | 114d | 0d |  |
| 26 | 1.2.3.7 | SWEA/STE Thermal Vac and Thermal Balance |  | 14d | 2004-07-06 | 2004-07-23 | 345SS |  |  | 316d |  |  |
| 27 | 1.2.3.8 | IDPU Bake Out |  | 5d | 2004-07-06 | 2004-07-12 | 181SS |  |  | 325d |  |  |
| 28 | 1.2.3.9 | Boom Suite Bake Out |  | 5d | 2004-07-26 | 2004-07-30 | 359SS |  |  | 311d |  |  |

Notes:
- 1: This is the new IMPACT Consolidated Schedule. Creation began in October 2003 and was then put on hold and subsequently completed in January 2004. Completed tasks, redundant milestones, contingency blocks and obsolete tasks were deleted from this schedule. / Schedule was baselined on
- 7: The SEPT and SIT instruments are being delivered directly to APL after their environmental testing at GSFC and seperate from the other SEP Suite instruments (SEP Central, LET and HET).
- 8: The SEPT and SIT instruments are being delivered directly to APL after their environmental testing at GSFC and seperate from the other SEP Suite instruments (SEP Central, LET and HET).
- 11: This is the initial IMPACT PER. Additional TRR's (Test Readiness Reviews) will be scheduled and held as the suite instruments become ready for their environmental testing.

| ID | WBS | Task | Duration | Start | Finish | Predecessors | Total slack | Free slack |
| --- | --- | --- | --- | --- | --- | --- | --- | --- |
| 29 | 1.2.4 | **Boom Suite FM 2 Environmental Test Flow Snapshot - UCB** | 93d | 2004-04-16 | 2004-08-25 |  | 293d |  |
| 30 | 1.2.4.1 | Boom Structure Vibration | 4d | 2004-04-16 | 2004-04-21 | 240SS | 132d |  |
| 31 | 1.2.4.2 | IDPU Vibration | 5d | 2004-05-10 | 2004-05-14 | 184SS | 115d |  |
| 32 | 1.2.4.3 | IDPU Thermal Vac | 10d | 2004-05-17 | 2004-05-28 | 185SS | 105d |  |
| 33 | 1.2.4.4 | Boom Structure Thermal Vac | 15d | 2004-05-12 | 2004-06-02 | 241SS | 103d |  |
| 34 | 1.2.4.5 | SWEA/STE Vibration | 5d | 2004-07-14 | 2004-07-20 | 352SS | 69d |  |
| 35 | 1.2.4.6 | SWEA/STE Thermal Vac | 10d | 2004-07-21 | 2004-08-03 | 353SS | 59d |  |
| 36 | 1.2.4.7 | Boom Suite FM 2 EMC | 5d | 2004-08-12 | 2004-08-18 | 365SS | 48d |  |
| 37 | 1.2.4.8 | IDPU Bake Out | 5d | 2004-08-19 | 2004-08-25 | 186SS | 43d |  |
| 38 | 1.2.4.9 | Boom Suite Bake Out | 5d | 2004-08-19 | 2004-08-25 | 366SS | 43d |  |
| 39 | 1.2.5 | **SEP Suite FM 1 Environmental Test Flow Snapshot** | 149d | 2004-02-09 | 2004-09-07 |  | 285d |  |
| 40 | 1.2.5.1 | SEPT Vibe and Acoustics (in Europe) | 10d | 2004-02-09 | 2004-02-23 | 566SS, 573SS | 424d |  |
| 41 | 1.2.5.2 | SEPT Thermal Vac (in Europe) | 10d | 2004-02-24 | 2004-03-08 | 567SS, 574SS | 414d | 0d |
| 42 | 1.2.5.3 | SEPT Bake Out (in Europe) | 3d | 2004-03-09 | 2004-03-11 | 568SS, 575SS | 411d |  |
| 43 | 1.2.5.4 | LET/HET/SEP Cen Accelerator Test (at MSU) | 11d | 2004-07-06 | 2004-07-20 | 797SS | 319d |  |
| 44 | 1.2.5.5 | SEPT Thermal Balance (at GSFC) | 10d | 2004-07-06 | 2004-07-19 | 569SS, 576SS | 320d |  |
| 45 | 1.2.5.6 | LET/HET/SEP Cen Vibe and Acoustics (at JPL) | 10d | 2004-07-16 | 2004-07-29 | 783SS | 312d |  |
| 46 | 1.2.5.7 | LET/HET/SEP Cen Thermal Balance (at JPL) | 5d | 2004-07-30 | 2004-08-05 | 784SS | 307d |  |
| 47 | 1.2.5.8 | LET/HET/SEP Cen Thermal Vac (at JPL) | 15d | 2004-08-12 | 2004-09-01 | 785SS | 288d |  |
| 48 | 1.2.5.9 | LET/HET/SEP Cen Bake Out (at JPL) | 3d | 2004-09-02 | 2004-09-07 | 788SS | 285d |  |
| 49 | 1.2.5.10 | SIT Vibe and Acoustics (at GSFC) | 10d | 2004-07-08 | 2004-07-21 | 718SS | 318d |  |
| 50 | 1.2.5.11 | SIT Thermal Balance (at GSFC) | 5d | 2004-07-23 | 2004-07-29 | 720SS | 312d |  |
| 51 | 1.2.5.12 | SIT Thermal Vac (at GSFC) | 10d | 2004-07-30 | 2004-08-12 | 721SS | 302d |  |
| 52 | 1.2.5.13 | SIT Bake Out (at GSFC) | 3d | 2004-08-17 | 2004-08-19 | 723SS | 297d |  |

| ID | WBS | Task | Type | Duration | Start | Finish | Predecessors | Complete | Remaining | Total slack | Free slack | Constraint |
| --- | --- | --- | --- | --- | --- | --- | --- | --- | --- | --- | --- | --- |
| 53 | 1.2.6 | **SEP Suite FM 2 Environmental Test Flow Snapshot** |  | 168d | 2004-02-03 | 2004-09-28 |  |  |  | 270d |  |  |
| 54 | 1.2.6.1 | SEPT Vibe and Acoustics (in Europe) |  | 10d | 2004-02-03 | 2004-02-17 | 581SS, 588SS |  |  | 428d |  |  |
| 55 | 1.2.6.2 | SEPT Thermal Vac (in Europe) |  | 10d | 2004-02-18 | 2004-03-02 | 582SS, 589SS |  |  | 418d |  |  |
| 56 | 1.2.6.3 | SEPT Bake Out (in Europe) |  | 3d | 2004-03-03 | 2004-03-05 | 583SS, 590SS |  |  | 415d |  |  |
| 57 | 1.2.6.4 | SEP Suite FM 2 EMC (at Caltech) |  | 5d | 2004-08-05 | 2004-08-11 | 790SS |  |  | 303d |  |  |
| 58 | 1.2.6.5 | LET/HET/SEP Cen Accelerator Test (at MSU) |  | 11d | 2004-07-06 | 2004-07-20 | 798SS |  |  | 319d |  |  |
| 59 | 1.2.6.6 | SEPT Thermal Balance (at GSFC) |  | 10d | 2004-07-06 | 2004-07-19 | 584SS, 591SS |  |  | 320d |  |  |
| 60 | 1.2.6.7 | LET/HET/SEP Cen Vibe and Acoustics (at JPL) |  | 10d | 2004-07-16 | 2004-07-29 | 791SS |  |  | 312d |  |  |
| 61 | 1.2.6.8 | LET/HET/SEP Cen Thermal Vac (at JPL) |  | 15d | 2004-08-12 | 2004-09-01 | 792SS |  |  | 288d |  |  |
| 62 | 1.2.6.9 | LET/HET/SEP Cen Bake Out (at JPL) |  | 3d | 2004-09-02 | 2004-09-07 | 795SS |  |  | 285d |  |  |
| 63 | 1.2.6.10 | SIT Vibe and Acoustics (at GSFC) |  | 10d | 2004-08-16 | 2004-08-27 | 727SS |  |  | 291d |  |  |
| 64 | 1.2.6.11 | SIT Thermal Balance (at GSFC) |  | 5d | 2004-08-31 | 2004-09-07 | 729SS |  |  | 285d |  |  |
| 65 | 1.2.6.12 | SIT Thermal Vac (at GSFC) |  | 10d | 2004-09-08 | 2004-09-21 | 730SS |  |  | 275d |  |  |
| 66 | 1.2.6.13 | SIT Bake Out (at GSFC) |  | 3d | 2004-09-24 | 2004-09-28 | 732SS |  |  | 270d |  |  |
| 67 | 1.3 | **Power Converters - UCB** |  | 330d | 2003-02-26 A | 2004-06-16 |  | 45% | 181.65d | 343d |  |  |
| 68 | 1.3.1 | **Deliveries** |  | 100d | 2003-12-09 A | 2004-04-30 |  | 20% | 80d | 44d |  |  |
| 69 | 1.3.1.1 | **FM 1** |  | 87d | 2003-12-09 A | 2004-04-13 |  | 40% | 52.2d | 33d |  |  |
| 70 | 1.3.1.1.1 | Deliver IDPU FM 1 LVPS (stays at UCB) | milestone | 0d | 2004-04-13 | 2004-04-13 | 124 |  |  | 33d | 0d |  |
| 71 | 1.3.1.1.2 | Deliver SEP FM 1 LVPS (to Caltech) |  | 1d | 2004-03-17 | 2004-03-17 | 128 |  |  | 50d | 28d |  |
| 72 | 1.3.1.1.3 | Deliver SWEA/STE FM 1 LVPS (stays at UCB) | milestone | 0d | 2004-03-22 | 2004-03-22 | 132 |  |  | 27d | 0d |  |
| 73 | 1.3.1.1.4 | Deliver PLASTIC FM 1 LVPS (to UNH) |  | 2d | 2004-03-04 | 2004-03-05 | 136 |  |  | 42d |  | finish no later than 2004-05-04 |
| 74 | 1.3.1.1.5 | Deliver SIT FM 1 HVPS (to UMD) |  | 2d | 2003-12-09 A | 2003-12-10 A | 138 | 100% |  |  |  |  |
| 75 | 1.3.1.2 | **FM 2** |  | 28d | 2004-03-24 | 2004-04-30 |  |  |  | 44d |  |  |
| 76 | 1.3.1.2.1 | Deliver IDPU FM 2 LVPS (stays at UCB) | milestone | 0d | 2004-04-30 | 2004-04-30 | 145 |  |  | 37d | 0d |  |
| 77 | 1.3.1.2.2 | Deliver SEP FM 2 LVPS (to Caltech) |  | 1d | 2004-04-19 | 2004-04-19 | 149 |  |  | 27d | 5d |  |
| 78 | 1.3.1.2.3 | Deliver SWEA/STE FM 2 LVPS (stays at UCB) | milestone | 0d | 2004-04-26 | 2004-04-26 | 153 |  |  | 48d | 15d |  |
| 79 | 1.3.1.2.4 | Deliver PLASTIC FM 2 LVPS (to UNH) |  | 2d | 2004-04-12 | 2004-04-13 | 157 |  |  | 41d |  | finish no later than 2004-06-10 |
| 80 | 1.3.1.2.5 | Deliver SIT FM 2 HVPS (to UMD) |  | 2d | 2004-03-24 | 2004-03-25 | 161 |  |  | 44d | 0d |  |

| ID | WBS | Task | Duration | Start | Finish | Predecessors | Complete | Remaining | Total slack | Free slack | Constraint |
| --- | --- | --- | --- | --- | --- | --- | --- | --- | --- | --- | --- |
| 81 | 1.3.2 | **Remaining Flight Procurements** | 71d | 2003-10-24 A | 2004-02-06 |  | 75% | 17.75d | 33d |  |  |
| 82 | 1.3.2.1 | Procure IDPU Flight Printed Wiring Board | 10d | 2004-01-26 | 2004-02-06 | 88 |  |  | 33d | 0d | start no earlier than 2004-01-26 |
| 83 | 1.3.2.2 | Procure SEP Flight Printed Wiring Board | 10d | 2003-11-24 A | 2003-12-08 A | 89 | 100% |  |  |  | start no earlier than 2003-11-24 |
| 84 | 1.3.2.3 | Procure SWEA Flight Printed Wiring Board | 10d | 2003-12-04 A | 2003-12-17 A | 90 | 100% |  |  |  |  |
| 85 | 1.3.2.4 | Procure PLASTIC Flight Printed Wiring Board | 10d | 2003-10-24 A | 2003-11-06 A |  | 100% |  |  |  | start no earlier than 2003-10-24 |
| 86 | 1.3.3 | **Fabrication** | 226d | 2003-02-26 A | 2004-01-20 |  | 86% | 31.81d | 71d |  |  |
| 87 | 1.3.3.1 | **FM 1 & FM 2** | 195d | 2003-02-26 A | 2003-12-03 A |  | 100% |  |  |  |  |
| 88 | 1.3.3.1.1 | Re-layout IDPU LVPS Flight Printed Wiring Board | 186d | 2003-02-26 A | 2003-11-19 A |  | 100% |  |  |  | start no earlier than 2003-02-26 |
| 89 | 1.3.3.1.2 | Re-layout SEP LVPS Flight Printed Wiring Board | 32d | 2003-09-24 A | 2003-11-07 A |  | 100% |  |  |  | start no earlier than 2003-09-24 |
| 90 | 1.3.3.1.3 | Re-layout SWEA LVPS Flight Printed Wiring Board | 5d | 2003-11-26 A | 2003-12-03 A |  | 100% |  |  |  | start no earlier than 2003-11-26 |
| 91 | 1.3.3.2 | **FM 1** | 45d | 2003-09-29 A | 2003-12-03 A |  | 100% |  |  |  |  |
| 92 | 1.3.3.2.1 | Wind IDPU LVPS FM 1 Magnets | 10d | 2003-10-17 A | 2003-10-30 A |  | 100% |  |  |  | start no earlier than 2003-10-17 |
| 93 | 1.3.3.2.2 | Wind SEP LVPS FM 1 Magnets | 15d | 2003-09-29 A | 2003-10-20 A |  | 100% |  |  |  | start no earlier than 2003-09-29 |
| 94 | 1.3.3.2.3 | Wind SWEA LVPS FM 1 Magnets | 5d | 2003-11-26 A | 2003-12-03 A |  | 100% |  |  |  | start no earlier than 2003-11-26 |
| 95 | 1.3.3.2.4 | Wind PLASTIC LVPS FM 1 Magnets | 45d | 2003-09-29 A | 2003-12-03 A |  | 100% |  |  |  | start no earlier than 2003-09-29 |
| 96 | 1.3.3.3 | **FM 2** | 15d | 2003-12-29 A | 2004-01-20 |  | 30% | 10.5d | 71d |  |  |
| 97 | 1.3.3.3.1 | Wind HVPS FM 2 Magnets | 15d | 2003-12-29 A | 2004-01-20 |  | 30% | 10.5d | 44d | 0d | start no earlier than 2003-12-29 |
| 98 | 1.3.3.3.2 | Wind IDPU LVPS FM 2 Magnets | 15d | 2003-12-29 A | 2004-01-20 | 97SS | 30% | 10.5d | 64d | 27d |  |
| 99 | 1.3.3.3.3 | Wind SEP LVPS FM 2 Magnets | 15d | 2003-12-29 A | 2004-01-20 | 97SS | 30% | 10.5d | 44d | 17d |  |
| 100 | 1.3.3.3.4 | Wind SWEA LVPS FM 2 Magnets | 15d | 2003-12-29 A | 2004-01-20 | 97SS | 30% | 10.5d | 71d | 23d |  |
| 101 | 1.3.3.3.5 | Wind PLASTIC LVPS FM 2 Magnets | 15d | 2003-12-29 A | 2004-01-20 | 97SS | 30% | 10.5d | 54d | 13d |  |
| 102 | 1.3.4 | **Assembly** | 57d | 2003-12-29 A | 2004-03-19 |  | 2% | 55.67d | 44d |  |  |
| 103 | 1.3.4.1 | **FM 1** | 44d | 2003-12-29 A | 2004-03-02 |  | 5% | 41.64d | 33d |  |  |
| 104 | 1.3.4.1.1 | Assemble IDPU FM 1 LVPS | 12d | 2004-02-13 | 2004-03-02 | 92, 116 |  |  | 33d | 0d |  |
| 105 | 1.3.4.1.2 | Assemble SEP FM 1 LVPS | 15d | 2004-01-12 | 2004-02-02 | 117, 93 |  |  | 50d | 0d | start no earlier than 2004-01-12 |
| 106 | 1.3.4.1.3 | Assemble SWEA FM 1 LVPS | 14d | 2004-01-20 | 2004-02-06 | 94, 118 |  |  | 27d | 0d | start no earlier than 2004-01-12 |
| 107 | 1.3.4.1.4 | Assemble PLASTIC FM 1 LVPS | 15d | 2003-12-29 A | 2004-01-20 | 119, 95 | 20% | 12d | 42d | 0d | start no earlier than 2003-12-29 |

| ID | WBS | Task | Duration | Start | Finish | Predecessors | Complete | Remaining | Total slack | Free slack | Constraint |
| --- | --- | --- | --- | --- | --- | --- | --- | --- | --- | --- | --- |
| 108 | 1.3.4.2 | **FM 2** | 42d | 2004-01-21 | 2004-03-19 |  |  |  | 44d |  |  |
| 109 | 1.3.4.2.1 | Assemble IDPU FM 2 LVPS | 15d | 2004-03-01 | 2004-03-19 | 98 |  |  | 37d | 0d | start no earlier than 2004-03-01 |
| 110 | 1.3.4.2.2 | Assemble SEP FM 2 LVPS | 15d | 2004-02-13 | 2004-03-05 | 99 |  |  | 27d | 0d | start no earlier than 2004-02-13 |
| 111 | 1.3.4.2.3 | Assemble SWEA FM 2 LVPS | 15d | 2004-02-24 | 2004-03-15 | 100 |  |  | 48d | 0d | start no earlier than 2004-02-24 |
| 112 | 1.3.4.2.4 | Assemble PLASTIC FM 2 LVPS | 14d | 2004-02-09 | 2004-02-27 | 101 |  |  | 41d | 0d | start no earlier than 2004-02-09 |
| 113 | 1.3.4.2.5 | Assemble SIT FM 2 HVPS | 14d | 2004-01-21 | 2004-02-09 | 97 |  |  | 44d | 0d |  |
| 114 | 1.3.5 | **Testing** | 157d | 2003-10-31 A | 2004-06-16 |  | 12% | 137.49d | 343d |  |  |
| 115 | 1.3.5.1 | **FM 1 & FM 2** | 55d | 2003-11-24 A | 2004-02-12 |  | 80% | 11d | 33d |  |  |
| 116 | 1.3.5.1.1 | Coupon Test IDPU Flight Printed Wiring Board | 4d | 2004-02-09 | 2004-02-12 | 82 |  |  | 33d | 0d |  |
| 117 | 1.3.5.1.2 | Coupon Test SEP Flight Printed Wiring Board | 5d | 2003-12-09 A | 2003-12-15 A | 83 | 100% |  |  |  |  |
| 118 | 1.3.5.1.3 | Coupon Test SWEA Flight Printed Wiring Board | 6d | 2004-01-09 A | 2004-01-16 A | 84 | 100% |  |  |  | start no earlier than 2004-01-09 |
| 119 | 1.3.5.1.4 | Coupon Test PLASTIC Flight Printed Wiring Board | 5d | 2003-11-24 A | 2003-12-01 A | 85 | 100% |  |  |  | start no earlier than 2003-11-24 |
| 120 | 1.3.5.2 | **FM 1** | 157d | 2003-10-31 A | 2004-06-16 |  | 16% | 132.47d | 343d |  |  |
| 121 | 1.3.5.2.1 | **IDPU** | 30d | 2004-03-03 | 2004-04-13 |  |  |  | 33d |  |  |
| 122 | 1.3.5.2.1.1 | Test IDPU FM 1 LVPS | 15d | 2004-03-03 | 2004-03-23 | 104 |  |  | 33d | 0d |  |
| 123 | 1.3.5.2.1.2 | Coat & Stake IDPU LVPS FM 1 Boards | 5d | 2004-03-24 | 2004-03-30 | 122 |  |  | 33d | 0d |  |
| 124 | 1.3.5.2.1.3 | Retest IDPU LVPS FM 1 Boards | 10d | 2004-03-31 | 2004-04-13 | 123 |  |  | 33d | 0d |  |
| 125 | 1.3.5.2.2 | **SEP** | 30d | 2004-02-03 | 2004-03-16 |  |  |  | 50d |  |  |
| 126 | 1.3.5.2.2.1 | Test SEP FM 1 LVPS | 15d | 2004-02-03 | 2004-02-24 | 105 |  |  | 50d | 0d |  |
| 127 | 1.3.5.2.2.2 | Coat & Stake SEP LVPS FM 1 Boards | 5d | 2004-02-25 | 2004-03-02 | 126 |  |  | 50d | 0d |  |
| 128 | 1.3.5.2.2.3 | Retest SEP LVPS FM 1 Boards | 10d | 2004-03-03 | 2004-03-16 | 127, 379 |  |  | 50d | 0d |  |
| 129 | 1.3.5.2.3 | **SWEA** | 30d | 2004-02-09 | 2004-03-22 |  |  |  | 27d |  |  |
| 130 | 1.3.5.2.3.1 | Test SWEA FM 1 LVPS | 15d | 2004-02-09 | 2004-03-01 | 106 |  |  | 27d | 0d |  |
| 131 | 1.3.5.2.3.2 | Coat & Stake SWEA LVPS FM 1 Boards | 5d | 2004-03-02 | 2004-03-08 | 130 |  |  | 27d | 0d |  |
| 132 | 1.3.5.2.3.3 | Retest SWEA LVPS FM 1 Boards | 10d | 2004-03-09 | 2004-03-22 | 131 |  |  | 27d | 0d |  |

| ID | WBS | Task | Duration | Start | Finish | Predecessors | Complete | Remaining | Total slack | Free slack | Constraint |
| --- | --- | --- | --- | --- | --- | --- | --- | --- | --- | --- | --- |
| 133 | 1.3.5.2.4 | **PLASTIC** | 30d | 2004-01-21 | 2004-03-03 |  |  |  | 42d |  |  |
| 134 | 1.3.5.2.4.1 | Test PLASTIC FM 1 LVPS | 15d | 2004-01-21 | 2004-02-10 | 107 |  |  | 42d | 0d |  |
| 135 | 1.3.5.2.4.2 | Coat & Stake PLASTIC LVPS FM 1 Boards | 5d | 2004-02-11 | 2004-02-18 | 134 |  |  | 42d | 0d |  |
| 136 | 1.3.5.2.4.3 | Retest PLASTIC LVPS FM 1 Boards | 10d | 2004-02-19 | 2004-03-03 | 135 |  |  | 42d | 0d |  |
| 137 | 1.3.5.2.5 | **SIT** | 157d | 2003-10-31 A | 2004-06-16 |  | 63% | 58.88d | 343d |  |  |
| 138 | 1.3.5.2.5.1 | Test SIT FM 1 HVPS | 25d | 2003-10-31 A | 2003-12-08 A |  | 100% |  |  |  | start no earlier than 2003-10-31 |
| 139 | 1.3.5.2.5.2 | Coat & Stake SIT FM 1 HVPS Boards (at UMD) | 5d | 2004-05-26 | 2004-06-02 | 690SS |  |  | 343d | 0d |  |
| 140 | 1.3.5.2.5.3 | Retest SIT FM 1 HVPS Boards (at UMD) | 10d | 2004-06-03 | 2004-06-16 | 139 |  |  | 343d |  |  |
| 141 | 1.3.5.3 | **FM 2** | 58d | 2004-02-10 | 2004-04-30 |  |  |  | 44d |  |  |
| 142 | 1.3.5.3.1 | **IDPU** | 30d | 2004-03-22 | 2004-04-30 |  |  |  | 37d |  |  |
| 143 | 1.3.5.3.1.1 | Test IDPU FM 2 LVPS | 15d | 2004-03-22 | 2004-04-09 | 109 |  |  | 37d | 0d |  |
| 144 | 1.3.5.3.1.2 | Coat & Stake IDPU LVPS FM 2 Boards | 5d | 2004-04-12 | 2004-04-16 | 143 |  |  | 37d | 0d |  |
| 145 | 1.3.5.3.1.3 | Retest IDPU LVPS FM 2 Boards | 10d | 2004-04-19 | 2004-04-30 | 144 |  |  | 37d | 0d |  |
| 146 | 1.3.5.3.2 | **SEP** | 30d | 2004-03-08 | 2004-04-16 |  |  |  | 27d |  |  |
| 147 | 1.3.5.3.2.1 | Test SEP FM 2 LVPS | 15d | 2004-03-08 | 2004-03-26 | 110 |  |  | 27d | 0d |  |
| 148 | 1.3.5.3.2.2 | Coat & Stake SEP LVPS FM 2 Boards | 5d | 2004-03-29 | 2004-04-02 | 147 |  |  | 27d | 0d |  |
| 149 | 1.3.5.3.2.3 | Retest SEP LVPS FM 2 Boards | 10d | 2004-04-05 | 2004-04-16 | 148, 379 |  |  | 27d | 0d |  |
| 150 | 1.3.5.3.3 | **SWEA** | 30d | 2004-03-16 | 2004-04-26 |  |  |  | 48d |  |  |
| 151 | 1.3.5.3.3.1 | Test SWEA FM 2 LVPS | 15d | 2004-03-16 | 2004-04-05 | 111 |  |  | 48d | 0d |  |
| 152 | 1.3.5.3.3.2 | Coat & Stake SWEA LVPS FM 2 Boards | 5d | 2004-04-06 | 2004-04-12 | 151 |  |  | 48d | 0d |  |
| 153 | 1.3.5.3.3.3 | Retest SWEA LVPS FM 2 Boards | 10d | 2004-04-13 | 2004-04-26 | 152 |  |  | 48d | 0d |  |
| 154 | 1.3.5.3.4 | **PLASTIC** | 30d | 2004-03-01 | 2004-04-09 |  |  |  | 41d |  |  |
| 155 | 1.3.5.3.4.1 | Test PLASTIC FM 2 LVPS | 15d | 2004-03-01 | 2004-03-19 | 112 |  |  | 41d | 0d |  |
| 156 | 1.3.5.3.4.2 | Coat & Stake PLASTIC LVPS FM 2 Boards | 5d | 2004-03-22 | 2004-03-26 | 155 |  |  | 41d | 0d |  |
| 157 | 1.3.5.3.4.3 | Retest PLASTIC LVPS FM 2 Boards | 10d | 2004-03-29 | 2004-04-09 | 156 |  |  | 41d | 0d |  |

| ID | WBS | Task | Type | Duration | Start | Finish | Predecessors | Complete | Remaining | Total slack | Free slack | Constraint |
| --- | --- | --- | --- | --- | --- | --- | --- | --- | --- | --- | --- | --- |
| 158 | 1.3.5.3.5 | **SIT** |  | 30d | 2004-02-10 | 2004-03-23 |  |  |  | 44d |  |  |
| 159 | 1.3.5.3.5.1 | Test SIT FM 2 HVPS |  | 15d | 2004-02-10 | 2004-03-02 | 113 |  |  | 44d | 0d |  |
| 160 | 1.3.5.3.5.2 | Coat & Stake SIT FM 2 HVPS Boards |  | 5d | 2004-03-03 | 2004-03-09 | 159 |  |  | 44d | 0d |  |
| 161 | 1.3.5.3.5.3 | Retest SIT FM 2 HVPS Boards |  | 10d | 2004-03-10 | 2004-03-23 | 160 |  |  | 44d | 0d |  |
| 162 | 1.4 | **IDPU - UCB** |  | 340d | 2003-05-05 A | 2004-09-07 |  | 59% | 141.03d | 285d |  |  |
| 163 | 1.4.1 | **Deliveries** |  | 78d | 2004-02-09 | 2004-05-28 |  |  |  | 98d |  |  |
| 164 | 1.4.1.1 | IDPU FM 1 Complete (to UCB for Boom I&T, then to CIT for SEP I&T, Suite EMC, BO & Final Boom I&T) | milestone | 0d | 2004-05-11 | 2004-05-11 | 180 |  |  | 33d | 6d |  |
| 165 | 1.4.1.2 | IDPU FM 2 Complete (to CIT for SEP I&T, then to UCB for Boom I&T, Boom EMC, BO & Final Boom I&T) | milestone | 0d | 2004-05-28 | 2004-05-28 | 185 |  |  | 37d | 18d |  |
| 166 | 1.4.1.3 | Deliver IDPU S/W Build 3 (to UNH) | milestone | 0d | 2004-02-09 | 2004-02-09 | 169 |  |  | 433d |  |  |
| 167 | 1.4.2 | **Flight Software** |  | 192d | 2003-05-05 A | 2004-02-09 |  | 81% | 36.72d | 105d |  |  |
| 168 | 1.4.2.1 | IDPU S/W Build #2.5 |  | 131d | 2003-05-05 A | 2003-11-07 A |  | 100% |  |  |  | start no earlier than 2003-05-05 |
| 169 | 1.4.2.2 | IDPU S/W Build #3 |  | 120d | 2003-08-15 A | 2004-02-09 |  | 60% | 48d | 105d | 0d | start no earlier than 2003-08-15 |
| 170 | 1.4.3 | **GSE** |  | 301d | 2003-06-30 A | 2004-09-07 |  | 50% | 149.32d | 285d |  |  |
| 171 | 1.4.3.1 | STE Science Display |  | 27d | 2003-10-23 A | 2003-12-02 A |  | 100% |  |  |  | start no earlier than 2003-10-23 |
| 172 | 1.4.3.2 | SWEA Science Display |  | 140d | 2003-06-30 A | 2004-01-21 |  | 62% | 53.2d | 446d |  | start no earlier than 2003-06-30 |
| 173 | 1.4.3.3 | GSE Continued Development |  | 291d | 2003-07-15 A | 2004-09-07 |  | 40% | 174d | 285d |  | start no earlier than 2003-07-15 |
| 174 | 1.4.4 | **Integration & Test** |  | 224d | 2003-10-07 A | 2004-08-25 |  | 33% | 149.33d | 33d |  |  |
| 175 | 1.4.4.1 | IDPU DCB FM 2 Board Level Testing |  | 15d | 2003-10-07 A | 2003-10-28 A |  | 100% |  |  |  | start no earlier than 2003-10-07 |
| 176 | 1.4.4.2 | IDPU DCB Clean/Stake/Coat (FM 1 & FM 2) |  | 10d | 2003-12-26 A | 2004-01-09 A | 175 | 100% |  |  |  | start no earlier than 2003-12-26 |
| 177 | 1.4.4.3 | **FM 1** |  | 63d | 2004-04-14 | 2004-07-12 |  |  |  | 33d |  |  |
| 178 | 1.4.4.3.1 | IDPU FM 1 I & T |  | 5d | 2004-04-14 | 2004-04-20 | 168, 70, 245, 289, 176 |  |  | 33d | 0d |  |
| 179 | 1.4.4.3.2 | IDPU FM 1 Vibration |  | 5d | 2004-04-21 | 2004-04-27 | 178 |  |  | 33d | 0d |  |
| 180 | 1.4.4.3.3 | IDPU FM 1 Thermal Vacuum |  | 10d | 2004-04-28 | 2004-05-11 | 179 |  |  | 33d | 0d |  |
| 181 | 1.4.4.3.4 | IDPU FM 1 Bakeout |  | 5d | 2004-07-06 | 2004-07-12 | 18, 180 |  |  | 51d | 0d |  |

| ID | WBS | Task | Type | Duration | Start | Finish | Predecessors | Complete | Remaining | Total slack | Free slack | Constraint |
| --- | --- | --- | --- | --- | --- | --- | --- | --- | --- | --- | --- | --- |
| 182 | 1.4.4.4 | **FM 2** |  | 82d | 2004-05-03 | 2004-08-25 |  |  |  | 33d |  |  |
| 183 | 1.4.4.4.1 | IDPU FM 2 I & T |  | 5d | 2004-05-03 | 2004-05-07 | 76, 246, 290, 175, 176 |  |  | 37d | 0d |  |
| 184 | 1.4.4.4.2 | IDPU FM 2 Vibration |  | 5d | 2004-05-10 | 2004-05-14 | 183 |  |  | 37d | 0d |  |
| 185 | 1.4.4.4.3 | IDPU FM 2 Thermal Vacuum |  | 10d | 2004-05-17 | 2004-05-28 | 169, 184 |  |  | 37d | 0d |  |
| 186 | 1.4.4.4.4 | IDPU FM 2 Bakeout |  | 5d | 2004-08-19 | 2004-08-25 | 185, 366SS |  |  | 33d | 0d |  |
| 187 | 1.5 | **BOOM Suite - UCB** |  | 302d | 2003-07-01 A | 2004-09-09 |  | 56% | 131.91d | 283d |  |  |
| 188 | 1.5.1 | **BOOM Structure - UCB** |  | 187d | 2003-09-10 A | 2004-06-08 |  | 59% | 77.56d | 73d |  |  |
| 189 | 1.5.1.1 | **Deliveries** |  | 104d | 2004-01-09 A | 2004-06-08 |  |  | 104d | 73d |  |  |
| 190 | 1.5.1.1.1 | Protoflight Boom available for I&T (if needed) | milestone | 0d | 2004-01-09 A | 2004-01-09 A | 195 | 100% |  |  |  |  |
| 191 | 1.5.1.1.2 | Deliver Boom Structure FM 1 (stays at UCB for Boom Suite FM 1 I&T) | milestone | 0d | 2004-05-17 | 2004-05-17 | 220 |  |  | 27d | 0d |  |
| 192 | 1.5.1.1.3 | Deliver Boom Structure FM 2 (stays at UCB for Boom Suite FM 2 I&T) | milestone | 0d | 2004-06-08 | 2004-06-08 | 242 |  |  | 73d | 40d |  |
| 193 | 1.5.1.2 | **Protoflight** |  | 79d | 2003-09-16 A | 2004-01-09 A |  | 100% |  |  |  |  |
| 194 | 1.5.1.2.1 | Protoflight Boom Post Environmental Deployment Test |  | 35d | 2003-09-16 A | 2003-11-04 A |  | 100% |  |  |  | start no earlier than 2003-09-16 |
| 195 | 1.5.1.2.2 | Document Protoflight Boom Test Results |  | 44d | 2003-11-05 A | 2004-01-09 A | 194 | 100% |  |  |  |  |
| 196 | 1.5.1.3 | **Flight Procurements** |  | 40d | 2003-09-10 A | 2003-11-05 A |  | 100% |  |  |  |  |
| 197 | 1.5.1.3.1 | Receive and Inspect Flight Boom Structure Tubes (FM 1) |  | 32d | 2003-09-10 A | 2003-10-24 A |  | 100% |  |  |  | start no earlier than 2003-09-10 |
| 198 | 1.5.1.3.2 | Receive and Inspect Flight Boom Structure Tubes (FM 2) |  | 40d | 2003-09-10 A | 2003-11-05 A |  | 100% |  |  |  | start no earlier than 2003-09-10 |
| 199 | 1.5.1.4 | **FM 1** |  | 159d | 2003-09-29 A | 2004-05-17 |  | 46% | 85.41d | 27d |  |  |
| 200 | 1.5.1.4.1 | **Telescoping** |  | 81d | 2003-10-27 A | 2004-02-24 |  | 59% | 33.29d | 29d |  |  |
| 201 | 1.5.1.4.1.1 | **Fabrication, Assembly & Test** |  | 81d | 2003-10-27 A | 2004-02-24 |  | 59% | 33.29d | 29d |  |  |
| 202 | 1.5.1.4.1.1.1 | Machine FM 1 Boom Structure Tubes as necessary |  | 5d | 2003-10-27 A | 2003-10-31 A | 197 | 100% |  |  |  |  |
| 203 | 1.5.1.4.1.1.2 | Machine FM 1 Boom Structure Parts (Rings) |  | 38d | 2003-11-07 A | 2004-01-05 A | 197FF+47d | 100% |  |  |  |  |
| 204 | 1.5.1.4.1.1.3 | Assemble FM 1 Boom Structure Telescoping Assembly |  | 20d | 2004-01-12 | 2004-02-09 | 202, 203 |  |  | 29d | 0d | start no earlier than 2004-01-12 |
| 205 | 1.5.1.4.1.1.4 | Test FM 1 Boom Structure Telescoping Assembly |  | 10d | 2004-02-10 | 2004-02-24 | 204 |  |  | 29d | 2d |  |

| ID | WBS | Task | Duration | Start | Finish | Predecessors | Complete | Remaining | Total slack | Free slack | Constraint |
| --- | --- | --- | --- | --- | --- | --- | --- | --- | --- | --- | --- |
| 206 | 1.5.1.4.2 | **Harness** | 102d | 2003-09-29 A | 2004-02-26 |  | 41% | 59.88d | 27d |  |  |
| 207 | 1.5.1.4.2.1 | **Fabrication** | 72d | 2003-09-29 A | 2004-01-13 |  | 59% | 29.88d | 27d |  |  |
| 208 | 1.5.1.4.2.1.1 | Machine FM 1 Harness Parts | 72d | 2003-09-29 A | 2004-01-13 |  | 59% | 29.88d | 27d | 0d | start no earlier than 2003-09-29 |
| 209 | 1.5.1.4.2.2 | **Assembly & Test** | 30d | 2004-01-14 | 2004-02-26 |  |  |  | 27d |  |  |
| 210 | 1.5.1.4.2.2.1 | Assemble FM 1 Harness subassembly | 20d | 2004-01-14 | 2004-02-11 | 208 |  |  | 27d | 0d |  |
| 211 | 1.5.1.4.2.2.2 | FM1 Harness Test | 10d | 2004-02-12 | 2004-02-26 | 210 |  |  | 27d | 0d |  |
| 212 | 1.5.1.4.3 | **Mounting** | 38d | 2003-09-29 A | 2003-11-21 A |  | 100% |  |  |  |  |
| 213 | 1.5.1.4.3.1 | FM 1Boom Structure Mounting Fabrication | 28d | 2003-09-29 A | 2003-11-06 A |  | 100% |  |  |  | start no earlier than 2003-09-29 |
| 214 | 1.5.1.4.3.2 | FM 1Boom Structure Mounting Assembly | 10d | 2003-11-07 A | 2003-11-21 A | 213 | 100% |  |  |  |  |
| 215 | 1.5.1.4.4 | **Integration & Test** | 57d | 2004-02-27 | 2004-05-17 |  |  |  | 27d |  |  |
| 216 | 1.5.1.4.4.1 | Integrate FM 1 Boom Structure subassemblies | 20d | 2004-02-27 | 2004-03-25 | 205, 211 |  |  | 27d | 0d |  |
| 217 | 1.5.1.4.4.2 | FM 1 Boom Structure Deployment Test | 10d | 2004-03-26 | 2004-04-08 | 216 |  |  | 27d | 0d |  |
| 218 | 1.5.1.4.4.3 | FM 1 Boom Structure Vibration Testing Completed | 4d | 2004-04-15 | 2004-04-20 | 217, 356 |  |  | 27d | 0d |  |
| 219 | 1.5.1.4.4.4 | FM 1 Boom Structure Themal Vac Testing Completed | 15d | 2004-04-21 | 2004-05-11 | 218 |  |  | 27d | 0d |  |
| 220 | 1.5.1.4.4.5 | FM 1 Boom Structure Post Environmental Deployment Test Completed | 4d | 2004-05-12 | 2004-05-17 | 219 |  |  | 27d | 0d |  |
| 221 | 1.5.1.5 | **FM 2** | 174d | 2003-09-29 A | 2004-06-08 |  | 47% | 91.4d | 73d |  |  |
| 222 | 1.5.1.5.1 | **Telescoping** | 73d | 2003-11-06 A | 2004-02-24 |  | 62% | 27.72d | 90d |  |  |
| 223 | 1.5.1.5.1.1 | **Fabrication, Assembly & Test** | 73d | 2003-11-06 A | 2004-02-24 |  | 62% | 27.72d | 90d |  |  |
| 224 | 1.5.1.5.1.1.1 | Machine FM 2 Boom Structure Tubes as necessary | 11d | 2003-11-06 A | 2003-11-21 A | 198 | 100% |  |  |  |  |
| 225 | 1.5.1.5.1.1.2 | Machine FM 2 Boom Structure Parts (Rings) | 38d | 2003-11-07 A | 2004-01-05 A | 203SS | 100% |  |  |  |  |
| 226 | 1.5.1.5.1.1.3 | Assemble FM 2 Boom Structure Telescoping Assembly | 20d | 2004-01-12 | 2004-02-09 | 224, 225 |  |  | 90d | 0d | start no earlier than 2004-01-12 |
| 227 | 1.5.1.5.1.1.4 | Test FM 2 Boom Structure Telescoping Assembly | 10d | 2004-02-10 | 2004-02-24 | 226 |  |  | 90d | 2d |  |
| 228 | 1.5.1.5.2 | **Harness** | 102d | 2003-09-29 A | 2004-02-26 |  | 41% | 59.88d | 88d |  |  |
| 229 | 1.5.1.5.2.1 | **Fabrication** | 72d | 2003-09-29 A | 2004-01-13 |  | 59% | 29.88d | 88d |  |  |
| 230 | 1.5.1.5.2.1.1 | Machine FM 2 Harness Parts | 72d | 2003-09-29 A | 2004-01-13 | 208SS | 59% | 29.88d | 88d | 0d |  |

| ID | WBS | Task | Duration | Start | Finish | Predecessors | Complete | Remaining | Total slack | Free slack | Constraint |
| --- | --- | --- | --- | --- | --- | --- | --- | --- | --- | --- | --- |
| 231 | 1.5.1.5.2.2 | **Assembly & Test** | 30d | 2004-01-14 | 2004-02-26 |  |  |  | 88d |  |  |
| 232 | 1.5.1.5.2.2.1 | Assemble FM 2 Harness subassembly | 20d | 2004-01-14 | 2004-02-11 | 230 |  |  | 88d | 0d |  |
| 233 | 1.5.1.5.2.2.2 | FM 2 Harness Test | 10d | 2004-02-12 | 2004-02-26 | 232 |  |  | 88d | 0d |  |
| 234 | 1.5.1.5.3 | **Mounting** | 38d | 2003-09-29 A | 2003-11-21 A |  | 100% |  |  |  |  |
| 235 | 1.5.1.5.3.1 | FM 2 Boom Structure Mountings Fabrication | 28d | 2003-09-29 A | 2003-11-06 A | 213SS | 100% |  |  |  |  |
| 236 | 1.5.1.5.3.2 | FM 2 Boom Structure Mountings Assembly | 10d | 2003-11-07 A | 2003-11-21 A | 235 | 100% |  |  |  |  |
| 237 | 1.5.1.5.4 | **Integration & Test** | 72d | 2004-02-27 | 2004-06-08 |  |  |  | 73d |  |  |
| 238 | 1.5.1.5.4.1 | Integrate FM 2 Boom Structure subassemblies | 20d | 2004-02-27 | 2004-03-25 | 227, 233 |  |  | 88d | 0d |  |
| 239 | 1.5.1.5.4.2 | FM 2 Boom Structure Deployment Test | 10d | 2004-03-26 | 2004-04-08 | 238 |  |  | 88d | 1d |  |
| 240 | 1.5.1.5.4.3 | FM 2 Boom Structure Vibration Test | 4d | 2004-04-16 | 2004-04-21 | 239, 362 |  |  | 87d | 0d |  |
| 241 | 1.5.1.5.4.4 | FM 2 Boom Structure Themal Vac Testing | 15d | 2004-05-12 | 2004-06-02 | 240, 219 |  |  | 73d | 0d |  |
| 242 | 1.5.1.5.4.5 | FM 2 Boom Structure Post Environmental Deployment Test | 4d | 2004-06-03 | 2004-06-08 | 241 |  |  | 73d | 0d |  |
| 243 | 1.5.2 | **MAG - GSFC** | 47d | 2004-01-09 | 2004-03-17 |  |  |  | 63d |  |  |
| 244 | 1.5.2.1 | **Deliveries** | 22d | 2004-02-17 | 2004-03-17 |  |  |  | 63d |  |  |
| 245 | 1.5.2.1.1 | Deliver MAG FM 1 (to UCB for IDPU/BOOM Suite FM 1 I&T) | 2d | 2004-02-17 | 2004-02-18 | 249 |  |  | 63d | 36d |  |
| 246 | 1.5.2.1.2 | Deliver MAG FM 2 (to UCB for IDPU/BOOM Suite FM 2 I&T) | 2d | 2004-03-16 | 2004-03-17 | 252 |  |  | 69d | 17d |  |
| 247 | 1.5.2.2 | **FM 1** | 25d | 2004-01-09 | 2004-02-13 |  |  |  | 63d |  |  |
| 248 | 1.5.2.2.1 | FM 1 MAG Testing | 10d | 2004-01-09 | 2004-01-23 |  |  |  | 63d | 0d | start no earlier than 2004-01-09 |
| 249 | 1.5.2.2.2 | MAG FM 1 Calibration | 15d | 2004-01-26 | 2004-02-13 | 248 |  |  | 63d | 0d |  |
| 250 | 1.5.2.3 | **FM 2** | 25d | 2004-02-09 | 2004-03-15 |  |  |  | 69d |  |  |
| 251 | 1.5.2.3.1 | FM 2 MAG Testing | 10d | 2004-02-09 | 2004-02-23 |  |  |  | 69d | 0d | start no earlier than 2004-02-09 |
| 252 | 1.5.2.3.2 | MAG FM 2 Calibration | 15d | 2004-02-24 | 2004-03-15 | 251 |  |  | 69d | 0d |  |
| 253 | 1.5.3 | **SWEA - CESR** | 79d | 2003-12-08 A | 2004-03-31 |  | 6% | 74.53d | 76d |  |  |
| 254 | 1.5.3.1 | **Deliveries** | 79d | 2003-12-08 A | 2004-03-31 |  | 50% | 39.5d | 76d |  |  |
| 255 | 1.5.3.1.1 | SWEA FM 1 Delivery to UCB | 3d | 2003-12-08 A | 2003-12-10 A |  | 100% |  |  |  | start no earlier than 2003-12-08 |
| 256 | 1.5.3.1.2 | SWEA FM 2 Delivery to UCB | 3d | 2004-03-29 | 2004-03-31 | 259 |  |  | 76d | 43d |  |

| ID | WBS | Task | Type | Duration | Start | Finish | Predecessors | Complete | Remaining | Total slack | Free slack | Constraint |
| --- | --- | --- | --- | --- | --- | --- | --- | --- | --- | --- | --- | --- |
| 257 | 1.5.3.2 | **FM 2** |  | 47d | 2004-01-21 | 2004-03-26 |  |  |  | 76d |  |  |
| 258 | 1.5.3.2.1 | SWEA FM 2 Final Assembly (Block 2) |  | 3d | 2004-01-21 | 2004-01-23 |  |  |  | 76d | 0d | start no earlier than 2004-01-21 |
| 259 | 1.5.3.2.2 | SWEA FM 2 Calibration |  | 44d | 2004-01-26 | 2004-03-26 | 258 |  |  | 76d | 0d |  |
| 260 | 1.5.4 | **STE - UCB** |  | 153d | 2003-08-29 A | 2004-04-09 |  | 55% | 69.36d | 87d |  |  |
| 261 | 1.5.4.1 | **Deliveries** |  | 8d | 2004-03-30 | 2004-04-09 |  |  |  | 31d |  |  |
| 262 | 1.5.4.1.1 | Deliver STE-D FM 1 (stays at UCB for SWEA/STE-D FM 1 I&T) | milestone | 0d | 2004-03-30 | 2004-03-30 | 277 |  |  | 31d | 4d |  |
| 263 | 1.5.4.1.2 | Deliver STE-D FM 2 (stays at UCB for SWEA/STE-D FM 2 I&T) | milestone | 0d | 2004-04-09 | 2004-04-09 | 285 |  |  | 69d | 36d |  |
| 264 | 1.5.4.1.3 | Deliver STE-U FM 1 (stays at UCB for BOOM Suite FM 1 I&T) | milestone | 0d | 2004-04-05 | 2004-04-05 | 278 |  |  | 30d | 3d |  |
| 265 | 1.5.4.1.4 | Deliver STE-U FM 2 (stays at UCB for BOOM Suite FM 2 I&T) | milestone | 0d | 2004-04-09 | 2004-04-09 | 286 |  |  | 87d | 0d |  |
| 266 | 1.5.4.2 | **STE-U/D Housing** |  | 38d | 2003-11-21 A | 2004-01-16 |  | 71% | 11d | 99d |  |  |
| 267 | 1.5.4.2.1 | Fabricate STE FM 1 Box |  | 38d | 2003-11-21 A | 2004-01-16 |  | 71% | 11d | 40d | 10d | start no earlier than 2003-11-21 |
| 268 | 1.5.4.2.2 | Fabricate STE FM 2 Box |  | 38d | 2003-11-21 A | 2004-01-16 |  | 71% | 11d | 99d | 30d | start no earlier than 2003-11-21 |
| 269 | 1.5.4.3 | **STE-U/D Detector Boards** |  | 153d | 2003-08-29 A | 2004-04-09 |  | 51% | 75.73d | 87d |  |  |
| 270 | 1.5.4.3.1 | Coupon Test STE FM 1 & FM 2 Detector Printed Wiring Board |  | 17d | 2003-10-10 A | 2003-11-04 A | 272, 280 | 100% |  |  |  | start no earlier than 2003-10-10 |
| 271 | 1.5.4.3.2 | **FM 1** |  | 149d | 2003-08-29 A | 2004-04-05 |  | 47% | 78.7d | 30d |  |  |
| 272 | 1.5.4.3.2.1 | Fabrication STE FM 1 Detector Printed Wiring Board |  | 29d | 2003-08-29 A | 2003-10-09 A |  | 100% |  |  |  | start no earlier than 2003-08-29 |
| 273 | 1.5.4.3.2.2 | Load STE FM 1 Detector Printed Wiring Board |  | 49d | 2003-11-05 A | 2004-01-16 | 270 | 78% | 11d | 30d | 0d |  |
| 274 | 1.5.4.3.2.3 | Test STE FM 1 Detector Printed Wiring Board |  | 10d | 2004-01-20 | 2004-02-02 | 273 |  |  | 30d | 0d |  |
| 275 | 1.5.4.3.2.4 | **Integration & Test** |  | 44d | 2004-02-03 | 2004-04-05 |  |  |  | 30d |  |  |
| 276 | 1.5.4.3.2.4.1 | Integrate & Test STE-U/D FM 1 Detectors W/ FM 1 Housings |  | 20d | 2004-02-03 | 2004-03-02 | 267, 274 |  |  | 30d | 0d |  |
| 277 | 1.5.4.3.2.4.2 | Calibrate STE-U/D FM 1 |  | 20d | 2004-03-03 | 2004-03-30 | 276 |  |  | 30d | 0d |  |
| 278 | 1.5.4.3.2.4.3 | STE-U FM 1 Thermal Vacuum/Balance |  | 14d | 2004-03-17 | 2004-04-05 | 277FS-10d |  |  | 30d | 0d |  |
| 279 | 1.5.4.3.3 | **FM 2** |  | 153d | 2003-08-29 A | 2004-04-09 |  | 48% | 79.78d | 87d |  |  |
| 280 | 1.5.4.3.3.1 | Fabricate STE FM 2 Detector Printed Wiring Board |  | 29d | 2003-08-29 A | 2003-10-09 A |  | 100% |  |  |  | start no earlier than 2003-08-29 |
| 281 | 1.5.4.3.3.2 | Load STE FM 2 Detector Printed Wiring Board |  | 63d | 2003-11-05 A | 2004-02-06 | 270 | 60% | 25d | 75d | 0d |  |
| 282 | 1.5.4.3.3.3 | Test STE FM 2 Detector Printed Wiring Board |  | 10d | 2004-02-09 | 2004-02-23 | 281 |  |  | 75d | 6d |  |

| ID | WBS | Task | Type | Duration | Start | Finish | Predecessors | Complete | Remaining | Total slack | Free slack | Constraint |
| --- | --- | --- | --- | --- | --- | --- | --- | --- | --- | --- | --- | --- |
| 283 | 1.5.4.3.3.4 | **Integration & Test** |  | 28d | 2004-03-03 | 2004-04-09 |  |  |  | 69d |  |  |
| 284 | 1.5.4.3.3.4.1 | Integrate & Test STE-U/D FM 2 Detectors W/ FM 2 Housings |  | 10d | 2004-03-03 | 2004-03-16 | 268, 282, 276 |  |  | 69d | 0d |  |
| 285 | 1.5.4.3.3.4.2 | Calibrate STE-U/D FM 2 |  | 18d | 2004-03-17 | 2004-04-09 | 284 |  |  | 69d | 0d |  |
| 286 | 1.5.4.3.3.4.3 | STE-U FM 2 Thermal Vacuum |  | 10d | 2004-03-29 | 2004-04-09 | 285FS-10d |  |  | 87d | 0d |  |
| 287 | 1.5.5 | **STE and SWEA - UCB** |  | 276d | 2003-07-01 A | 2004-08-03 |  | 67% | 91.88d | 309d |  |  |
| 288 | 1.5.5.1 | **Deliveries** |  | 125d | 2004-02-06 | 2004-08-03 |  |  |  | 33d |  |  |
| 289 | 1.5.5.1.1 | Deliver STE-U FM 1 Interface (stays at UCB for IDPU FM 1 I&T) | milestone | 0d | 2004-02-06 | 2004-02-06 | 338 |  |  | 79d | 46d |  |
| 290 | 1.5.5.1.2 | Deliver STE-U FM 2 Interface (stays at UCB for IDPU FM 2 I&T) | milestone | 0d | 2004-02-20 | 2004-02-20 | 347 |  |  | 87d | 50d |  |
| 291 | 1.5.5.1.3 | Deliver SWEA/STE-D FM 1 (stays at UCB for Boom Suite FM 1 I&T) | milestone | 0d | 2004-05-17 | 2004-05-17 | 344 |  |  | 27d | 0d |  |
| 292 | 1.5.5.1.4 | Deliver SWEA/STE-D FM 2 (stays at UCB for Boom Suite FM 2 I&T) | milestone | 0d | 2004-08-03 | 2004-08-03 | 353 |  |  | 33d | 0d |  |
| 293 | 1.5.5.2 | **SWEA Pedestal** |  | 137d | 2003-07-01 A | 2004-01-16 |  | 92% | 11d | 97d |  |  |
| 294 | 1.5.5.2.1 | Fabricate SWEA FM 1 Baseplate |  | 137d | 2003-07-01 A | 2004-01-16 |  | 92% | 11d | 51d | 18d | start no earlier than 2003-07-01 |
| 295 | 1.5.5.2.2 | Fabricate SWEA FM 2 Baseplate |  | 137d | 2003-07-01 A | 2004-01-16 |  | 92% | 11d | 97d | 64d | start no earlier than 2003-07-01 |
| 296 | 1.5.5.3 | **STE-D Pre-Amp Board** |  | 98d | 2003-09-22 A | 2004-02-12 |  | 89% | 10.54d | 79d |  |  |
| 297 | 1.5.5.3.1 | **FM 1** |  | 98d | 2003-09-22 A | 2004-02-12 |  | 87% | 12.56d | 33d |  |  |
| 298 | 1.5.5.3.1.1 | Fabricate STE-D FM 1 Preamp Printed Wiring Board |  | 34d | 2003-09-22 A | 2003-11-07 A |  | 100% |  |  |  | start no earlier than 2003-09-22 |
| 299 | 1.5.5.3.1.2 | Load STE-D FM 1 Preamp Printed Wiring Board |  | 5d | 2004-02-06 | 2004-02-12 | 303 |  |  | 33d | 0d | start no earlier than 2004-02-06 |
| 300 | 1.5.5.3.2 | **FM 2** |  | 98d | 2003-09-22 A | 2004-02-12 |  | 87% | 12.56d | 79d |  |  |
| 301 | 1.5.5.3.2.1 | Fabricate STE-D FM 2 Preamp Printed Wiring Board |  | 34d | 2003-09-22 A | 2003-11-07 A |  | 100% |  |  |  | start no earlier than 2003-09-22 |
| 302 | 1.5.5.3.2.2 | Load STE-D FM 2 Preamp Printed Wiring Board |  | 5d | 2004-02-06 | 2004-02-12 | 299SS |  |  | 79d | 46d |  |
| 303 | 1.5.5.3.3 | Coupon Test STE-D FM 1 & FM 2 Pre-Amp Printed Wiring Boards |  | 15d | 2003-11-10 A | 2003-12-02 A | 298, 301 | 100% |  |  |  |  |
| 304 | 1.5.5.4 | **STE-D Shaper Board** |  | 94d | 2003-12-04 A | 2004-04-19 |  | 64% | 33.42d | 33d |  |  |
| 305 | 1.5.5.4.1 | **FM 1** |  | 44d | 2003-12-04 A | 2004-02-06 |  | 67% | 14.67d | 37d |  |  |
| 306 | 1.5.5.4.1.1 | Fabricate STE-D FM 1 Shaper Printed Wiring Board |  | 10d | 2003-12-04 A | 2003-12-17 A |  | 100% |  |  |  | start no earlier than 2003-12-04 |
| 307 | 1.5.5.4.1.2 | Load STE-D FM 1 Shaper Printed Wiring Board |  | 5d | 2004-02-02 | 2004-02-06 | 311 |  |  | 37d | 0d | start no earlier than 2004-02-02 |

| ID | WBS | Task | Duration | Start | Finish | Predecessors | Complete | Remaining | Total slack | Free slack | Constraint |
| --- | --- | --- | --- | --- | --- | --- | --- | --- | --- | --- | --- |
| 308 | 1.5.5.4.2 | **FM 2** | 94d | 2003-12-04 A | 2004-04-19 |  | 67% | 31.33d | 33d |  |  |
| 309 | 1.5.5.4.2.1 | Fabricate STE-D FM 2 Shaper Printed Wiring Board | 10d | 2003-12-04 A | 2003-12-17 A |  | 100% |  |  |  | start no earlier than 2003-12-04 |
| 310 | 1.5.5.4.2.2 | Load STE-D FM 2 Shaper Printed Wiring Board | 5d | 2004-04-13 | 2004-04-19 | 311, 342 |  |  | 33d | 0d |  |
| 311 | 1.5.5.4.3 | Coupon Test STE-D FM 1 & FM 2 Shaper Printed Wiring Boards | 15d | 2003-12-18 A | 2004-01-09 | 306, 309 | 60% | 6d | 51d | 14d |  |
| 312 | 1.5.5.5 | **STE-D Interface Board** | 94d | 2003-12-04 A | 2004-04-19 |  | 64% | 33.42d | 384d |  |  |
| 313 | 1.5.5.5.1 | **FM 1** | 44d | 2003-12-04 A | 2004-02-06 |  | 67% | 14.67d | 37d |  |  |
| 314 | 1.5.5.5.1.1 | Fabricate SWEA / STE-D FM 1 Digital to Analog Converter Printed Wiring Board | 10d | 2003-12-04 A | 2003-12-17 A |  | 100% |  |  |  | start no earlier than 2003-12-04 |
| 315 | 1.5.5.5.1.2 | Load SWEA / STE-D FM 1 Digital to Analog Converter Printed Wiring Board | 5d | 2004-02-02 | 2004-02-06 | 307SS |  |  | 37d | 4d |  |
| 316 | 1.5.5.5.2 | **FM 2** | 94d | 2003-12-04 A | 2004-04-19 |  | 67% | 31.33d | 33d |  |  |
| 317 | 1.5.5.5.2.1 | Fabricate SWEA / STE-D FM 2 Digital to Analog Converter Printed Wiring Board | 10d | 2003-12-04 A | 2003-12-17 A |  | 100% |  |  |  | start no earlier than 2003-12-04 |
| 318 | 1.5.5.5.2.2 | Load SWEA / STE-D FM 2 Digital to Analog Converter Printed Wiring Board | 5d | 2004-04-13 | 2004-04-19 | 310SS |  |  | 33d | 0d |  |
| 319 | 1.5.5.5.3 | Coupon Test STE-D FM 1 & FM 2 D/A Converter Printed Wiring Boards | 15d | 2003-12-18 A | 2004-01-09 | 314, 317 | 60% | 6d | 453d |  |  |
| 320 | 1.5.5.6 | **STE-U Pre-Amp Board** | 98d | 2003-09-22 A | 2004-02-12 |  | 95% | 5.33d | 87d |  |  |
| 321 | 1.5.5.6.1 | **FM 1** | 79d | 2003-09-22 A | 2004-01-15 A |  | 100% |  |  |  |  |
| 322 | 1.5.5.6.1.1 | Fabricate STE-U FM 1 Preamp Printed Wiring Board | 34d | 2003-09-22 A | 2003-11-07 A |  | 100% |  |  |  | start no earlier than 2003-09-22 |
| 323 | 1.5.5.6.1.2 | Load STE-U FM 1 Preamp Printed Wiring Board | 4d | 2004-01-12 A | 2004-01-15 A | 327 | 100% |  |  |  | start no earlier than 2004-01-12 |
| 324 | 1.5.5.6.2 | **FM 2** | 98d | 2003-09-22 A | 2004-02-12 |  | 87% | 12.56d | 87d |  |  |
| 325 | 1.5.5.6.2.1 | Fabricate STE-U FM 2 Preamp Printed Wiring Board | 34d | 2003-09-22 A | 2003-11-07 A |  | 100% |  |  |  | start no earlier than 2003-09-22 |
| 326 | 1.5.5.6.2.2 | Load STE-U FM 2 Preamp Printed Wiring Board | 5d | 2004-02-06 | 2004-02-12 | 327 |  |  | 87d | 0d | start no earlier than 2004-02-06 |
| 327 | 1.5.5.6.3 | Coupon Test STE-U FM 1 & FM 2 Pre-Amp Printed Wiring Boards | 15d | 2003-11-10 A | 2003-12-02 A | 322, 325 | 100% |  |  |  |  |
| 328 | 1.5.5.7 | **STE-U Shaper & Interface Board** | 39d | 2003-12-04 A | 2004-01-30 |  | 64% | 13.87d | 96d |  |  |
| 329 | 1.5.5.7.1 | **FM 1** | 39d | 2003-12-04 A | 2004-01-30 |  | 67% | 13d | 79d |  |  |
| 330 | 1.5.5.7.1.1 | Fabricate STE-U FM 1Shaper & Interface Printed Wiring Board | 10d | 2003-12-04 A | 2003-12-17 A |  | 100% |  |  |  | start no earlier than 2003-12-04 |
| 331 | 1.5.5.7.1.2 | Load STE-U FM 1 Shaper & Interface Printed Wiring Board | 5d | 2004-01-26 | 2004-01-30 | 335 |  |  | 79d | 0d | start no earlier than 2004-01-26 |

| ID | WBS | Task | Duration | Start | Finish | Predecessors | Complete | Remaining | Total slack | Free slack | Constraint |
| --- | --- | --- | --- | --- | --- | --- | --- | --- | --- | --- | --- |
| 332 | 1.5.5.7.2 | **FM 2** | 39d | 2003-12-04 A | 2004-01-30 |  | 67% | 13d | 96d |  |  |
| 333 | 1.5.5.7.2.1 | Fabricate STE-U FM 2 Shaper & Interface Printed Wiring Board | 10d | 2003-12-04 A | 2003-12-17 A |  | 100% |  |  |  | start no earlier than 2003-12-04 |
| 334 | 1.5.5.7.2.2 | Load STE-U FM 2 Shaper & Interface Printed Wiring Board | 5d | 2004-01-26 | 2004-01-30 | 331SS |  |  | 96d | 9d |  |
| 335 | 1.5.5.7.3 | Coupon Test STE-U FM 1 & FM 2 Shaper & Interface Printed Wiring Boards | 15d | 2003-12-18 A | 2004-01-09 | 330, 333 | 60% | 6d | 88d | 9d |  |
| 336 | 1.5.5.8 | **Integration & Test** | 130d | 2004-02-02 | 2004-08-03 |  |  |  | 33d |  |  |
| 337 | 1.5.5.8.1 | **FM 1** | 123d | 2004-02-02 | 2004-07-23 |  |  |  | 37d |  |  |
| 338 | 1.5.5.8.1.1 | Integrate & Test STE-U FM 1 Interface Boards | 5d | 2004-02-02 | 2004-02-06 | 323, 331 |  |  | 79d | 0d |  |
| 339 | 1.5.5.8.1.2 | Integrate & Test SWEA/STE-D FM 1 Interface Boards | 20d | 2004-02-13 | 2004-03-12 | 294, 299, 307, 315 |  |  | 33d | 0d |  |
| 340 | 1.5.5.8.1.3 | Integrate & Test SWEA/STE-D FM 1 Interface with SWEA/STE-D FM 1 LVPS | 10d | 2004-03-23 | 2004-04-05 | 339, 72 |  |  | 27d | 0d |  |
| 341 | 1.5.5.8.1.4 | Clean/Coat/Stake SWEA/STE-D Interface | 10d | 2004-03-15 | 2004-03-26 | 339 |  |  | 33d | 6d |  |
| 342 | 1.5.5.8.1.5 | Integrate & Test SWEA/STE-D FM 1 Combined | 5d | 2004-04-06 | 2004-04-12 | 340, 341, 255, 262 |  |  | 27d | 0d |  |
| 343 | 1.5.5.8.1.6 | Calibrate SWEA/STE FM 1 | 20d | 2004-04-13 | 2004-05-10 | 342 |  |  | 27d | 0d |  |
| 344 | 1.5.5.8.1.7 | SWEA/STE FM 1 Vibration | 5d | 2004-05-11 | 2004-05-17 | 343 |  |  | 27d | 0d |  |
| 345 | 1.5.5.8.1.8 | SWEA/STE-D FM 1 Thermal Vac/Thermal Balance | 14d | 2004-07-06 | 2004-07-23 | 18 |  |  | 37d | 0d |  |
| 346 | 1.5.5.8.2 | **FM 2** | 121d | 2004-02-13 | 2004-08-03 |  |  |  | 33d |  |  |
| 347 | 1.5.5.8.2.1 | Integrate & Test STE-U FM 2 Interface Boards | 5d | 2004-02-13 | 2004-02-20 | 326, 334 |  |  | 87d | 0d |  |
| 348 | 1.5.5.8.2.2 | Integrate & Test SWEA/STE-D FM 2 Interface Boards | 20d | 2004-04-20 | 2004-05-17 | 295, 302, 310, 318 |  |  | 33d | 0d |  |
| 349 | 1.5.5.8.2.3 | Integrate & Test SWEA/STE-D FM 2 Interface with SWEA/STE-D FM 2 LVPS | 10d | 2004-05-18 | 2004-06-01 | 348, 78 |  |  | 33d | 0d |  |
| 350 | 1.5.5.8.2.4 | Integrate & Test SWEA/STE-D FM 2 Combined | 10d | 2004-06-02 | 2004-06-15 | 349, 256, 263 |  |  | 33d | 0d |  |
| 351 | 1.5.5.8.2.5 | Calibrate SWEA/STE FM 2 | 20d | 2004-06-16 | 2004-07-13 | 350 |  |  | 33d | 0d |  |
| 352 | 1.5.5.8.2.6 | SWEA/STE FM 2 Vibration | 5d | 2004-07-14 | 2004-07-20 | 351 |  |  | 33d | 0d |  |
| 353 | 1.5.5.8.2.7 | SWEA/STE-D FM 2 Thermal Vac | 10d | 2004-07-21 | 2004-08-03 | 352 |  |  | 33d | 0d |  |
| 354 | 1.5.6 | **Boom Suite I&T - UCB** | 108d | 2004-04-09 | 2004-09-09 |  |  |  | 27d |  |  |
| 355 | 1.5.6.1 | **FM 1** | 90d | 2004-04-09 | 2004-08-13 |  |  |  | 27d |  |  |
| 356 | 1.5.6.1.1 | FM 1 Boom/MAG/STE-U I&T | 4d | 2004-04-09 | 2004-04-14 | 217, 245, 264 |  |  | 27d | 0d |  |
| 357 | 1.5.6.1.2 | FM 1 Boom/SWEA/STE/MAG I&T | 2d | 2004-05-18 | 2004-05-19 | 291, 191 |  |  | 27d | 0d |  |
| 358 | 1.5.6.1.3 | FM 1 Integrated Boom/IDPU I&T | 4d | 2004-05-20 | 2004-05-25 | 357, 191, 164 |  |  | 27d | 7d |  |
| 359 | 1.5.6.1.4 | BOOM Suite FM 1 Bakeout | 5d | 2004-07-26 | 2004-07-30 | 358, 345 |  |  | 37d | 0d |  |
| 360 | 1.5.6.1.5 | Final BOOM Suite FM 1 I & T | 10d | 2004-08-02 | 2004-08-13 | 359, 181 |  |  | 37d | 0d |  |

| ID | WBS | Task | Duration | Start | Finish | Predecessors | Complete | Remaining | Total slack | Free slack | Constraint |
| --- | --- | --- | --- | --- | --- | --- | --- | --- | --- | --- | --- |
| 361 | 1.5.6.2 | **FM 2** | 107d | 2004-04-12 | 2004-09-09 |  |  |  | 33d |  |  |
| 362 | 1.5.6.2.1 | FM 2 Boom/MAG/STE-U I&T | 4d | 2004-04-12 | 2004-04-15 | 239, 246, 265 |  |  | 87d | 0d |  |
| 363 | 1.5.6.2.2 | FM 2 Boom/SWEA/STE/MAG I&T | 2d | 2004-08-04 | 2004-08-05 | 292, 192 |  |  | 33d | 0d |  |
| 364 | 1.5.6.2.3 | FM 2 Integrated Boom/IDPU I&T | 4d | 2004-08-06 | 2004-08-11 | 363, 192, 775 |  |  | 33d | 0d |  |
| 365 | 1.5.6.2.4 | Boom Suite FM 2 EMC | 5d | 2004-08-12 | 2004-08-18 | 364 |  |  | 33d | 0d |  |
| 366 | 1.5.6.2.5 | BOOM Suite FM 2 Bakeout | 5d | 2004-08-19 | 2004-08-25 | 365 |  |  | 33d | 0d |  |
| 367 | 1.5.6.2.6 | Final BOOM Suite FM 2 I & T | 10d | 2004-08-26 | 2004-09-09 | 366, 186 |  |  | 33d | 0d |  |
| 368 | 1.6 | **SEP Suite - CIT** | 351d | 2003-06-02 A | 2004-10-20 |  | 29% | 249.28d | 255d |  |  |
| 369 | 1.6.1 | **SEP Mechanical - Sandy Shuman (GSFC)** | 93d | 2004-01-22 | 2004-06-02 |  |  |  | 19d |  |  |
| 370 | 1.6.1.1 | **SIT Electronics Enclosure (Priority 1)** | 21d | 2004-01-22 | 2004-02-20 |  |  |  | 22d |  |  |
| 371 | 1.6.1.1.1 | Complete Design/Drawings for SIT Enclosure | 5d | 2004-01-22 | 2004-01-28 |  |  |  | 22d | 0d | start no earlier than 2004-01-22 |
| 372 | 1.6.1.1.2 | Fabrication of SIT Enclosure | 10d | 2004-01-29 | 2004-02-11 | 371 |  |  | 33d | 0d |  |
| 373 | 1.6.1.1.3 | Inspection and Final Assembly of SIT Enclosure | 5d | 2004-02-12 | 2004-02-19 | 372 |  |  | 33d | 0d |  |
| 374 | 1.6.1.1.4 | Deliver SIT Enclosure to UMD | 1d | 2004-02-20 | 2004-02-20 | 373 |  |  | 33d | 0d |  |
| 375 | 1.6.1.2 | **SEP FM 1 & FM 2 LVPS Boxes (Priority 2)** | 23d | 2004-01-29 | 2004-03-02 |  |  |  | 22d |  |  |
| 376 | 1.6.1.2.1 | Complete Design/Drawings for SEP LVPS Boxes | 5d | 2004-01-29 | 2004-02-04 | 371 |  |  | 22d | 0d |  |
| 377 | 1.6.1.2.2 | Fabrication of SEP LVPS Boxes | 10d | 2004-02-05 | 2004-02-19 | 376 |  |  | 50d | 0d |  |
| 378 | 1.6.1.2.3 | Inspection and Final Assembly of SEP LVPS Boxes | 5d | 2004-02-20 | 2004-02-26 | 377 |  |  | 50d | 0d |  |
| 379 | 1.6.1.2.4 | Deliver SEP LVPS Boxes to UCB | 3d | 2004-02-27 | 2004-03-02 | 378 |  |  | 50d | 0d |  |
| 380 | 1.6.1.3 | **SEP Electronics Enclosure (Priority 3)** | 31d | 2004-02-05 | 2004-03-19 |  |  |  | 22d |  |  |
| 381 | 1.6.1.3.1 | Complete Design/Drawings for SEP Enclosure | 13d | 2004-02-05 | 2004-02-24 | 376 |  |  | 22d | 0d |  |
| 382 | 1.6.1.3.2 | Fabrication of SEP Enclosure | 10d | 2004-02-25 | 2004-03-09 | 381 |  |  | 65d | 0d |  |
| 383 | 1.6.1.3.3 | Inspection and Final Assembly of SEP Enclosure | 5d | 2004-03-10 | 2004-03-16 | 382 |  |  | 65d | 0d |  |
| 384 | 1.6.1.3.4 | Deliver SEP Enclosure to CIT | 3d | 2004-03-17 | 2004-03-19 | 383 |  |  | 65d | 29d |  |

| ID | WBS | Task | Type | Duration | Start | Finish | Predecessors | Total slack | Free slack | Constraint |
| --- | --- | --- | --- | --- | --- | --- | --- | --- | --- | --- |
| 385 | 1.6.1.4 | **SEP Central Bias Supply Shields (Priority 4)** |  | 20d | 2004-02-25 | 2004-03-23 |  | 22d |  |  |
| 386 | 1.6.1.4.1 | Complete Design/Drawings for Bias Supply Shields |  | 5d | 2004-02-25 | 2004-03-02 | 381 | 22d | 0d |  |
| 387 | 1.6.1.4.2 | Fabrication of Bias Supply Shields |  | 10d | 2004-03-03 | 2004-03-16 | 386 | 22d | 0d |  |
| 388 | 1.6.1.4.3 | Inspection and Delivery (to CIT) of Bias Supply Shields |  | 5d | 2004-03-17 | 2004-03-23 | 387 | 22d | 0d |  |
| 389 | 1.6.1.5 | **LET Telescope (Priority 5)** |  | 26d | 2004-03-03 | 2004-04-07 |  | 25d |  |  |
| 390 | 1.6.1.5.1 | Complete Design/Drawings for LET Telescope |  | 8d | 2004-03-03 | 2004-03-12 | 386 | 25d | 0d |  |
| 391 | 1.6.1.5.2 | Fabrication of LET Telescope |  | 10d | 2004-03-15 | 2004-03-26 | 390 | 38d | 0d |  |
| 392 | 1.6.1.5.3 | Inspection and Final Assembly of LET Telescope |  | 5d | 2004-03-29 | 2004-04-02 | 391 | 38d | 0d |  |
| 393 | 1.6.1.5.4 | Deliver LET Telescope to CIT |  | 3d | 2004-04-05 | 2004-04-07 | 392 | 38d | 16d |  |
| 394 | 1.6.1.6 | **HET Electronics Enclosure (Priority 6)** |  | 23d | 2004-03-15 | 2004-04-14 |  | 25d |  |  |
| 395 | 1.6.1.6.1 | Complete Design/Drawings for HET Enclosure |  | 8d | 2004-03-15 | 2004-03-24 | 390 | 25d | 0d |  |
| 396 | 1.6.1.6.2 | Fabrication of HET Enclosure |  | 10d | 2004-03-25 | 2004-04-07 | 395 | 25d | 0d |  |
| 397 | 1.6.1.6.3 | Inspection and Final Assembly of HET Enclosure |  | 5d | 2004-04-08 | 2004-04-14 | 396 | 25d | 0d |  |
| 398 | 1.6.1.6.4 | Deliver HET Enclosure (stays at GSFC) | milestone | 0d | 2004-04-14 | 2004-04-14 | 397 | 25d | 0d |  |
| 399 | 1.6.1.7 | **HET Telescope (Priority 7)** |  | 61d | 2004-01-27 | 2004-04-21 |  | 16d |  |  |
| 400 | 1.6.1.7.1 | On Going work for HET Telescope (Complete Design/Drawings & Prep for Fab) |  | 46d | 2004-01-27 | 2004-03-31 |  | 16d | 0d | start no earlier than 2004-01-27 |
| 401 | 1.6.1.7.2 | Fabrication of HET Telescope |  | 10d | 2004-04-01 | 2004-04-14 | 400 | 25d | 0d |  |
| 402 | 1.6.1.7.3 | Inspection and Final Assembly of HET Telescope |  | 5d | 2004-04-15 | 2004-04-21 | 401, 398 | 25d | 0d |  |
| 403 | 1.6.1.7.4 | Deliver HET Telescope (stays at GSFC) | milestone | 0d | 2004-04-21 | 2004-04-21 | 402 | 25d | 6d |  |
| 404 | 1.6.1.8 | **SIT Telescope (Priority 8)** |  | 34d | 2004-04-01 | 2004-05-18 |  | 16d |  |  |
| 405 | 1.6.1.8.1 | Complete Design/Drawings for SIT Telescope |  | 18d | 2004-04-01 | 2004-04-26 | 400 | 16d | 0d |  |
| 406 | 1.6.1.8.2 | Fabrication of SIT Telescope |  | 10d | 2004-04-27 | 2004-05-10 | 405 | 16d | 0d |  |
| 407 | 1.6.1.8.3 | Inspection and Final Assembly of SIT Telescope |  | 5d | 2004-05-11 | 2004-05-17 | 406 | 16d | 0d |  |
| 408 | 1.6.1.8.4 | Deliver SIT Telescope to UMD |  | 1d | 2004-05-18 | 2004-05-18 | 407 | 16d | 0d |  |

| ID | WBS | Task | Type | Duration | Start | Finish | Predecessors | Complete | Remaining | Total slack | Free slack | Constraint |
| --- | --- | --- | --- | --- | --- | --- | --- | --- | --- | --- | --- | --- |
| 409 | 1.6.1.9 | **Shipping Containers for HET, SIT & SEP Central (Priority 9)** |  | 23d | 2004-04-27 | 2004-05-27 |  |  |  | 23d |  |  |
| 410 | 1.6.1.9.1 | Design |  | 5d | 2004-04-27 | 2004-05-03 | 405 |  |  | 23d | 0d |  |
| 411 | 1.6.1.9.2 | Fabrication/Machining |  | 10d | 2004-05-04 | 2004-05-17 | 410 |  |  | 23d | 0d |  |
| 412 | 1.6.1.9.3 | Inspection and Assembly |  | 5d | 2004-05-18 | 2004-05-24 | 411 |  |  | 23d | 0d |  |
| 413 | 1.6.1.9.4 | HET Container stays at GSFC | milestone | 0d | 2004-05-24 | 2004-05-24 | 412 |  |  | 23d | 3d |  |
| 414 | 1.6.1.9.5 | SIT Container to UMD |  | 1d | 2004-05-25 | 2004-05-25 | 412 |  |  | 25d | 11d |  |
| 415 | 1.6.1.9.6 | SEP Central Container to CIT |  | 3d | 2004-05-25 | 2004-05-27 | 412 |  |  | 40d | 26d |  |
| 416 | 1.6.1.10 | **LET Radiation Test Fixture (Priority 10)** |  | 21d | 2004-05-04 | 2004-06-02 |  |  |  | 24d |  |  |
| 417 | 1.6.1.10.1 | Design |  | 5d | 2004-05-04 | 2004-05-10 | 410 |  |  | 24d | 0d |  |
| 418 | 1.6.1.10.2 | Fabrication |  | 10d | 2004-05-11 | 2004-05-24 | 417 |  |  | 24d | 0d |  |
| 419 | 1.6.1.10.3 | Inspection and Assembly |  | 5d | 2004-05-25 | 2004-06-01 | 418 |  |  | 24d | 0d |  |
| 420 | 1.6.1.10.4 | Deliver to CIT for SEP I&T |  | 1d | 2004-06-02 | 2004-06-02 | 419 |  |  | 24d | 10d |  |
| 421 | 1.6.2 | **SEP Central - CIT** |  | 211d | 2003-08-01 A | 2004-06-03 |  | 27% | 154.44d | 26d |  |  |
| 422 | 1.6.2.1 | **Deliveries** |  | 35d | 2004-04-14 | 2004-06-03 |  |  |  | 26d |  |  |
| 423 | 1.6.2.1.1 | Deliver all SEP Cen FM 1 Boards to SEP I&T (stays at CIT) | milestone | 0d | 2004-04-29 | 2004-04-29 | 447 |  |  | 36d | 0d |  |
| 424 | 1.6.2.1.2 | Deliver all SEP Cen FM 2 Boards & FM 2 LVPS to SEP I&T (stays at CIT) | milestone | 0d | 2004-04-29 | 2004-04-29 | 447 |  |  | 50d | 0d |  |
| 425 | 1.6.2.1.3 | SEP Central Build 3 Software Complete | milestone | 0d | 2004-04-14 | 2004-04-14 | 449 |  |  | 47d | 11d |  |
| 426 | 1.6.2.1.4 | Final SEP Central Flight Software Complete | milestone | 0d | 2004-06-03 | 2004-06-03 | 450 |  |  | 26d | 12d |  |
| 427 | 1.6.2.2 | **Logic Board** |  | 30d | 2004-02-13 | 2004-03-26 |  |  |  | 29d |  |  |
| 428 | 1.6.2.2.1 | **Assembly** |  | 10d | 2004-02-13 | 2004-02-27 |  |  |  | 29d |  |  |
| 429 | 1.6.2.2.1.1 | Assemble FM 1 SEP Central Logic board |  | 10d | 2004-02-13 | 2004-02-27 |  |  |  | 29d | 0d | start no earlier than 2004-02-13 |
| 430 | 1.6.2.2.1.2 | Assemble FM 2 SEP Central Logic board |  | 10d | 2004-02-13 | 2004-02-27 | 429SS |  |  | 29d | 0d |  |
| 431 | 1.6.2.2.2 | **Test** |  | 20d | 2004-03-01 | 2004-03-26 |  |  |  | 29d |  |  |
| 432 | 1.6.2.2.2.1 | Test FM 1 SEP Central Logic board (initial) |  | 20d | 2004-03-01 | 2004-03-26 | 429 |  |  | 29d | 7d |  |
| 433 | 1.6.2.2.2.2 | Test FM 2 SEP Central Logic board (initial) |  | 20d | 2004-03-01 | 2004-03-26 | 430 |  |  | 29d | 7d |  |

| ID | WBS | Task | Type | Duration | Start | Finish | Predecessors | Complete | Remaining | Total slack | Free slack | Constraint |
| --- | --- | --- | --- | --- | --- | --- | --- | --- | --- | --- | --- | --- |
| 434 | 1.6.2.3 | **Analog/Post-Reg Board** |  | 0d | 2004-01-27 A | 2004-01-27 A |  | 100% |  |  |  |  |
| 435 | 1.6.2.3.1 | FM 1 Analog/Post-Reg Board Complete Test and awaiting Conformal Coat with other SEP Central Boards | milestone | 0d | 2004-01-27 A | 2004-01-27 A |  | 100% |  |  |  | start no earlier than 2004-01-27 |
| 436 | 1.6.2.3.2 | FM 2 Analog/Post-Reg Board Complete Test and awaiting Conformal Coat with other SEP Central Boards | milestone | 0d | 2004-01-27 A | 2004-01-27 A |  | 100% |  |  |  | start no earlier than 2004-01-27 |
| 437 | 1.6.2.4 | **SEP Solid State Detector Bias Supply Board** |  | 55d | 2004-01-20 | 2004-04-06 |  |  |  | 22d |  |  |
| 438 | 1.6.2.4.1 | **Assembly & Initial Test** |  | 40d | 2004-01-20 | 2004-03-16 |  |  |  | 27d |  |  |
| 439 | 1.6.2.4.1.1 | Assemble and Initial Test FM 1 SSD Bias Supply Board |  | 40d | 2004-01-20 | 2004-03-16 |  |  |  | 27d | 0d | start no earlier than 2004-01-20 |
| 440 | 1.6.2.4.1.2 | Assemble and Initial Test FM 2 SSD Bias Supply Board |  | 40d | 2004-01-20 | 2004-03-16 | 439SS |  |  | 27d | 5d |  |
| 441 | 1.6.2.4.2 | **Final Test** |  | 10d | 2004-03-24 | 2004-04-06 |  |  |  | 22d |  |  |
| 442 | 1.6.2.4.2.1 | Final Test FM 1 SSD Bias Supply Board |  | 10d | 2004-03-24 | 2004-04-06 | 439, 388 |  |  | 22d | 0d |  |
| 443 | 1.6.2.4.2.2 | Final Test FM 2 SSD Bias Supply Board |  | 10d | 2004-03-24 | 2004-04-06 | 440, 388 |  |  | 22d | 0d |  |
| 444 | 1.6.2.5 | **Conformal Coat, Mass Properties and Bake Out (SEP Central, LET, SEP LVPS)** |  | 17d | 2004-04-07 | 2004-04-29 |  |  |  | 22d |  |  |
| 445 | 1.6.2.5.1 | Stake/Conformal Coat All SEP Central and LET Boards |  | 10d | 2004-04-07 | 2004-04-20 | 432, 433, 435, 436, 442, 443, 512, 513 |  |  | 22d | 0d |  |
| 446 | 1.6.2.5.2 | Mass Properties/Photo All SEP Central and LET Boards |  | 4d | 2004-04-21 | 2004-04-26 | 445 |  |  | 22d | 0d |  |
| 447 | 1.6.2.5.3 | Bake Out All SEP Central/LET Boards and SEP LVPS (FM 1 & 2) |  | 3d | 2004-04-27 | 2004-04-29 | 446, 77, 71 |  |  | 22d | 0d |  |
| 448 | 1.6.2.6 | **Flight Software** |  | 211d | 2003-08-01 A | 2004-06-03 |  | 49% | 107d | 26d |  |  |
| 449 | 1.6.2.6.1 | SEP Central Build 3 |  | 176d | 2003-08-01 A | 2004-04-14 |  | 59% | 72d | 26d | 0d | start no earlier than 2003-08-01 |
| 450 | 1.6.2.6.2 | Final Flight S/W Build |  | 35d | 2004-04-15 | 2004-06-03 | 449 |  |  | 26d | 0d |  |
| 451 | 1.6.3 | **HET - GSFC** |  | 118d | 2004-01-06 | 2004-06-22 |  |  |  | 19d |  |  |
| 452 | 1.6.3.1 | **Deliveries** |  | 37d | 2004-04-30 | 2004-06-22 |  |  |  | 19d |  |  |
| 453 | 1.6.3.1.1 | Deliver HET FM 1 (to CIT for SEP Suite I&T) |  | 2d | 2004-05-28 | 2004-06-01 | 494, 413 |  |  | 20d | 0d |  |
| 454 | 1.6.3.1.2 | Deliver HET FM 2 (to CIT for SEP Suite I&T) |  | 2d | 2004-06-21 | 2004-06-22 | 497, 413 |  |  | 19d | 0d |  |
| 455 | 1.6.3.1.3 | Deliver Final HET Flight Software to SEP I&T |  | 2d | 2004-04-30 | 2004-05-03 | 490 |  |  | 40d | 20d |  |
| 456 | 1.6.3.2 | **Detectors** |  | 60d | 2004-01-06 | 2004-03-31 |  |  |  | 40d |  |  |
| 457 | 1.6.3.2.1 | Receive & Inspect HET Flight Detectors |  | 40d | 2004-01-06 | 2004-03-03 |  |  |  | 40d | 0d | start no earlier than 2004-01-06 |

| ID | WBS | Task | Duration | Start | Finish | Predecessors | Total slack | Free slack | Constraint |
| --- | --- | --- | --- | --- | --- | --- | --- | --- | --- |
| 458 | 1.6.3.2.2 | **Detector Testing** | 60d | 2004-01-06 | 2004-03-31 |  | 40d |  |  |
| 459 | 1.6.3.2.2.1 | Capacitance, Current, Depletion, Alpha Resolution Testing | 60d | 2004-01-06 | 2004-03-31 | 457SS | 40d | 0d |  |
| 460 | 1.6.3.2.2.2 | Life Test HET Detectors | 60d | 2004-01-06 | 2004-03-31 | 459SS | 40d | 21d |  |
| 461 | 1.6.3.3 | **Electronics Board** | 80d | 2004-01-22 | 2004-05-13 |  | 24d |  |  |
| 462 | 1.6.3.3.1 | **Assembly** | 36d | 2004-01-22 | 2004-03-12 |  | 24d |  |  |
| 463 | 1.6.3.3.1.1 | Install Socket on HET Electronics FM 1 Board for ETU ACTEL | 1d | 2004-01-22 | 2004-01-22 |  | 24d | 0d | start no earlier than 2004-01-22 |
| 464 | 1.6.3.3.1.2 | Complete Population of HET Electronics FM 1 Board (ETU ACTEL) | 1d | 2004-01-23 | 2004-01-23 | 463 | 24d | 0d |  |
| 465 | 1.6.3.3.1.3 | Complete Population of HET Electronics FM 2 Board (Flight ACTEL) | 2d | 2004-03-11 | 2004-03-12 | 464, 471, 506 | 30d | 6d |  |
| 466 | 1.6.3.3.2 | **Test** | 78d | 2004-01-26 | 2004-05-13 |  | 24d |  |  |
| 467 | 1.6.3.3.2.1 | **FM 1** | 40d | 2004-01-26 | 2004-03-22 |  | 24d |  |  |
| 468 | 1.6.3.3.2.1.1 | Test HET FM 1 Electronics Board w/ETU ACTEL | 20d | 2004-01-26 | 2004-02-23 | 464 | 24d | 0d |  |
| 469 | 1.6.3.3.2.1.2 | Remove ETU ACTEL and socket from HET FM 1 Electronics Board | 1d | 2004-02-24 | 2004-02-24 | 468 | 24d | 0d |  |
| 470 | 1.6.3.3.2.1.3 | Install Flight ACTEL on HET FM 1 Electronics Board | 1d | 2004-02-25 | 2004-02-25 | 469 | 24d | 0d |  |
| 471 | 1.6.3.3.2.1.4 | Retest HET FM 1 Electronics Board w/Flight ACTEL | 10d | 2004-02-26 | 2004-03-10 | 470 | 24d | 0d |  |
| 472 | 1.6.3.3.2.1.5 | Conformal Coat HET FM 1 Electronics Board | 2d | 2004-03-11 | 2004-03-12 | 471 | 24d | 0d |  |
| 473 | 1.6.3.3.2.1.6 | Retest Conformal Coated HET FM 1 Electronics Board | 2d | 2004-03-15 | 2004-03-16 | 472 | 24d | 0d |  |
| 474 | 1.6.3.3.2.1.7 | Bakeout HET FM 1 Electronics Board | 2d | 2004-03-17 | 2004-03-18 | 473 | 24d | 0d |  |
| 475 | 1.6.3.3.2.1.8 | Retest Bakedout HET FM 1 Electronics Board | 2d | 2004-03-19 | 2004-03-22 | 474 | 24d | 0d |  |
| 476 | 1.6.3.3.2.2 | **FM 2** | 38d | 2004-03-23 | 2004-05-13 |  | 24d |  |  |
| 477 | 1.6.3.3.2.2.1 | Test HET FM 2 Electronics Board | 30d | 2004-03-23 | 2004-05-03 | 465, 468, 475 | 24d | 0d |  |
| 478 | 1.6.3.3.2.2.2 | Conformal Coat HET FM 2 Electronics Board | 2d | 2004-05-04 | 2004-05-05 | 477 | 24d | 0d |  |
| 479 | 1.6.3.3.2.2.3 | Retest Conformal Coated HET FM 2 Electronics Board | 2d | 2004-05-06 | 2004-05-07 | 478, 473 | 24d | 0d |  |
| 480 | 1.6.3.3.2.2.4 | Bakeout HET FM 2 Electronics Board | 2d | 2004-05-10 | 2004-05-11 | 479 | 24d | 0d |  |
| 481 | 1.6.3.3.2.2.5 | Retest Bakedout HET FM 2 Electronics Board | 2d | 2004-05-12 | 2004-05-13 | 480, 475 | 24d | 0d |  |

| ID | WBS | Task | Type | Duration | Start | Finish | Predecessors | Complete | Remaining | Total slack | Free slack | Constraint |
| --- | --- | --- | --- | --- | --- | --- | --- | --- | --- | --- | --- | --- |
| 482 | 1.6.3.4 | **Flight Software** |  | 70d | 2004-01-22 | 2004-04-29 |  |  |  | 19d |  |  |
| 483 | 1.6.3.4.1 | **Design** |  | 10d | 2004-01-22 | 2004-02-04 |  |  |  | 19d |  |  |
| 484 | 1.6.3.4.1.1 | Complete Definition of HET PH Event Processing |  | 10d | 2004-01-22 | 2004-02-04 |  |  |  | 19d | 0d | start no earlier than 2004-01-22 |
| 485 | 1.6.3.4.2 | **Coding** |  | 20d | 2004-02-05 | 2004-03-04 |  |  |  | 19d |  |  |
| 486 | 1.6.3.4.2.1 | Code HET PH Event Processing Update for Flight |  | 10d | 2004-02-05 | 2004-02-19 | 484 |  |  | 19d | 0d |  |
| 487 | 1.6.3.4.2.2 | Code HET Telemetry Formatting Update for Flight |  | 10d | 2004-02-20 | 2004-03-04 | 486 |  |  | 19d | 0d |  |
| 488 | 1.6.3.4.3 | **Test** |  | 40d | 2004-03-05 | 2004-04-29 |  |  |  | 19d |  |  |
| 489 | 1.6.3.4.3.1 | Test Integrated HET S/W with Simulated Data |  | 15d | 2004-03-05 | 2004-03-25 | 487 |  |  | 19d | 0d |  |
| 490 | 1.6.3.4.3.2 | Verify HET On-Board Software |  | 25d | 2004-03-26 | 2004-04-29 | 489 |  |  | 19d | 0d |  |
| 491 | 1.6.3.5 | **Integration & Test** |  | 35d | 2004-04-30 | 2004-06-18 |  |  |  | 19d |  |  |
| 492 | 1.6.3.5.1 | **FM 1** |  | 20d | 2004-04-30 | 2004-05-27 |  |  |  | 19d |  |  |
| 493 | 1.6.3.5.1.1 | Integrate HET FM 1 Electronics Telescope (Ahead) |  | 5d | 2004-04-30 | 2004-05-06 | 475, 460, 490, 403 |  |  | 19d | 0d |  |
| 494 | 1.6.3.5.1.2 | Test HET FM 1 Telescope (Ahead) |  | 15d | 2004-05-07 | 2004-05-27 | 493 |  |  | 19d | 0d |  |
| 495 | 1.6.3.5.2 | **FM 2** |  | 25d | 2004-05-14 | 2004-06-18 |  |  |  | 19d |  |  |
| 496 | 1.6.3.5.2.1 | Integrate HET FM 2 Electronics Telescope (Behind) |  | 5d | 2004-05-14 | 2004-05-20 | 481, 493, 460, 490, 403 |  |  | 24d | 5d |  |
| 497 | 1.6.3.5.2.2 | Test HET FM 2 Telescope (Behind) |  | 15d | 2004-05-28 | 2004-06-18 | 494, 496 |  |  | 19d | 0d |  |
| 498 | 1.6.4 | **LET - CIT** |  | 221d | 2003-07-14 A | 2004-05-27 |  | 56% | 97.42d | 36d |  |  |
| 499 | 1.6.4.1 | **Deliveries** |  | 17d | 2004-05-04 | 2004-05-27 |  |  |  | 36d |  |  |
| 500 | 1.6.4.1.1 | Deliver LET FM 1 (stays at CIT for SEP I&T) | milestone | 0d | 2004-05-27 | 2004-05-27 | 518 |  |  | 22d | 0d |  |
| 501 | 1.6.4.1.2 | Deliver LET FM 2 (stays at CIT for SEP I&T) | milestone | 0d | 2004-05-27 | 2004-05-27 | 520 |  |  | 36d | 0d |  |
| 502 | 1.6.4.1.3 | Deliver LET Flight Software Build 3 | milestone | 0d | 2004-05-04 | 2004-05-04 | 515 |  |  | 39d | 17d |  |
| 503 | 1.6.4.2 | **Detectors** |  | 167d | 2003-07-14 A | 2004-03-12 |  | 71% | 49d | 56d |  |  |
| 504 | 1.6.4.2.1 | Complete LET Flight Detector Testing |  | 167d | 2003-07-14 A | 2004-03-12 |  | 71% | 49d | 56d | 34d | start no earlier than 2003-07-14 |
| 505 | 1.6.4.3 | **Hybrids** |  | 144d | 2003-08-01 A | 2004-03-01 |  | 72% | 40d | 27d |  |  |
| 506 | 1.6.4.3.1 | Complete Test of Flight Hybrids (LET and to GSFC for HET FM 2) |  | 144d | 2003-08-01 A | 2004-03-01 |  | 72% | 40d | 27d | 0d | start no earlier than 2003-08-01 |

| ID | WBS | Task | Duration | Start | Finish | Predecessors | Complete | Remaining | Total slack | Free slack | Constraint |
| --- | --- | --- | --- | --- | --- | --- | --- | --- | --- | --- | --- |
| 507 | 1.6.4.4 | **Detector/Misc Board** | 21d | 2004-03-02 | 2004-03-30 |  |  |  | 27d |  |  |
| 508 | 1.6.4.4.1 | **Assembly** | 10d | 2004-03-02 | 2004-03-15 |  |  |  | 27d |  |  |
| 509 | 1.6.4.4.1.1 | Assemble LET FM 1 Detector Board | 10d | 2004-03-02 | 2004-03-15 | 506 |  |  | 27d | 0d |  |
| 510 | 1.6.4.4.1.2 | Assemble LET FM 2 Detector Board | 10d | 2004-03-02 | 2004-03-15 | 506 |  |  | 27d | 0d |  |
| 511 | 1.6.4.4.2 | **Test** | 11d | 2004-03-16 | 2004-03-30 |  |  |  | 27d |  |  |
| 512 | 1.6.4.4.2.1 | Test LET FM 1 Detector Board | 11d | 2004-03-16 | 2004-03-30 | 509 |  |  | 27d | 5d |  |
| 513 | 1.6.4.4.2.2 | Test LET FM 2 Detector Board | 11d | 2004-03-16 | 2004-03-30 | 510 |  |  | 27d | 5d |  |
| 514 | 1.6.4.5 | **Flight Software** | 190d | 2003-08-01 A | 2004-05-04 |  | 55% | 86d | 39d |  |  |
| 515 | 1.6.4.5.1 | Let Flight Software Build 3 | 190d | 2003-08-01 A | 2004-05-04 |  | 55% | 86d | 39d | 0d | start no earlier than 2003-08-01 |
| 516 | 1.6.4.6 | **Integration & Test** | 20d | 2004-04-30 | 2004-05-27 |  |  |  | 22d |  |  |
| 517 | 1.6.4.6.1 | **FM 1** | 20d | 2004-04-30 | 2004-05-27 |  |  |  | 22d |  |  |
| 518 | 1.6.4.6.1.1 | Integrate LET FM 1 Housing With Detectors | 20d | 2004-04-30 | 2004-05-27 | 504, 447, 393 |  |  | 22d | 0d |  |
| 519 | 1.6.4.6.2 | **FM 2** | 20d | 2004-04-30 | 2004-05-27 |  |  |  | 36d |  |  |
| 520 | 1.6.4.6.2.1 | Integrate LET FM 2 Housing With Detectors | 20d | 2004-04-30 | 2004-05-27 | 504, 447, 393 |  |  | 36d | 0d |  |
| 521 | 1.6.5 | **SEPT - Kiel/ESTEC** | 240d | 2003-08-08 A | 2004-07-21 |  | 35% | 154.99d | 318d |  |  |
| 522 | 1.6.5.1 | **Deliveries** | 102d | 2004-03-01 | 2004-07-21 |  |  |  | 68d |  |  |
| 523 | 1.6.5.1.1 | Deliver SEPT-NS FM 1 to CIT for SEP I&T and Suite EMC | 5d | 2004-03-12 | 2004-03-18 | 567, 568 |  |  | 70d | 0d |  |
| 524 | 1.6.5.1.2 | Deliver SEPT-E FM 1 to CIT for SEP I&T and Suite EMC | 5d | 2004-03-01 | 2004-03-05 | 574, 575 |  |  | 79d | 9d |  |
| 525 | 1.6.5.1.3 | Final Delivery of SEPT FM 1 to APL | 2d | 2004-07-20 | 2004-07-21 | 569, 576 |  |  | 54d | 33d |  |
| 526 | 1.6.5.1.4 | Deliver SEPT-NS FM 2 to CIT for SEP I&T and Suite EMC | 5d | 2004-03-08 | 2004-03-12 | 582, 583 |  |  | 88d | 0d |  |
| 527 | 1.6.5.1.5 | Deliver SEPT-E FM 2 to CIT for SEP I&T and Suite EMC | 5d | 2004-03-08 | 2004-03-12 | 589, 590 |  |  | 88d | 0d |  |
| 528 | 1.6.5.1.6 | Final Delivery of SEPT FM 2 to APL | 2d | 2004-07-20 | 2004-07-21 | 584, 591 |  |  | 68d | 52d |  |
| 529 | 1.6.5.2 | **Mechanical Assembly** | 46d | 2003-12-22 A | 2004-02-27 |  | 66% | 15.71d | 420d |  |  |
| 530 | 1.6.5.2.1 | **FM 1** | 13d | 2003-12-22 A | 2004-01-09 A |  | 100% |  |  |  |  |
| 531 | 1.6.5.2.1.1 | Assemble SEPT-NS FM 1 Sensor and E-Box Housing | 13d | 2003-12-22 A | 2004-01-09 A |  | 100% |  |  |  | start no earlier than 2003-12-22 |
| 532 | 1.6.5.2.1.2 | Assemble SEPT-E FM 1 Sensor and E-Box Housing | 13d | 2003-12-22 A | 2004-01-09 A |  | 100% |  |  |  | start no earlier than 2003-12-22 |

| ID | WBS | Task | Duration | Start | Finish | Predecessors | Complete | Remaining | Total slack | Free slack | Constraint |
| --- | --- | --- | --- | --- | --- | --- | --- | --- | --- | --- | --- |
| 533 | 1.6.5.2.2 | **FM 2** | 14d | 2003-12-29 A | 2004-01-16 A |  | 100% |  |  |  |  |
| 534 | 1.6.5.2.2.1 | Assemble SEPT-NS FM 2 Sensor and E-Box Housing | 14d | 2003-12-29 A | 2004-01-16 A | 531SS+4d | 100% |  |  |  |  |
| 535 | 1.6.5.2.2.2 | Assemble SEPT-E FM 2 Sensor and E-Box Housing | 14d | 2003-12-29 A | 2004-01-16 A | 532SS+4d | 100% |  |  |  |  |
| 536 | 1.6.5.2.3 | **Spare** | 28d | 2004-01-20 | 2004-02-27 |  |  |  | 420d |  |  |
| 537 | 1.6.5.2.3.1 | Assemble SEPT Spare Sensor and E-Box Housing | 28d | 2004-01-20 | 2004-02-27 | 534, 535 |  |  | 420d |  |  |
| 538 | 1.6.5.3 | **Electronics** | 144d | 2003-08-08 A | 2004-03-08 |  | 43% | 82.09d | 414d |  |  |
| 539 | 1.6.5.3.1 | **Assembly** | 124d | 2003-08-08 A | 2004-02-06 |  | 44% | 68.95d | 414d |  |  |
| 540 | 1.6.5.3.1.1 | **FM 2** | 106d | 2003-08-08 A | 2004-01-12 A |  | 100% |  |  |  |  |
| 541 | 1.6.5.3.1.1.1 | Assemble SEPT-NS FM 2 Electronics | 106d | 2003-08-08 A | 2004-01-12 A |  | 100% |  |  |  | start no earlier than 2003-08-08 |
| 542 | 1.6.5.3.1.1.2 | Assemble SEPT-E FM 2 Electronics | 92d | 2003-08-08 A | 2003-12-19 A |  | 100% |  |  |  | start no earlier than 2003-08-08 |
| 543 | 1.6.5.3.1.2 | **Spare** | 124d | 2003-08-08 | 2004-02-06 |  |  |  | 414d |  |  |
| 544 | 1.6.5.3.1.2.1 | Assemble SEPT-NS FS Electronics | 124d | 2003-08-08 | 2004-02-06 | 541SS |  |  | 414d | 0d |  |
| 545 | 1.6.5.3.1.2.2 | Assemble SEPT-E FS Electronics | 124d | 2003-08-08 | 2004-02-06 | 542SS |  |  | 414d | 0d |  |
| 546 | 1.6.5.3.2 | **Test** | 59d | 2003-12-11 A | 2004-03-08 |  | 35% | 38.55d | 414d |  |  |
| 547 | 1.6.5.3.2.1 | **FM 2** | 34d | 2003-12-11 A | 2004-01-30 |  | 74% | 8.74d | 439d |  |  |
| 548 | 1.6.5.3.2.1.1 | SEPT-NS FM 2 Electronics Test | 4d | 2004-01-13 A | 2004-01-16 A | 541 | 100% |  |  |  |  |
| 549 | 1.6.5.3.2.1.2 | SEPT-E FM 2 Electronics Test | 4d | 2003-12-11 A | 2003-12-16 A | 542FS-7d | 100% |  |  |  |  |
| 550 | 1.6.5.3.2.1.3 | Coat SEPT-NS FM 2 Electronics Board | 4d | 2004-01-20 | 2004-01-23 | 548 |  |  | 439d | 0d |  |
| 551 | 1.6.5.3.2.1.4 | Coat SEPT-E FM 2 Electronics Board | 5d | 2003-12-17 A | 2003-12-23 A | 549 | 100% |  |  |  |  |
| 552 | 1.6.5.3.2.1.5 | SEPT-NS FM 2 Mechanical Integration | 5d | 2004-01-26 | 2004-01-30 | 550 |  |  | 439d |  |  |
| 553 | 1.6.5.3.2.1.6 | SEPT-E FM 2 Mechanical Integration | 13d | 2003-12-24 A | 2004-01-13 A | 551 | 100% |  |  |  |  |
| 554 | 1.6.5.3.2.2 | **Spare** | 20d | 2004-02-09 | 2004-03-08 |  |  |  | 414d |  |  |
| 555 | 1.6.5.3.2.2.1 | SEPT-NS Flight Spare Electronics Test | 5d | 2004-02-09 | 2004-02-13 | 544 |  |  | 414d | 0d |  |
| 556 | 1.6.5.3.2.2.2 | SEPT-E Flight Spare Electronics Test | 5d | 2004-02-09 | 2004-02-13 | 545 |  |  | 414d | 0d |  |
| 557 | 1.6.5.3.2.2.3 | Coat SEPT-NS FS Electronics Board | 5d | 2004-02-17 | 2004-02-23 | 555 |  |  | 414d | 0d |  |
| 558 | 1.6.5.3.2.2.4 | Coat SEPT-E FS Electronics Board | 5d | 2004-02-17 | 2004-02-23 | 556 |  |  | 414d | 0d |  |
| 559 | 1.6.5.3.2.2.5 | SEPT-NS FS Mechanical Integration | 10d | 2004-02-24 | 2004-03-08 | 557 |  |  | 414d |  |  |
| 560 | 1.6.5.3.2.2.6 | SEPT-E FS Mechanical Integration | 10d | 2004-02-24 | 2004-03-08 | 558 |  |  | 414d |  |  |

| ID | WBS | Task | Duration | Start | Finish | Predecessors | Complete | Remaining | Total slack | Free slack | Constraint |
| --- | --- | --- | --- | --- | --- | --- | --- | --- | --- | --- | --- |
| 561 | 1.6.5.4 | **Integration & Test** | 133d | 2004-01-12 A | 2004-07-19 |  | 3% | 129.13d | 68d |  |  |
| 562 | 1.6.5.4.1 | **FM 1** | 133d | 2004-01-12 A | 2004-07-19 |  | 6% | 125.27d | 54d |  |  |
| 563 | 1.6.5.4.1.1 | **SEPT-NS** | 124d | 2004-01-26 | 2004-07-19 |  |  |  | 54d |  |  |
| 564 | 1.6.5.4.1.1.1 | SEPT-NS FM 1 Integration & Test | 5d | 2004-01-26 | 2004-01-30 | 531 |  |  | 70d | 0d | start no earlier than 2004-01-26 |
| 565 | 1.6.5.4.1.1.2 | Muon and Radioactive Source Test | 5d | 2004-02-02 | 2004-02-06 | 564 |  |  | 70d | 0d |  |
| 566 | 1.6.5.4.1.1.3 | SEPT-NS FM 1 Vibration and Acoustics | 10d | 2004-02-09 | 2004-02-23 | 565 |  |  | 70d | 0d |  |
| 567 | 1.6.5.4.1.1.4 | SEPT-NS FM 1 Thermal Vac | 10d | 2004-02-24 | 2004-03-08 | 566 |  |  | 70d | 0d |  |
| 568 | 1.6.5.4.1.1.5 | SEPT-NS FM 1 Bake Out | 3d | 2004-03-09 | 2004-03-11 | 567 |  |  | 70d | 0d |  |
| 569 | 1.6.5.4.1.1.6 | SEPT-NS FM 1 Thermal Balance | 10d | 2004-07-06 | 2004-07-19 | 18 |  |  | 54d | 0d |  |
| 570 | 1.6.5.4.1.2 | **SEPT-E** | 133d | 2004-01-12 A | 2004-07-19 |  | 12% | 117.53d | 54d |  |  |
| 571 | 1.6.5.4.1.2.1 | SEPT-E FM 1 Integration & Test | 5d | 2004-01-12 A | 2004-01-16 A | 532 | 100% |  |  |  |  |
| 572 | 1.6.5.4.1.2.2 | Muon and Radioactive Source Test | 5d | 2004-01-20 | 2004-01-26 | 571 |  |  | 79d | 0d |  |
| 573 | 1.6.5.4.1.2.3 | SEPT-E FM 1 Vibration and Acoustics | 10d | 2004-01-27 | 2004-02-09 | 572 |  |  | 79d | 0d |  |
| 574 | 1.6.5.4.1.2.4 | SEPT-E FM 1 Thermal Vac | 10d | 2004-02-10 | 2004-02-24 | 573 |  |  | 79d | 0d |  |
| 575 | 1.6.5.4.1.2.5 | SEPT-E FM 1 Bake Out | 3d | 2004-02-25 | 2004-02-27 | 574 |  |  | 79d | 0d |  |
| 576 | 1.6.5.4.1.2.6 | SEPT-E FM 1 Thermal Balance | 10d | 2004-07-06 | 2004-07-19 | 18 |  |  | 54d | 0d |  |
| 577 | 1.6.5.4.2 | **FM 2** | 128d | 2004-01-20 | 2004-07-19 |  |  |  | 68d |  |  |
| 578 | 1.6.5.4.2.1 | **SEPT-NS** | 128d | 2004-01-20 | 2004-07-19 |  |  |  | 68d |  |  |
| 579 | 1.6.5.4.2.1.1 | SEPT-NS FM 2 Integration & Test | 5d | 2004-01-20 | 2004-01-26 | 534 |  |  | 88d | 0d |  |
| 580 | 1.6.5.4.2.1.2 | Muon and Radioactive Source Test | 5d | 2004-01-27 | 2004-02-02 | 579 |  |  | 88d | 0d |  |
| 581 | 1.6.5.4.2.1.3 | SEPT-NS FM 2 Vibration and Acoustics | 10d | 2004-02-03 | 2004-02-17 | 580 |  |  | 88d | 0d |  |
| 582 | 1.6.5.4.2.1.4 | SEPT-NS FM 2 Thermal Vac | 10d | 2004-02-18 | 2004-03-02 | 581 |  |  | 88d | 0d |  |
| 583 | 1.6.5.4.2.1.5 | SEPT-NS FM 2 Bake Out | 3d | 2004-03-03 | 2004-03-05 | 582 |  |  | 88d | 0d |  |
| 584 | 1.6.5.4.2.1.6 | SEPT-NS FM 2 Thermal Balance | 10d | 2004-07-06 | 2004-07-19 | 18 |  |  | 68d | 0d |  |

| ID | WBS | Task | Duration | Start | Finish | Predecessors | Complete | Remaining | Total slack | Free slack | Constraint |
| --- | --- | --- | --- | --- | --- | --- | --- | --- | --- | --- | --- |
| 585 | 1.6.5.4.2.2 | **SEPT-E** | 128d | 2004-01-20 | 2004-07-19 |  |  |  | 68d |  |  |
| 586 | 1.6.5.4.2.2.1 | SEPT-E FM 2 Integration & Test | 5d | 2004-01-20 | 2004-01-26 | 535 |  |  | 88d | 0d |  |
| 587 | 1.6.5.4.2.2.2 | Muon and Radioactive Source Test | 5d | 2004-01-27 | 2004-02-02 | 586 |  |  | 88d | 0d |  |
| 588 | 1.6.5.4.2.2.3 | SEPT-E FM 2 Vibration and Acoustics | 10d | 2004-02-03 | 2004-02-17 | 587 |  |  | 88d | 0d |  |
| 589 | 1.6.5.4.2.2.4 | SEPT-E FM 2 Thermal Vac | 10d | 2004-02-18 | 2004-03-02 | 588 |  |  | 88d | 0d |  |
| 590 | 1.6.5.4.2.2.5 | SEPT-E FM 2 Bake Out | 3d | 2004-03-03 | 2004-03-05 | 589 |  |  | 88d | 0d |  |
| 591 | 1.6.5.4.2.2.6 | SEPT-E FM 2 Thermal Balance | 10d | 2004-07-06 | 2004-07-19 | 18 |  |  | 68d | 0d |  |
| 592 | 1.6.6 | **SIT - UMD** | 351d | 2003-06-02 A | 2004-10-20 |  | 26% | 261.02d | 255d |  |  |
| 593 | 1.6.6.1 | **Deliveries** | 81d | 2004-06-11 | 2004-10-04 |  |  |  | 14d |  |  |
| 594 | 1.6.6.1.1 | Deliver SIT FM 1 to CIT for SEP I&T and Suite EMC | 2d | 2004-06-11 | 2004-06-14 | 414, 693 |  |  | 14d | 0d |  |
| 595 | 1.6.6.1.2 | Deliver SIT FM 1 back to GSFC for Environmental Testing (after EMC Test) | 2d | 2004-07-06 | 2004-07-07 | 18 |  |  | 29d | 0d |  |
| 596 | 1.6.6.1.3 | Final Delivery of SIT FM 1 to APL | 1d | 2004-08-25 | 2004-08-25 | 725 |  |  | 29d | 8d |  |
| 597 | 1.6.6.1.4 | Deliver SIT FM 2 to CIT for SEP I&T | 2d | 2004-07-23 | 2004-07-26 | 698, 414 |  |  | 16d | 0d |  |
| 598 | 1.6.6.1.5 | Deliver SIT FM 2 back to GSFC for Environmental Testing | 2d | 2004-08-12 | 2004-08-13 | 790 |  |  | 16d | 0d |  |
| 599 | 1.6.6.1.6 | Final Delivery of SIT FM 2 to APL | 1d | 2004-10-04 | 2004-10-04 | 734 |  |  | 16d | 0d |  |
| 600 | 1.6.6.2 | **Detectors** | 43d | 2004-01-05 | 2004-03-05 |  |  |  | 42d |  |  |
| 601 | 1.6.6.2.1 | **Detector Testing** | 43d | 2004-01-05 | 2004-03-05 |  |  |  | 42d |  |  |
| 602 | 1.6.6.2.1.1 | **FM 1** | 43d | 2004-01-05 | 2004-03-05 |  |  |  | 33d |  |  |
| 603 | 1.6.6.2.1.1.1 | Test FM 1 Solid States Detectors | 24d | 2004-01-05 | 2004-02-06 |  |  |  | 42d | 0d | start no earlier than 2004-01-05 |
| 604 | 1.6.6.2.1.1.2 | Test FM 1 Foils | 24d | 2004-01-05 | 2004-02-06 | 603SS |  |  | 42d | 0d |  |
| 605 | 1.6.6.2.1.1.3 | Alpha Tests FM 1 w/Proto Elect | 10d | 2004-02-23 | 2004-03-05 | 603, 604, 374 |  |  | 33d | 0d |  |
| 606 | 1.6.6.2.1.2 | **FM 2** | 43d | 2004-01-05 | 2004-03-05 |  |  |  | 68d |  |  |
| 607 | 1.6.6.2.1.2.1 | Test FM 2 Solid States Detectors | 24d | 2004-01-05 | 2004-02-06 | 603SS |  |  | 77d | 9d |  |
| 608 | 1.6.6.2.1.2.2 | Test FM 2 Foils | 24d | 2004-01-05 | 2004-02-06 | 604SS |  |  | 77d | 9d |  |
| 609 | 1.6.6.2.1.2.3 | Alpha Tests FM 2 w/Proto Elect | 10d | 2004-02-23 | 2004-03-05 | 607, 608, 374 |  |  | 68d | 52d |  |

| ID | WBS | Task | Type | Duration | Start | Finish | Predecessors | Complete | Remaining | Total slack | Free slack | Constraint |
| --- | --- | --- | --- | --- | --- | --- | --- | --- | --- | --- | --- | --- |
| 610 | 1.6.6.3 | **ACTEL - for SIT Logic Board** |  | 11d | 2004-02-27 | 2004-03-12 |  |  |  | 60d |  |  |
| 611 | 1.6.6.3.1 | Burn Final SIT ACTEL Chip (at GSFC) |  | 1d | 2004-02-27 | 2004-02-27 |  |  |  | 60d | 0d | start no earlier than 2004-02-27 |
| 612 | 1.6.6.3.2 | Evaluate (Test) SIT Final ACTEL Chip |  | 10d | 2004-03-01 | 2004-03-12 | 611 |  |  | 60d | 46d |  |
| 613 | 1.6.6.4 | **TOF Boards** |  | 20d | 2004-02-17 | 2004-03-15 |  |  |  | 40d |  |  |
| 614 | 1.6.6.4.1 | Receive Analog and Digital TOF Boards (FM 1 & FM 2) | milestone | 0d | 2004-02-17 | 2004-02-17 |  |  |  | 40d | 0d | start no earlier than 2004-02-17 |
| 615 | 1.6.6.4.2 | **Test** |  | 20d | 2004-02-17 | 2004-03-15 |  |  |  | 40d |  |  |
| 616 | 1.6.6.4.2.1 | **FM 1** |  | 10d | 2004-02-17 | 2004-03-01 |  |  |  | 40d |  |  |
| 617 | 1.6.6.4.2.1.1 | FM 1 TOF Boards Functional Test |  | 10d | 2004-02-17 | 2004-03-01 | 614 |  |  | 40d | 0d |  |
| 618 | 1.6.6.4.2.2 | **FM 2** |  | 10d | 2004-03-02 | 2004-03-15 |  |  |  | 65d |  |  |
| 619 | 1.6.6.4.2.2.1 | FM 2 TOF Boards Functional Test |  | 10d | 2004-03-02 | 2004-03-15 | 614, 617 |  |  | 65d | 49d |  |
| 620 | 1.6.6.5 | **Energy Board** |  | 76d | 2003-11-10 A | 2004-03-02 |  | 57% | 32.42d | 74d |  |  |
| 621 | 1.6.6.5.1 | **Assembly** |  | 46d | 2003-11-10 A | 2004-01-16 |  | 76% | 11.02d | 89d |  |  |
| 622 | 1.6.6.5.1.1 | **FM 1** |  | 46d | 2003-11-10 A | 2004-01-16 |  | 76% | 11d | 54d |  |  |
| 623 | 1.6.6.5.1.1.1 | Assemble FM 1 Energy Board |  | 46d | 2003-11-10 A | 2004-01-16 |  | 76% | 11d | 54d | 0d | start no earlier than 2003-11-10 |
| 624 | 1.6.6.5.1.2 | **FM 2** |  | 46d | 2003-11-10 A | 2004-01-16 |  | 76% | 11.04d | 89d |  |  |
| 625 | 1.6.6.5.1.2.1 | Assemble FM 2 Energy Board |  | 46d | 2003-11-10 A | 2004-01-16 | 623SS | 76% | 11.04d | 89d | 15d |  |
| 626 | 1.6.6.5.2 | **Test** |  | 30d | 2004-01-20 | 2004-03-02 |  |  |  | 54d |  |  |
| 627 | 1.6.6.5.2.1 | **FM 1** |  | 15d | 2004-01-20 | 2004-02-09 |  |  |  | 54d |  |  |
| 628 | 1.6.6.5.2.1.1 | Bench Test/Calibration |  | 10d | 2004-01-20 | 2004-02-02 | 623 |  |  | 54d | 0d |  |
| 629 | 1.6.6.5.2.1.2 | Thermal |  | 3d | 2004-02-03 | 2004-02-05 | 628 |  |  | 54d | 0d |  |
| 630 | 1.6.6.5.2.1.3 | Voltage Margin |  | 2d | 2004-02-06 | 2004-02-09 | 629 |  |  | 54d | 0d |  |
| 631 | 1.6.6.5.2.2 | **FM 2** |  | 15d | 2004-02-10 | 2004-03-02 |  |  |  | 74d |  |  |
| 632 | 1.6.6.5.2.2.1 | FM 2 Energy Board Functional Test |  | 15d | 2004-02-10 | 2004-03-02 | 625, 630 |  |  | 74d | 58d |  |
| 633 | 1.6.6.6 | **Logic Board** |  | 168d | 2003-11-10 A | 2004-07-09 |  | 31% | 115.65d | 16d |  |  |
| 634 | 1.6.6.6.1 | **Design** |  | 3d | 2003-11-17 A | 2003-11-19 A |  | 100% |  |  |  |  |
| 635 | 1.6.6.6.1.1 | Layout new Logic Board Design |  | 3d | 2003-11-17 A | 2003-11-19 A |  | 100% |  |  |  | start no earlier than 2003-11-17 |

| ID | WBS | Task | Duration | Start | Finish | Predecessors | Complete | Remaining | Total slack | Free slack | Constraint |
| --- | --- | --- | --- | --- | --- | --- | --- | --- | --- | --- | --- |
| 636 | 1.6.6.6.2 | **Fabrication** | 10d | 2004-02-02 | 2004-02-13 |  |  |  | 14d |  |  |
| 637 | 1.6.6.6.2.1 | FM 1 & FM 2 Logic Board Fabrication | 10d | 2004-02-02 | 2004-02-13 | 635, 651 |  |  | 14d | 0d | start no earlier than 2004-02-02 |
| 638 | 1.6.6.6.3 | **Assembly** | 91d | 2004-03-02 | 2004-07-07 |  |  |  | 14d |  |  |
| 639 | 1.6.6.6.3.1 | **FM 1** | 58d | 2004-03-02 | 2004-05-20 |  |  |  | 14d |  |  |
| 640 | 1.6.6.6.3.1.1 | Assemble FM 1 Logic Board with ETU ACTELs | 11d | 2004-03-02 | 2004-03-16 | 653 |  |  | 14d | 0d |  |
| 641 | 1.6.6.6.3.1.2 | Disassembel FM 1 Logic Board with ETU ACTELs | 1d | 2004-05-17 | 2004-05-17 | 707 |  |  | 14d | 0d |  |
| 642 | 1.6.6.6.3.1.3 | Retrofit/Inspect FM 1 Flight ACTELs | 2d | 2004-05-18 | 2004-05-19 | 641, 612 |  |  | 14d | 0d |  |
| 643 | 1.6.6.6.3.1.4 | Reassemble FM 1 Logic Board with Flight ACTELs | 1d | 2004-05-20 | 2004-05-20 | 642 |  |  | 14d | 0d |  |
| 644 | 1.6.6.6.3.2 | **FM 2** | 91d | 2004-03-02 | 2004-07-07 |  |  |  | 16d |  |  |
| 645 | 1.6.6.6.3.2.1 | Assemble FM 2 Logic Board with ETU ACTELS | 11d | 2004-03-02 | 2004-03-16 | 653 |  |  | 49d | 15d |  |
| 646 | 1.6.6.6.3.2.2 | Disassemble FM 2 Logic Boards | 1d | 2004-07-02 | 2004-07-02 | 716, 641SS |  |  | 16d | 0d |  |
| 647 | 1.6.6.6.3.2.3 | Retrofit/Inspect Flight ACTELS | 2d | 2004-07-05 | 2004-07-06 | 646, 612 |  |  | 16d | 0d |  |
| 648 | 1.6.6.6.3.2.4 | Reassemble FM 2 Logic Boards | 1d | 2004-07-07 | 2004-07-07 | 647 |  |  | 16d | 0d |  |
| 649 | 1.6.6.6.4 | **Test** | 168d | 2003-11-10 A | 2004-07-09 |  | 42% | 98d | 16d |  |  |
| 650 | 1.6.6.6.4.1 | **ETU** | 55d | 2003-11-10 A | 2004-01-30 |  | 75% | 13.75d | 14d |  |  |
| 651 | 1.6.6.6.4.1.1 | Test New ETU Logic Board | 55d | 2003-11-10 A | 2004-01-30 |  | 75% | 13.75d | 14d | 0d | start no earlier than 2003-11-10 |
| 652 | 1.6.6.6.4.2 | **FM1 & FM 2** | 10d | 2004-02-17 | 2004-03-01 |  |  |  | 14d |  |  |
| 653 | 1.6.6.6.4.2.1 | Coupon Testing | 10d | 2004-02-17 | 2004-03-01 | 637 |  |  | 14d | 0d |  |
| 654 | 1.6.6.6.4.3 | **FM 1** | 49d | 2004-03-17 | 2004-05-24 |  |  |  | 14d |  |  |
| 655 | 1.6.6.6.4.3.1 | Functional Test of FM 1 Logic Board w/ETU ACTELS | 15d | 2004-03-17 | 2004-04-06 | 640 |  |  | 14d | 0d |  |
| 656 | 1.6.6.6.4.3.2 | Funtional Test of FM 1 Logic Board w/Flight ACTELS | 2d | 2004-05-21 | 2004-05-24 | 643 |  |  | 14d | 0d |  |
| 657 | 1.6.6.6.4.4 | **FM 2** | 67d | 2004-04-07 | 2004-07-09 |  |  |  | 16d |  |  |
| 658 | 1.6.6.6.4.4.1 | Functional Test of FM 2 Logic Board w/ETU ACTELS | 15d | 2004-04-07 | 2004-04-27 | 645, 655 |  |  | 34d | 18d |  |
| 659 | 1.6.6.6.4.4.2 | Functional Test of FM 2 Logic Board w/Flight ACTELS | 2d | 2004-07-08 | 2004-07-09 | 648 |  |  | 16d | 0d |  |

| ID | WBS | Task | Duration | Start | Finish | Predecessors | Complete | Remaining | Total slack | Free slack | Constraint |
| --- | --- | --- | --- | --- | --- | --- | --- | --- | --- | --- | --- |
| 660 | 1.6.6.7 | **Mother Board** | 50d | 2003-12-22 | 2004-03-04 |  |  |  | 42d |  |  |
| 661 | 1.6.6.7.1 | **Design** | 15d | 2003-12-22 | 2004-01-13 |  |  |  | 42d |  |  |
| 662 | 1.6.6.7.1.1 | **FM 1 & FM 2** | 15d | 2003-12-22 | 2004-01-13 |  |  |  | 42d |  |  |
| 663 | 1.6.6.7.1.1.1 | Finalize Mother Board Layout | 15d | 2003-12-22 | 2004-01-13 |  |  |  | 42d | 0d | start no earlier than 2003-12-22 |
| 664 | 1.6.6.7.2 | **Fabrication** | 15d | 2004-01-14 | 2004-02-04 |  |  |  | 42d |  |  |
| 665 | 1.6.6.7.2.1 | **FM 1 & FM 2** | 15d | 2004-01-14 | 2004-02-04 |  |  |  | 42d |  |  |
| 666 | 1.6.6.7.2.1.1 | Fabricate FM 1 & FM 2 Mother Boards | 15d | 2004-01-14 | 2004-02-04 | 663 |  |  | 42d | 0d |  |
| 667 | 1.6.6.7.3 | **Assembly** | 10d | 2004-02-05 | 2004-02-19 |  |  |  | 42d |  |  |
| 668 | 1.6.6.7.3.1 | Assemble FM 1 Mother Board | 10d | 2004-02-05 | 2004-02-19 | 666 |  |  | 42d | 0d |  |
| 669 | 1.6.6.7.3.2 | Assemble FM 2 Mother Board | 10d | 2004-02-05 | 2004-02-19 | 668SS |  |  | 64d | 5d |  |
| 670 | 1.6.6.7.4 | **Test** | 20d | 2004-02-05 | 2004-03-04 |  |  |  | 52d |  |  |
| 671 | 1.6.6.7.4.1 | **FM 1 & FM 2** | 15d | 2004-02-05 | 2004-02-26 |  |  |  | 421d |  |  |
| 672 | 1.6.6.7.4.1.1 | Coupon Testing of Mother Boards | 15d | 2004-02-05 | 2004-02-26 | 666 |  |  | 421d |  |  |
| 673 | 1.6.6.7.4.2 | **FM 1** | 5d | 2004-02-20 | 2004-02-26 |  |  |  | 42d |  |  |
| 674 | 1.6.6.7.4.2.1 | Functional Test FM 1 Mother Board | 5d | 2004-02-20 | 2004-02-26 | 668 |  |  | 42d | 0d |  |
| 675 | 1.6.6.7.4.3 | **FM 2** | 5d | 2004-02-27 | 2004-03-04 |  |  |  | 59d |  |  |
| 676 | 1.6.6.7.4.3.1 | Functional Test FM 2 Mother Board | 5d | 2004-02-27 | 2004-03-04 | 669, 674 |  |  | 59d | 15d |  |
| 677 | 1.6.6.8 | **HVPS** | 62d | 2004-01-12 | 2004-04-08 |  |  |  | 44d |  |  |
| 678 | 1.6.6.8.1 | **Test** | 62d | 2004-01-12 | 2004-04-08 |  |  |  | 44d |  |  |
| 679 | 1.6.6.8.1.1 | **FM 1** | 10d | 2004-01-12 | 2004-01-26 |  |  |  | 61d |  |  |
| 680 | 1.6.6.8.1.1.1 | Functional Test SIT FM 1 HVPS | 10d | 2004-01-12 | 2004-01-26 | 74 |  |  | 61d | 28d | start no earlier than 2004-01-12 |
| 681 | 1.6.6.8.1.2 | **FM 2** | 10d | 2004-03-26 | 2004-04-08 |  |  |  | 44d |  |  |
| 682 | 1.6.6.8.1.2.1 | Functional Test SIT FM 2 HVPS | 10d | 2004-03-26 | 2004-04-08 | 80, 676 |  |  | 44d | 28d |  |
| 683 | 1.6.6.9 | **Flight Software** | 210d | 2003-06-02 A | 2004-04-01 |  | 70% | 63d | 44d |  |  |
| 684 | 1.6.6.9.1 | **Test** | 210d | 2003-06-02 A | 2004-04-01 |  | 70% | 63d | 44d |  |  |
| 685 | 1.6.6.9.1.1 | **FM 1 & FM 2** | 210d | 2003-06-02 A | 2004-04-01 |  | 70% | 63d | 44d |  |  |
| 686 | 1.6.6.9.1.1.1 | Validate SIT On-Board Code | 210d | 2003-06-02 A | 2004-04-01 |  | 70% | 63d | 44d | 30d | start no earlier than 2003-06-02 |

| ID | WBS | Task | Duration | Start | Finish | Predecessors | Total slack | Free slack |
| --- | --- | --- | --- | --- | --- | --- | --- | --- |
| 687 | 1.6.6.10 | **Integration & Test (using ETU Telescope for FM 1)** | 98d | 2004-03-08 | 2004-07-22 |  | 16d |  |
| 688 | 1.6.6.10.1 | **FM 1 (Flight Telescope)** | 12d | 2004-05-25 | 2004-06-10 |  | 14d |  |
| 689 | 1.6.6.10.1.1 | Disassemble SIT FM 1 | 1d | 2004-05-25 | 2004-05-25 | 656 | 14d | 0d |
| 690 | 1.6.6.10.1.2 | Conformal Coat SIT FM 1 Boards | 2d | 2004-05-26 | 2004-05-27 | 689 | 14d | 0d |
| 691 | 1.6.6.10.1.3 | Reassemble SIT FM 1 with Flight Telescope | 1d | 2004-05-28 | 2004-05-28 | 690, 408 | 14d | 0d |
| 692 | 1.6.6.10.1.4 | Bench Calibration SIT FM 1 w/Flight Telescope | 3d | 2004-06-01 | 2004-06-03 | 691 | 14d | 0d |
| 693 | 1.6.6.10.1.5 | Vacuum Test SIT FM 1 w/Flight Telescope | 5d | 2004-06-04 | 2004-06-10 | 692 | 14d | 0d |
| 694 | 1.6.6.10.2 | **FM 2** | 9d | 2004-07-12 | 2004-07-22 |  | 16d |  |
| 695 | 1.6.6.10.2.1 | Disassemble SIT FM 2 | 1d | 2004-07-12 | 2004-07-12 | 659 | 16d | 0d |
| 696 | 1.6.6.10.2.2 | Conformal Coat SIT FM 2 Boards | 2d | 2004-07-13 | 2004-07-14 | 695 | 16d | 0d |
| 697 | 1.6.6.10.2.3 | Reassemble SIT FM 2 | 1d | 2004-07-15 | 2004-07-15 | 696 | 16d | 0d |
| 698 | 1.6.6.10.2.4 | Post-Coat Retest SIT FM 2 | 5d | 2004-07-16 | 2004-07-22 | 697 | 16d | 0d |
| 699 | 1.6.6.10.3 | **FM 1 (ETU Telescope)** | 50d | 2004-03-08 | 2004-05-14 |  | 14d |  |
| 700 | 1.6.6.10.3.1 | Integrate SIT FM 1 HVPS and SIT ETU Telescope Without Electronics | 3d | 2004-03-08 | 2004-03-10 | 680, 605 | 33d | 19d |
| 701 | 1.6.6.10.3.2 | Integrate Electronics to SIT ETU Telescope | 2d | 2004-04-07 | 2004-04-08 | 655, 617, 674, 630, 700 | 14d | 0d |
| 702 | 1.6.6.10.3.3 | SIT FM 1 Debug | 5d | 2004-04-09 | 2004-04-15 | 701 | 14d | 0d |
| 703 | 1.6.6.10.3.4 | SIT FM 1 Bench Test | 5d | 2004-04-16 | 2004-04-22 | 702 | 14d | 0d |
| 704 | 1.6.6.10.3.5 | SIT FM 1 Alpha TEST | 5d | 2004-04-23 | 2004-04-29 | 703 | 14d | 0d |
| 705 | 1.6.6.10.3.6 | SIT FM 1 Noise Removal | 5d | 2004-04-30 | 2004-05-06 | 704 | 14d | 0d |
| 706 | 1.6.6.10.3.7 | SIT FM 1 Thermal Test | 5d | 2004-05-07 | 2004-05-13 | 705 | 14d | 0d |
| 707 | 1.6.6.10.3.8 | SIT FM 1 Functional Test | 1d | 2004-05-14 | 2004-05-14 | 706, 686 | 14d | 0d |
| 708 | 1.6.6.10.4 | **FM 2** | 31d | 2004-05-19 | 2004-07-01 |  | 16d |  |
| 709 | 1.6.6.10.4.1 | Integrate SIT FM 2 HVPS and SIT FM 2 Telescope Without Electronics | 3d | 2004-05-19 | 2004-05-21 | 682, 609, 408 | 16d | 0d |
| 710 | 1.6.6.10.4.2 | Integrate Electronics to SIT FM 2 Telescope | 2d | 2004-05-24 | 2004-05-25 | 658, 619, 676, 632, 709 | 16d | 0d |
| 711 | 1.6.6.10.4.3 | SIT FM 2 Debug | 5d | 2004-05-26 | 2004-06-02 | 710 | 16d | 0d |
| 712 | 1.6.6.10.4.4 | SIT FM 2 Bench Test | 5d | 2004-06-03 | 2004-06-09 | 711 | 16d | 0d |
| 713 | 1.6.6.10.4.5 | SIT FM 2 Alpha Test | 5d | 2004-06-10 | 2004-06-16 | 712 | 16d | 0d |
| 714 | 1.6.6.10.4.6 | SIT FM 2 Noise Removal | 5d | 2004-06-17 | 2004-06-23 | 713, 705 | 16d | 0d |
| 715 | 1.6.6.10.4.7 | SIT FM 2 Thermal Test | 5d | 2004-06-24 | 2004-06-30 | 714 | 16d | 0d |
| 716 | 1.6.6.10.4.8 | SIT FM 2 Functional Test | 1d | 2004-07-01 | 2004-07-01 | 715 | 16d | 0d |

| ID | WBS | Task | Duration | Start | Finish | Predecessors | Complete | Remaining | Total slack | Free slack | Constraint |
| --- | --- | --- | --- | --- | --- | --- | --- | --- | --- | --- | --- |
| 717 | 1.6.6.11 | **Environmental Testing at GSFC (FM 1)** | 34d | 2004-07-08 | 2004-08-24 |  |  |  | 29d |  |  |
| 718 | 1.6.6.11.1 | SIT FM 1 Vibration and Acoustics | 10d | 2004-07-08 | 2004-07-21 | 595 |  |  | 29d | 0d |  |
| 719 | 1.6.6.11.2 | Functional Test | 1d | 2004-07-22 | 2004-07-22 | 718 |  |  | 29d | 0d |  |
| 720 | 1.6.6.11.3 | SIT FM 1 Thermal Balance | 5d | 2004-07-23 | 2004-07-29 | 719 |  |  | 29d | 0d |  |
| 721 | 1.6.6.11.4 | SIT FM 1 Thermal Vac | 10d | 2004-07-30 | 2004-08-12 | 720 |  |  | 29d | 0d |  |
| 722 | 1.6.6.11.5 | Disassemble SIT Instruments | 2d | 2004-08-13 | 2004-08-16 | 721 |  |  | 29d | 0d |  |
| 723 | 1.6.6.11.6 | Bake Out | 3d | 2004-08-17 | 2004-08-19 | 722 |  |  | 29d | 0d |  |
| 724 | 1.6.6.11.7 | Reassemble Instruments | 2d | 2004-08-20 | 2004-08-23 | 723 |  |  | 29d | 0d |  |
| 725 | 1.6.6.11.8 | Functional Test | 1d | 2004-08-24 | 2004-08-24 | 724 |  |  | 29d | 0d |  |
| 726 | 1.6.6.12 | **Environmental Testing at GSFC (FM 2)** | 34d | 2004-08-16 | 2004-10-01 |  |  |  | 16d |  |  |
| 727 | 1.6.6.12.1 | SIT FM 2 Vibration and Acoustics | 10d | 2004-08-16 | 2004-08-27 | 598 |  |  | 16d | 0d |  |
| 728 | 1.6.6.12.2 | Functional Test | 1d | 2004-08-30 | 2004-08-30 | 727 |  |  | 16d | 0d |  |
| 729 | 1.6.6.12.3 | SIT FM 2 Thermal Balance | 5d | 2004-08-31 | 2004-09-07 | 728 |  |  | 16d | 0d |  |
| 730 | 1.6.6.12.4 | SIT FM 2 Thermal Vac | 10d | 2004-09-08 | 2004-09-21 | 729 |  |  | 16d | 0d |  |
| 731 | 1.6.6.12.5 | Disassemble SIT Instruments | 2d | 2004-09-22 | 2004-09-23 | 730 |  |  | 16d | 0d |  |
| 732 | 1.6.6.12.6 | Bake Out | 3d | 2004-09-24 | 2004-09-28 | 731 |  |  | 16d | 0d |  |
| 733 | 1.6.6.12.7 | Reassemble Instruments | 2d | 2004-09-29 | 2004-09-30 | 732 |  |  | 16d | 0d |  |
| 734 | 1.6.6.12.8 | Functional Test | 1d | 2004-10-01 | 2004-10-01 | 733 |  |  | 16d | 0d |  |
| 735 | 1.6.6.13 | **Emulators/Simulators/GSE** | 214d | 2003-12-17 A | 2004-10-20 |  | 9% | 194.55d | 255d |  |  |
| 736 | 1.6.6.13.1 | **Simulators** | 80d | 2003-12-17 A | 2004-04-12 |  | 13% | 70d | 389d |  |  |
| 737 | 1.6.6.13.1.1 | Labview CPU Ready | 80d | 2003-12-17 A | 2004-04-12 |  | 13% | 70d | 389d | 0d | start no earlier than 2003-12-17 |
| 738 | 1.6.6.13.1.2 | Test Simulator | 80d | 2003-12-17 A | 2004-04-12 | 737SS | 13% | 70d | 389d |  |  |
| 739 | 1.6.6.13.2 | **GSE** | 60d | 2004-07-27 | 2004-10-20 |  |  |  | 255d |  |  |
| 740 | 1.6.6.13.2.1 | Pulse Generator | 60d | 2004-07-27 | 2004-10-20 | 594, 597 |  |  | 255d |  |  |

| ID | WBS | Task | Duration | Start | Finish | Predecessors | Complete | Remaining | Total slack | Free slack | Constraint |
| --- | --- | --- | --- | --- | --- | --- | --- | --- | --- | --- | --- |
| 741 | 1.6.7 | **SEP Suite I&T - CIT** | 305d | 2003-08-01 A | 2004-10-15 |  | 31% | 209.01d | 258d |  |  |
| 742 | 1.6.7.1 | **ETU** | 5d | 2004-02-23 | 2004-02-27 |  |  |  | 420d |  |  |
| 743 | 1.6.7.1.1 | Complete Integration/Test of SEP Central EM with Sensors | 5d | 2004-02-23 | 2004-02-27 |  |  |  | 420d |  | start no earlier than 2004-02-23 |
| 744 | 1.6.7.2 | **FM 1 & FM 2** | 154d | 2004-03-08 | 2004-10-12 |  |  |  | 74d |  |  |
| 745 | 1.6.7.2.1 | Software Support For SEP Integration | 115d | 2004-04-30 | 2004-10-12 | 756SS |  |  | 261d |  |  |
| 746 | 1.6.7.2.2 | Generate SEPT integration & test procedure | 5d | 2004-03-08 | 2004-03-12 | 757FS-10d |  |  | 75d | 39d |  |
| 747 | 1.6.7.2.3 | Generate LET integration & test procedure | 5d | 2004-04-26 | 2004-04-30 | 758FS-10d |  |  | 41d | 19d |  |
| 748 | 1.6.7.2.4 | Generate HET integration & test procedure | 5d | 2004-05-19 | 2004-05-25 | 760FS-10d |  |  | 25d | 5d |  |
| 749 | 1.6.7.2.5 | Generate SIT integration & test procedure | 5d | 2004-06-02 | 2004-06-08 | 764FS-10d |  |  | 19d | 5d |  |
| 750 | 1.6.7.2.6 | Generate SEP system test procedure | 5d | 2004-06-03 | 2004-06-09 | 765FS-10d |  |  | 19d | 5d |  |
| 751 | 1.6.7.2.7 | Software Support For Acceptance Testing of SEP Instruments | 27d | 2004-06-17 | 2004-07-23 | 766SS |  |  | 316d |  |  |
| 752 | 1.6.7.2.8 | Generate SEP-IDPU integration procedure | 5d | 2004-05-20 | 2004-05-26 | 761FS-10d |  |  | 21d | 0d |  |
| 753 | 1.6.7.2.9 | Generate SEP-IDPU test procedure | 5d | 2004-05-27 | 2004-06-03 | 752 |  |  | 21d | 1d |  |
| 754 | 1.6.7.2.10 | Software Support of SEP Accelerator Tests | 20d | 2004-06-22 | 2004-07-19 | 797SS-10d |  |  | 320d |  |  |
| 755 | 1.6.7.3 | **FM 1** | 66d | 2004-03-19 | 2004-06-21 |  |  |  | 14d |  |  |
| 756 | 1.6.7.3.1 | Integrate/test SEP Central FM 1 | 5d | 2004-04-30 | 2004-05-06 | 423, 425, 384 |  |  | 36d | 0d |  |
| 757 | 1.6.7.3.2 | Receive & inspect SEPT FM 1 | 1d | 2004-03-19 | 2004-03-19 | 523, 524 |  |  | 70d | 0d |  |
| 758 | 1.6.7.3.3 | Integrate & test SEPT FM 1 | 1d | 2004-05-07 | 2004-05-07 | 746, 756, 757 |  |  | 36d | 0d |  |
| 759 | 1.6.7.3.4 | Integrate & test LET FM 1 | 1d | 2004-05-28 | 2004-05-28 | 747, 758, 500, 502 |  |  | 22d | 2d |  |
| 760 | 1.6.7.3.5 | Receive & inspect HET FM 1 | 1d | 2004-06-02 | 2004-06-02 | 453, 455 |  |  | 20d | 0d |  |
| 761 | 1.6.7.3.6 | Integrate & test HET FM 1 | 1d | 2004-06-03 | 2004-06-03 | 748, 759, 760 |  |  | 20d | 0d |  |
| 762 | 1.6.7.3.7 | Integrate SEP FM 1 - IDPU FM 1 | 1d | 2004-06-04 | 2004-06-04 | 752, 761 |  |  | 20d | 0d |  |
| 763 | 1.6.7.3.8 | Test SEP FM 1 - IDPU FM 1 | 1d | 2004-06-07 | 2004-06-07 | 753, 762, 358 |  |  | 20d | 6d |  |
| 764 | 1.6.7.3.9 | Receive & inspect SIT FM 1 | 1d | 2004-06-15 | 2004-06-15 | 594 |  |  | 14d | 0d |  |
| 765 | 1.6.7.3.10 | Integrate & test SIT FM 1 | 1d | 2004-06-16 | 2004-06-16 | 749, 761, 764, 763 |  |  | 14d | 0d |  |
| 766 | 1.6.7.3.11 | SEP system test FM 1 | 3d | 2004-06-17 | 2004-06-21 | 750, 765, 420 |  |  | 14d | 0d |  |

| ID | WBS | Task | Duration | Start | Finish | Predecessors | Total slack | Free slack | Constraint |
| --- | --- | --- | --- | --- | --- | --- | --- | --- | --- |
| 767 | 1.6.7.4 | **FM 2** | 102d | 2004-03-15 | 2004-08-04 |  | 14d |  |  |
| 768 | 1.6.7.4.1 | Integrate/testSEP Central FM 2 | 5d | 2004-04-30 | 2004-05-06 | 424, 425, 384 | 50d | 0d |  |
| 769 | 1.6.7.4.2 | Receive & inspect SEPT FM 2 | 1d | 2004-03-15 | 2004-03-15 | 526, 527 | 88d | 38d |  |
| 770 | 1.6.7.4.3 | Integrate & test SEPT FM 2 | 1d | 2004-05-07 | 2004-05-07 | 746, 768, 769 | 50d | 14d |  |
| 771 | 1.6.7.4.4 | Integrate & test LET FM 2 | 1d | 2004-05-28 | 2004-05-28 | 747, 770, 501, 502 | 36d | 17d |  |
| 772 | 1.6.7.4.5 | Receive & inspect HET FM 2 | 1d | 2004-06-23 | 2004-06-23 | 454 | 19d | 0d |  |
| 773 | 1.6.7.4.6 | Integrate & test HET FM 2 | 1d | 2004-06-24 | 2004-06-24 | 748, 771, 772 | 19d | 0d |  |
| 774 | 1.6.7.4.7 | Integrate SEP FM 2 - IDPU FM 2 | 1d | 2004-06-25 | 2004-06-25 | 752, 773, 165 | 19d | 0d |  |
| 775 | 1.6.7.4.8 | Test SEP FM 2 - IDPU FM 2 | 1d | 2004-06-28 | 2004-06-28 | 753, 774 | 19d | 5d |  |
| 776 | 1.6.7.4.9 | Receive & inspect SIT FM 2 | 1d | 2004-07-27 | 2004-07-27 | 597 | 16d | 2d |  |
| 777 | 1.6.7.4.10 | Integrate & test SIT FM 2 | 1d | 2004-07-30 | 2004-07-30 | 749, 776, 791 | 14d | 0d |  |
| 778 | 1.6.7.4.11 | SEP FM 2 system test | 3d | 2004-08-02 | 2004-08-04 | 750, 777 | 14d | 0d |  |
| 779 | 1.6.7.5 | **Environmental Test (at JPL)** | 88d | 2004-05-17 | 2004-09-17 |  | 28d |  |  |
| 780 | 1.6.7.5.1 | Generate Environmental Test Procedures | 15d | 2004-05-17 | 2004-06-07 |  | 46d | 28d | start no earlier than 2004-05-17 |
| 781 | 1.6.7.5.2 | Manufacture test cables (JPL) | 20d | 2004-06-01 | 2004-06-28 |  | 31d | 13d | start no earlier than 2004-06-01 |
| 782 | 1.6.7.5.3 | **FM 1** | 45d | 2004-07-16 | 2004-09-17 |  | 14d |  |  |
| 783 | 1.6.7.5.3.1 | FM 1 LET/HET/SEP Central Vibration/Acoustics Test | 10d | 2004-07-16 | 2004-07-29 | 18FS+3d, 780, 781, 797FS+3d | 18d | 0d |  |
| 784 | 1.6.7.5.3.2 | FM 1 LET/HET/SEP Central Thermal Balance Test | 5d | 2004-07-30 | 2004-08-05 | 783 | 18d | 0d |  |
| 785 | 1.6.7.5.3.3 | FM 1 LET/HET/SEP Central T/V Test | 15d | 2004-08-12 | 2004-09-01 | 784, 790 | 14d | 0d |  |
| 786 | 1.6.7.5.3.4 | Evaluate SEP performance | 10d | 2004-09-02 | 2004-09-16 | 785 | 14d | 0d |  |
| 787 | 1.6.7.5.3.5 | Generate test reports | 11d | 2004-09-02 | 2004-09-17 | 786SS | 14d |  | finish no later than 2004-10-07 |
| 788 | 1.6.7.5.3.6 | Bakeout Clean SEP exterior & prepare for delivery | 3d | 2004-09-02 | 2004-09-07 | 785 | 21d | 0d |  |
| 789 | 1.6.7.5.4 | **FM 2** | 45d | 2004-07-16 | 2004-09-17 |  | 14d |  |  |
| 790 | 1.6.7.5.4.1 | FM 2 EMI/EMC Test at CalTech | 5d | 2004-08-05 | 2004-08-11 | 778 | 14d | 0d |  |
| 791 | 1.6.7.5.4.2 | FM 2 LET/HET/SEP Central Vibration/Acoustics Test | 10d | 2004-07-16 | 2004-07-29 | 798FS+3d | 14d | 0d |  |
| 792 | 1.6.7.5.4.3 | FM 2 LET/HET/SEP Central T/V Test | 15d | 2004-08-12 | 2004-09-01 | 790 | 28d | 0d |  |
| 793 | 1.6.7.5.4.4 | Evaluate SEP performance | 10d | 2004-09-02 | 2004-09-16 | 792 | 28d | 0d |  |
| 794 | 1.6.7.5.4.5 | Generate test reports | 11d | 2004-09-02 | 2004-09-17 | 793SS | 28d |  | finish no later than 2004-10-28 |
| 795 | 1.6.7.5.4.6 | Bakeout Clean SEP exterior & prepare for delivery | 3d | 2004-09-02 | 2004-09-07 | 792 | 35d | 0d |  |

| ID | WBS | Task | Duration | Start | Finish | Predecessors | Complete | Remaining | Total slack | Free slack | Constraint |
| --- | --- | --- | --- | --- | --- | --- | --- | --- | --- | --- | --- |
| 796 | 1.6.7.6 | **Accelerator Test (at MSU)** | 5d | 2004-07-06 | 2004-07-12 |  |  |  | 14d |  |  |
| 797 | 1.6.7.6.1 | FM 1 LET/SEP Cen end-to-end test at Accelerator | 5d | 2004-07-06 | 2004-07-12 | 803, 18, 415 |  |  | 14d | 0d |  |
| 798 | 1.6.7.6.2 | FM 2 LET/SEP Cen end-to-end test at Accelerator | 5d | 2004-07-06 | 2004-07-12 | 797SS, 775 |  |  | 14d | 0d |  |
| 799 | 1.6.7.7 | **GSE** | 305d | 2003-08-01 A | 2004-10-15 |  | 55% | 137.48d | 258d |  |  |
| 800 | 1.6.7.7.1 | **End-to-End Test Equipment** | 218d | 2003-08-11 A | 2004-06-22 |  | 84% | 35.3d | 23d |  |  |
| 801 | 1.6.7.7.1.1 | Design | 192d | 2003-08-11 A | 2004-05-14 |  | 95% | 9.3d | 23d | 0d | start no earlier than 2003-08-11 |
| 802 | 1.6.7.7.1.2 | Assemble | 21d | 2004-05-17 | 2004-06-15 | 801 |  |  | 23d | 0d |  |
| 803 | 1.6.7.7.1.3 | Test | 5d | 2004-06-16 | 2004-06-22 | 802 |  |  | 23d | 9d |  |
| 804 | 1.6.7.7.2 | **GSE software** | 305d | 2003-08-01 A | 2004-10-15 |  | 34% | 200.66d | 258d |  |  |
| 805 | 1.6.7.7.2.1 | Build GSE software release 2 | 157d | 2003-08-01 A | 2004-03-18 |  | 66% | 53d | 281d | 1d | start no earlier than 2003-08-01 |
| 806 | 1.6.7.7.2.2 | Write user's guide | 8d | 2004-03-22 | 2004-03-31 | 805 |  |  | 280d | 22d | start no earlier than 2004-03-22 |
| 807 | 1.6.7.7.2.3 | Build GSE software release 3 | 117d | 2004-05-03 | 2004-10-15 | 806 |  |  | 258d | 0d | start no earlier than 2004-05-03 |
| 808 | 1.6.7.7.2.4 | Write user's guide supplement | 22d | 2004-09-15 | 2004-10-15 | 807FS-22d |  |  | 258d |  |  |
| 809 | 1.7 | **SWEA and SIT Refurbishment (after S/C Environmental Testing)** | 14d | 2005-09-27 | 2005-10-14 |  |  |  | 0d |  |  |
| 810 | 1.7.1 | Ship SWEA FM 1 to UCB | 3d | 2005-09-27 | 2005-09-29 |  |  |  | 0d |  | start no earlier than 2005-09-27 |
| 811 | 1.7.2 | Ship (Hand Carry) SIT FM 1 to UMD | 1d | 2005-09-27 | 2005-09-27 |  |  |  | 2d | 0d | start no earlier than 2005-09-27 |
| 812 | 1.7.3 | Ship SWEA FM 2 to UCB | 3d | 2005-10-04 | 2005-10-06 |  |  |  | 1d | 0d | start no earlier than 2005-10-04 |
| 813 | 1.7.4 | Ship (Hand Carry) SIT FM 2 to UMD | 1d | 2005-10-04 | 2005-10-04 |  |  |  | 3d | 0d | start no earlier than 2005-10-04 |
| 814 | 1.7.5 | Vacuum Testing of SWEA FM 1 @ UCB | 5d | 2005-09-30 | 2005-10-06 | 810 |  |  | 0d |  |  |
| 815 | 1.7.6 | Vacuum Testing of SIT FM 1 @ UMD | 5d | 2005-09-28 | 2005-10-04 | 811 |  |  | 2d | 0d |  |
| 816 | 1.7.7 | Vacuum Testing of SWEA FM 2 @ UCB | 5d | 2005-10-07 | 2005-10-13 | 812 |  |  | 1d |  |  |
| 817 | 1.7.8 | Vacuum Testing of SIT FM 2 @ UMD | 5d | 2005-10-05 | 2005-10-11 | 813 |  |  | 3d |  |  |
| 818 | 1.7.9 | Ship SWEA FM 1 & 2 to Launch Site for Re-integration to S/C | 3d | 2005-10-07 | 2005-10-11 | 814 |  |  | 0d |  |  |
| 819 | 1.7.10 | Ship SIT FM 1 & 2 to Launch Site for Re-integration to S/C | 3d | 2005-10-05 | 2005-10-07 | 815 |  |  | 2d |  |  |
| 820 | 1.7.11 | Reintegration of SWEA and SIT to S/C (at Launch Site) | 3d | 2005-10-12 | 2005-10-14 | 818, 819 |  |  | 0d |  | finish no later than 2005-11-18 |

Notes:
- 796: The Accelerator Test Date is still TBD. The actually testing date will depend on availability of the facility at MSU and the readiness of our flight hardware. The date currently reflected in the schedule is therefore subject to change as required.
